# HABILITACIÓN DE ACCESOS Y PLATAFORMAS, Y MOVIMIENTO DE TIERRAS II PARTE - CUENCA HUAURA

Schedule from Primavera P6, 2023-03-17 to 2024-05-31, data date 2023-03-17.

## Calendars

- Calendario ARCC: Mon-Sun 07:00-17:00.

## Schedule

| ID | WBS | Activity | Type | Duration | Start | Finish | Predecessors | Total float | Free float |
| --- | --- | --- | --- | --- | --- | --- | --- | --- | --- |
| 1 |  | Hito 1: Inicio - KOM | milestone | 0d | 2023-03-17 | 2023-03-17 |  | 0d |  |
| 2 |  | Hito 2: Inicio de Habilitación y Mejoramiento de accesos | milestone | 0d | 2023-04-01 | 2023-04-01 | 1 SS+15d | 0d |  |
| 3 |  | Hito: Inicio de Paquete 2 | milestone | 0d | 2023-04-02 | 2023-04-02 | 2 SS+1d | 0d |  |
| 4 |  | Hito: Inicio de Paquete 3 | milestone | 0d | 2023-07-03 | 2023-07-03 | 3 SS+92d | 0d |  |
| 762 |  | Hito: Fin de proyecto | milestone | 0d | 2024-05-31 | 2024-05-31 | 7 FF, 11 FF | 0d |  |
|  | 5 | **Obras Provisionales** |  |  | 2023-04-02 | 2024-05-31 |  |  |  |
| 10 |  | Desbroce en areas auxiliares | resource dependent | 13d | 2023-04-02 | 2023-04-14 | 3 SS | 324d | 0d |
| 11 |  | Mantenimiento de caminos de acceso | resource dependent | 426d | 2023-04-02 | 2024-05-31 | 3 SS | 0d |  |
| 6 |  | Campamento Provisional de Obra | resource dependent | 30d | 2023-04-02 | 2023-05-01 | 3 SS | 396d |  |
| 7 |  | Movilización y Desmovilización de maquinaria pesada | resource dependent | 426d | 2023-04-02 | 2024-05-31 | 3 SS | 0d |  |
| 12 |  | Habilitacion de plataformas | resource dependent | 24d | 2023-04-07 | 2023-04-30 | 10 FS-8d | 381d | 0d |
| 8 |  | Mejoramiento y Habilitación de caminos de acceso | resource dependent | 97d | 2023-04-07 | 2023-07-12 | 10 FS-8d | 324d |  |
| 13 |  | Tubería HDPE corrugada ø=450mm, para caminos de acceso (o similar) | resource dependent | 2d | 2023-04-15 | 2023-04-16 | 10 | 381d | 0d |
| 9 |  | Limpieza manual de material vegetal y de residuos | resource dependent | 33d | 2023-04-15 | 2023-05-17 | 10 | 380d |  |
| 14 |  | Tubería HDPE Corrugada Ø=630mm, para caminos de acceso (o similar) | resource dependent | 2d | 2023-04-17 | 2023-04-18 | 13 | 381d | 0d |
| 15 |  | Tubería HDPE corrugada ø=900mm, para caminos de acceso (o similar) | resource dependent | 5d | 2023-04-19 | 2023-04-23 | 14 | 381d | 0d |
| 16 |  | Tubería HDPE Corrugada Ø=1000mm, para caminos de acceso (o similar) | resource dependent | 9d | 2023-04-24 | 2023-05-02 | 15 | 381d | 0d |
| 21 |  | Encofrado y desencofrado para proteccion de estructuras | resource dependent | 13d | 2023-04-30 | 2023-05-12 | 12 FS-1d | 381d | 0d |
| 20 |  | Acero corrugado fy= 4200 kg/cm2 grado 60 para proteccion de estructuras | resource dependent | 12d | 2023-05-01 | 2023-05-12 | 12 | 381d | 0d |
| 17 |  | Tubería HDPE Corrugada Ø=1200mm, para caminos de acceso (o similar) | resource dependent | 11d | 2023-05-03 | 2023-05-13 | 16 | 381d | 0d |
| 18 |  | Concreto ciclopeo f'c=175 kg/cm2 + 30% P.G. para proteccion de estructuras | resource dependent | 3d | 2023-05-10 | 2023-05-12 | 17 FS-4d | 381d | 0d |
| 19 |  | Concreto estructural (f'c=280 kg/cm2) para proteccion de estructuras | resource dependent | 4d | 2023-05-13 | 2023-05-16 | 20, 21, 17 FS-1d, 18 | 381d |  |
|  | 6 | **Topografía** |  |  | 2023-04-02 | 2023-05-01 |  |  |  |
| 23 |  | Trazo y replanteo inicial | resource dependent | 30d | 2023-04-02 | 2023-05-01 | 3 SS | 0d |  |

Notes:
- 1: Expenses: Hito 1: Inicio - KOM - (cost) 0
- 2: Expenses: Hito 2: Inicio de Habilitación y Mejoramiento de accesos - (cost) 0
- 3: Expenses: Hito: Inicio de Paquete 2 - (cost) 0
- 4: Expenses: Hito: Inicio de Paquete 3 - (cost) 0
- 762: Expenses: Hito: Fin de proyecto - (cost) 0

| ID | WBS | Activity | Type | Duration | Start | Finish | Predecessors | Total float | Free float |
| --- | --- | --- | --- | --- | --- | --- | --- | --- | --- |
|  | 7 | **FRENTE 1** |  |  | 2023-04-22 | 2024-05-31 |  |  |  |
|  | 1 | **DIQUE DI-PR-25-I (PAQUETE 2)** |  |  | 2023-04-22 | 2023-06-01 |  |  |  |
|  | 1 | **Excavaciones** |  |  | 2023-04-22 | 2023-05-03 |  |  |  |
| 27 |  | Desbroce | resource dependent | 2d | 2023-04-22 | 2023-04-23 | 3 SS+20d, 23 FS-10d | 0d |  |
| 32 |  | Conformación de material excedente en DMO | resource dependent | 2d | 2023-04-22 | 2023-04-23 | 48 FS-2d | 404d |  |
| 28 |  | Excavación de cimentación | resource dependent | 4d | 2023-04-24 | 2023-04-27 | 27 | 0d |  |
| 31 |  | Conformación de material excedente en DME | resource dependent | 3d | 2023-04-24 | 2023-04-26 | 49 FS-10d | 401d |  |
| 29 |  | Perfilado y conformación de Plataforma de fundación | resource dependent | 2d | 2023-04-28 | 2023-04-29 | 28 | 0d |  |
| 30 |  | Excavación de uña | resource dependent | 4d | 2023-04-28 | 2023-05-01 | 28 | 0d |  |
| 33 |  | Excavación Localizada - Sobreexcavación | resource dependent | 2d | 2023-05-02 | 2023-05-03 | 30 | 0d |  |
|  | 2 | **Rellenos** |  |  | 2023-04-30 | 2023-06-01 |  |  |  |
| 35 |  | Relleno con material granular (incluye extracción de material, zarandeo y combinación de material) | resource dependent | 6d | 2023-04-30 | 2023-05-05 | 29 | 0d |  |
| 38 |  | Perfilado de Talud del dique | resource dependent | 2d | 2023-05-06 | 2023-05-07 | 35 | 0d |  |
| 39 |  | Relleno con material seleccionado (incluye extracción de material, zarandeo y combinación de material) en sobreexcavación | resource dependent | 3d | 2023-05-06 | 2023-05-08 | 35 | 387d | 0d |
| 40 |  | Grava para Drenaje | resource dependent | 2d | 2023-05-09 | 2023-05-10 | 39 | 387d |  |
| 36 |  | Relleno sin compactar | resource dependent | 2d | 2023-05-29 | 2023-05-30 | 46 FS-2d | 365d | 0d |
| 37 |  | Relleno afirmado | resource dependent | 2d | 2023-05-31 | 2023-06-01 | 46, 36 | 365d | 0d |
|  | 3 | **Geotextil** |  |  | 2023-05-08 | 2023-05-11 |  |  |  |
| 43 |  | Zanja de anclaje | resource dependent | 3d | 2023-05-08 | 2023-05-10 | 38 | 0d |  |
| 42 |  | Instalación de Geotextil 400 gr/m2 | resource dependent | 3d | 2023-05-09 | 2023-05-11 | 43 FS-2d | 0d |  |
|  | 4 | **Colocación de roca** |  |  | 2023-05-12 | 2023-05-30 |  |  |  |
| 45 |  | Colocación de roca en uña | resource dependent | 12d | 2023-05-12 | 2023-05-23 | 42 | 0d |  |
| 46 |  | Colocación de roca en Talud | resource dependent | 7d | 2023-05-24 | 2023-05-30 | 45 | 0d |  |
|  | 5 | **Transportes** |  |  | 2023-04-22 | 2023-06-01 |  |  |  |
| 48 |  | Transporte de material orgánico (a DMO) D<=1km | resource dependent | 2d | 2023-04-22 | 2023-04-23 | 27 SS | 404d | 0d |
| 49 |  | Transporte de material excedente (dique provisional) D<=1km | resource dependent | 10d | 2023-04-24 | 2023-05-03 | 28 SS, 33 FF | 394d | 0d |
| 54 |  | Transporte de material de préstamo cantera de rio (cuerpo de terraplén) D<=1km | resource dependent | 6d | 2023-04-30 | 2023-05-05 | 35 SS | 392d |  |
| 55 |  | Transporte de material de préstamo cantera de rio (cuerpo de terraplén) D>1km | resource dependent | 6d | 2023-04-30 | 2023-05-05 | 35 SS | 392d |  |
| 56 |  | Transporte de material seleccionado para zanja D<=1km | resource dependent | 3d | 2023-05-08 | 2023-05-10 | 43 SS | 387d |  |
| 57 |  | Transporte de material seleccionado para zanja D>1km | resource dependent | 3d | 2023-05-08 | 2023-05-10 | 43 SS | 387d |  |
| 52 |  | Transporte de roca D<=1km | resource dependent | 19d | 2023-05-12 | 2023-05-30 | 45 SS, 46 FF | 367d |  |
| 53 |  | Transporte de roca D>1km | resource dependent | 19d | 2023-05-12 | 2023-05-30 | 45 SS, 46 FF | 367d |  |
| 50 |  | Transporte de material de préstamo (afirmado) D<=1km | resource dependent | 2d | 2023-05-31 | 2023-06-01 | 37 SS | 365d |  |
| 51 |  | Transporte de material de préstamo (afirmado) D>1km | resource dependent | 2d | 2023-05-31 | 2023-06-01 | 37 SS | 365d |  |

| ID | WBS | Activity | Type | Duration | Start | Finish | Predecessors | Total float | Free float |
| --- | --- | --- | --- | --- | --- | --- | --- | --- | --- |
|  | 10 | **Obras Civiles DI-PR-19B-D (PAQUETE 3)** |  |  | 2023-07-03 | 2023-08-18 |  |  |  |
| 279 |  | Trazo y replanteo de interferencia | resource dependent | 7d | 2023-07-03 | 2023-07-09 | 4 SS | 75d | 0d |
| 282 |  | Limpieza de terreno manual | resource dependent | 2d | 2023-07-03 | 2023-07-04 | 4 SS | 0d |  |
| 280 |  | Desvío provisional con tubería | resource dependent | 5d | 2023-07-05 | 2023-07-09 | 282 | 0d |  |
| 281 |  | Desvío provisional en tierras | resource dependent | 2d | 2023-07-10 | 2023-07-11 | 280 | 0d |  |
| 283 |  | Excavaciones no clasificada para estructuras | resource dependent | 2d | 2023-07-12 | 2023-07-13 | 281 | 0d |  |
| 284 |  | Excavacion no clasificada de zanja | resource dependent | 3d | 2023-07-14 | 2023-07-16 | 283 | 0d |  |
| 286 |  | Suministro de roca (Alcantarillas) | resource dependent | 7d | 2023-07-17 | 2023-07-23 | 284 | 0d |  |
| 295 |  | Cama de arena e=0.20m | resource dependent | 3d | 2023-07-17 | 2023-07-19 | 284 | 2d | 0d |
| 296 |  | Tubería HDPE Corrugada Ø=900mm (Suministro e instalación) | resource dependent | 2d | 2023-07-20 | 2023-07-21 | 295 | 2d |  |
| 285 |  | Relleno estructural | resource dependent | 7d | 2023-07-24 | 2023-07-30 | 287 FS-3d, 296 | 0d |  |
| 287 |  | Colocación de roca en uña (Alcantarillas) | resource dependent | 3d | 2023-07-24 | 2023-07-26 | 286 | 0d |  |
| 293 |  | Acero de refuerzo f'y=4200kg/cm2 | resource dependent | 12d | 2023-07-26 | 2023-08-06 | 285 FS-5d | 5d |  |
| 292 |  | Encofrado y Desencofrado Cara Oculta | resource dependent | 6d | 2023-07-27 | 2023-08-01 | 285 FS-4d | 2d | 0d |
| 288 |  | Concreto de Nivelacion (f'c=100 kg/cm2) | resource dependent | 2d | 2023-07-31 | 2023-08-01 | 285, 264 | 0d |  |
| 289 |  | Concreto Clase C (f'c=280 kg/cm2) Premezclado - Cimientos reforzados | resource dependent | 3d | 2023-08-02 | 2023-08-04 | 288, 292 FS-4d, 293 FS-10d | 0d |  |
| 291 |  | Encofrado y Desencofrado Caravista | resource dependent | 5d | 2023-08-02 | 2023-08-06 | 292 | 2d |  |
| 290 |  | Concreto Clase C (f'c=280 kg/cm2) Premezclado - Muros de contencion | resource dependent | 4d | 2023-08-05 | 2023-08-08 | 289, 291 FS-4d | 0d |  |
| 294 |  | Emboquillado de piedra e=0.30m | resource dependent | 2d | 2023-08-09 | 2023-08-10 | 290 | 4d |  |
| 299 |  | Waterstop (anillos de estanqueidad) | resource dependent | 2d | 2023-08-09 | 2023-08-10 | 290, 296 | 0d |  |
| 301 |  | Relleno con material granular (incluye extracción de material, zarandeo y combinación de material) | resource dependent | 3d | 2023-08-09 | 2023-08-11 | 290 | 294d |  |
| 297 |  | Compuertas Charnela Ø900 (Suministro e instalacion) | resource dependent | 2d | 2023-08-11 | 2023-08-12 | 299 | 0d |  |
| 298 |  | Sello en juntas | resource dependent | 2d | 2023-08-13 | 2023-08-14 | 297 | 0d |  |
| 300 |  | Pintura bituminosa | resource dependent | 4d | 2023-08-15 | 2023-08-18 | 294, 298 | 0d |  |

| ID | WBS | Activity | Type | Duration | Start | Finish | Predecessors | Total float | Free float |
| --- | --- | --- | --- | --- | --- | --- | --- | --- | --- |
|  | 11 | **Obras Civiles DI-PR-18-D (PAQUETE 3)** |  |  | 2023-07-10 | 2023-09-09 |  |  |  |
| 303 |  | Trazo y replanteo de interferencia | resource dependent | 9d | 2023-07-10 | 2023-07-18 | 279 | 318d |  |
| 305 |  | Limpieza de terreno manual | resource dependent | 9d | 2023-07-10 | 2023-07-18 | 279 | 75d | 0d |
| 304 |  | Desvío provisional con tubería | resource dependent | 7d | 2023-07-19 | 2023-07-25 | 305 | 75d | 0d |
| 306 |  | Excavaciones no clasificada para estructuras | resource dependent | 2d | 2023-07-26 | 2023-07-27 | 304 | 75d | 0d |
| 307 |  | Excavacion no clasificada de zanja | resource dependent | 2d | 2023-07-28 | 2023-07-29 | 306 | 75d | 0d |
| 309 |  | Suministro de roca (Alcantarillas) | resource dependent | 5d | 2023-07-30 | 2023-08-03 | 307 | 75d | 0d |
| 319 |  | Cama de arena e=0.20m | resource dependent | 3d | 2023-07-30 | 2023-08-01 | 307 | 77d | 0d |
| 320 |  | Tubería HDPE Corrugada Ø=1200mm (Suministro e instalación) | resource dependent | 2d | 2023-08-02 | 2023-08-03 | 319 | 77d | 2d |
| 310 |  | Colocación de roca en uña (Alcantarillas) | resource dependent | 2d | 2023-08-04 | 2023-08-05 | 309 | 75d | 0d |
| 308 |  | Relleno estructural | resource dependent | 11d | 2023-08-06 | 2023-08-16 | 310, 320 | 75d | 0d |
| 311 |  | Concreto de Nivelacion (f'c=100 kg/cm2) | resource dependent | 4d | 2023-08-17 | 2023-08-20 | 290, 308 | 75d | 0d |
| 315 |  | Encofrado y Desencofrado Cara Oculta | resource dependent | 5d | 2023-08-17 | 2023-08-21 | 308 | 75d | 0d |
| 316 |  | Acero de refuerzo f'y=4200kg/cm2 | resource dependent | 11d | 2023-08-17 | 2023-08-27 | 308 | 75d | 0d |
| 312 |  | Concreto Clase C (f'c=280 kg/cm2) Premezclado - Cimientos reforzados | resource dependent | 3d | 2023-08-21 | 2023-08-23 | 311, 315 FS-1d, 316 FS-7d | 75d | 0d |
| 314 |  | Encofrado y Desencofrado Caravista | resource dependent | 6d | 2023-08-22 | 2023-08-27 | 315 | 75d | 0d |
| 313 |  | Concreto Clase C (f'c=280 kg/cm2) Premezclado - Muros de contencion | resource dependent | 5d | 2023-08-24 | 2023-08-28 | 312, 314 FS-4d | 75d | 0d |
| 317 |  | Emboquillado de piedra e=0.30m | resource dependent | 6d | 2023-08-29 | 2023-09-03 | 313 | 265d | 0d |
| 323 |  | Waterstop (anillos de estanqueidad) | resource dependent | 2d | 2023-08-29 | 2023-08-30 | 313, 320 | 75d | 0d |
| 321 |  | Compuertas Charnela Ø1200 (Suministro e instalacion) | resource dependent | 3d | 2023-08-31 | 2023-09-02 | 323 | 75d | 0d |
| 322 |  | Sello en juntas | resource dependent | 2d | 2023-09-03 | 2023-09-04 | 321 | 75d | 0d |
| 318 |  | Emboquillado de piedra e=0.50m | resource dependent | 6d | 2023-09-04 | 2023-09-09 | 317 | 265d |  |
| 324 |  | Pintura bituminosa | resource dependent | 5d | 2023-09-05 | 2023-09-09 | 322 | 75d |  |
|  | 2 | **DIQUE DI-PR-24-D (PAQUETE 2)** |  |  | 2023-04-24 | 2023-07-24 |  |  |  |
|  | 1 | **Excavaciones** |  |  | 2023-04-24 | 2023-05-28 |  |  |  |
| 60 |  | Desbroce | resource dependent | 4d | 2023-04-24 | 2023-04-27 | 27 | 0d |  |
| 65 |  | Conformación de material excedente en DMO | resource dependent | 4d | 2023-04-24 | 2023-04-27 | 81 FS-2d | 400d |  |
| 61 |  | Excavación de cimentación | resource dependent | 12d | 2023-05-04 | 2023-05-15 | 33, 60 | 0d |  |
| 64 |  | Conformación de material excedente en DME | resource dependent | 25d | 2023-05-04 | 2023-05-28 | 82 FS-25d | 369d |  |
| 62 |  | Perfilado y conformación de Plataforma de fundación | resource dependent | 4d | 2023-05-13 | 2023-05-16 | 61 FS-3d | 0d |  |
| 63 |  | Excavación de uña | resource dependent | 11d | 2023-05-16 | 2023-05-26 | 61, 33 | 369d | 0d |
| 66 |  | Excavación Localizada - Sobreexcavación | resource dependent | 2d | 2023-05-27 | 2023-05-28 | 63 | 369d | 0d |

| ID | WBS | Activity | Type | Duration | Start | Finish | Predecessors | Total float | Free float |
| --- | --- | --- | --- | --- | --- | --- | --- | --- | --- |
|  | 2 | **Rellenos** |  |  | 2023-05-14 | 2023-07-24 |  |  |  |
| 68 |  | Relleno con material granular (incluye extracción de material, zarandeo y combinación de material) | resource dependent | 14d | 2023-05-14 | 2023-05-27 | 62 FS-3d | 0d |  |
| 71 |  | Perfilado de Talud del dique | resource dependent | 4d | 2023-05-25 | 2023-05-28 | 68 FS-3d | 0d |  |
| 72 |  | Relleno con material seleccionado (incluye extracción de material, zarandeo y combinación de material) en sobreexcavación | resource dependent | 5d | 2023-05-28 | 2023-06-01 | 68 | 361d | 0d |
| 73 |  | Grava para Drenaje | resource dependent | 4d | 2023-06-02 | 2023-06-05 | 72 | 361d |  |
| 69 |  | Relleno sin compactar | resource dependent | 4d | 2023-07-19 | 2023-07-22 | 79 FS-4d | 312d | 0d |
| 70 |  | Relleno afirmado | resource dependent | 2d | 2023-07-23 | 2023-07-24 | 79, 69 | 312d | 0d |
|  | 3 | **Geotextil** |  |  | 2023-05-29 | 2023-05-31 |  |  |  |
| 76 |  | Zanja de anclaje | resource dependent | 2d | 2023-05-29 | 2023-05-30 | 71 | 0d |  |
| 75 |  | Instalación de Geotextil 400 gr/m2 | resource dependent | 2d | 2023-05-30 | 2023-05-31 | 76 FS-1d | 0d |  |
|  | 4 | **Colocación de roca** |  |  | 2023-05-31 | 2023-07-22 |  |  |  |
| 78 |  | Colocación de roca en uña | resource dependent | 34d | 2023-05-31 | 2023-07-03 | 46, 75 FS-1d, 250 | 0d |  |
| 79 |  | Colocación de roca en Talud | resource dependent | 19d | 2023-07-04 | 2023-07-22 | 78 | 0d |  |
|  | 5 | **Transportes** |  |  | 2023-04-24 | 2023-07-24 |  |  |  |
| 81 |  | Transporte de material orgánico (a DMO) D<=1km | resource dependent | 2d | 2023-04-24 | 2023-04-25 | 60 SS | 400d | 0d |
| 82 |  | Transporte de material excedente (dique provisional) D<=1km | resource dependent | 25d | 2023-05-04 | 2023-05-28 | 61 SS, 66 FF | 369d | 0d |
| 87 |  | Transporte de material de préstamo cantera de rio (cuerpo de terraplén) D<=1km | resource dependent | 14d | 2023-05-14 | 2023-05-27 | 68 SS | 370d |  |
| 88 |  | Transporte de material de préstamo cantera de rio (cuerpo de terraplén) D>1km | resource dependent | 14d | 2023-05-14 | 2023-05-27 | 68 SS | 370d |  |
| 89 |  | Transporte de material seleccionado para zanja D<=1km | resource dependent | 2d | 2023-05-29 | 2023-05-30 | 76 SS | 367d |  |
| 90 |  | Transporte de material seleccionado para zanja D>1km | resource dependent | 2d | 2023-05-29 | 2023-05-30 | 76 SS | 367d |  |
| 85 |  | Transporte de roca D<=1km | resource dependent | 53d | 2023-05-31 | 2023-07-22 | 78 SS, 79 FF | 314d |  |
| 86 |  | Transporte de roca D>1km | resource dependent | 53d | 2023-05-31 | 2023-07-22 | 78 SS, 79 FF | 314d |  |
| 83 |  | Transporte de material de préstamo (afirmado) D<=1km | resource dependent | 2d | 2023-07-23 | 2023-07-24 | 70 SS | 312d |  |
| 84 |  | Transporte de material de préstamo (afirmado) D>1km | resource dependent | 2d | 2023-07-23 | 2023-07-24 | 70 SS | 312d |  |

| ID | WBS | Activity | Type | Duration | Start | Finish | Predecessors | Total float | Free float |
| --- | --- | --- | --- | --- | --- | --- | --- | --- | --- |
|  | 3 | **DIQUE DI-PR-13-D (PAQUETE 2)** |  |  | 2023-04-28 | 2023-09-13 |  |  |  |
|  | 1 | **Excavaciones** |  |  | 2023-04-28 | 2023-06-24 |  |  |  |
| 93 |  | Desbroce | resource dependent | 3d | 2023-04-28 | 2023-04-30 | 60, 742 | 0d |  |
| 99 |  | Conformación de material excedente en DMO | resource dependent | 5d | 2023-04-28 | 2023-05-02 | 114 FS-3d, 115 FS-3d | 395d |  |
| 94 |  | Remoción de dique existente | resource dependent | 20d | 2023-05-01 | 2023-05-20 | 93 | 0d |  |
| 98 |  | Conformación de material excedente en DME | resource dependent | 44d | 2023-05-12 | 2023-06-24 | 116 FS-44d, 117 FS-44d | 342d |  |
| 95 |  | Excavación de cimentación | resource dependent | 18d | 2023-05-21 | 2023-06-07 | 61, 94 | 0d |  |
| 96 |  | Perfilado y conformación de Plataforma de fundación | resource dependent | 10d | 2023-06-01 | 2023-06-10 | 95 FS-7d | 0d |  |
| 97 |  | Excavación de uña | resource dependent | 17d | 2023-06-08 | 2023-06-24 | 95 | 12d | 0d |
|  | 2 | **Rellenos** |  |  | 2023-06-04 | 2023-09-13 |  |  |  |
| 101 |  | Relleno con material granular (incluye extracción de material, zarandeo y combinación de material) | resource dependent | 20d | 2023-06-04 | 2023-06-23 | 96 FS-7d | 0d |  |
| 104 |  | Perfilado de Talud del dique | resource dependent | 7d | 2023-06-19 | 2023-06-25 | 101 FS-5d | 0d |  |
| 105 |  | Grava para Drenaje | resource dependent | 5d | 2023-06-24 | 2023-06-28 | 101 | 338d |  |
| 102 |  | Relleno sin compactar | resource dependent | 9d | 2023-09-01 | 2023-09-09 | 111 FS-9d | 261d | 0d |
| 103 |  | Relleno afirmado | resource dependent | 4d | 2023-09-10 | 2023-09-13 | 111, 102 | 261d | 0d |
|  | 3 | **Geotextil** |  |  | 2023-06-26 | 2023-07-09 |  |  |  |
| 108 |  | Zanja de anclaje | resource dependent | 13d | 2023-06-26 | 2023-07-08 | 104 | 0d |  |
| 107 |  | Instalación de Geotextil 400 gr/m2 | resource dependent | 13d | 2023-06-27 | 2023-07-09 | 108 FS-12d | 0d |  |
|  | 4 | **Colocación de roca** |  |  | 2023-05-21 | 2023-09-09 |  |  |  |
| 112 |  | Extracción y Selección de Rocas Reutilizables (50% de roca utilizable) | resource dependent | 30d | 2023-05-21 | 2023-06-19 | 94 | 14d |  |
| 110 |  | Colocación de roca en uña | resource dependent | 46d | 2023-07-04 | 2023-08-18 | 78, 107 FS-6d, 276, 112 | 0d |  |
| 111 |  | Colocación de roca en Talud | resource dependent | 49d | 2023-07-23 | 2023-09-09 | 79 | 0d |  |
|  | 5 | **Transportes** |  |  | 2023-04-28 | 2023-09-13 |  |  |  |
| 114 |  | Transporte de material orgánico (a DMO) D<=1km | resource dependent | 3d | 2023-04-28 | 2023-04-30 | 93 SS | 395d | 0d |
| 115 |  | Transporte de material orgánico (a DMO) D>1km | resource dependent | 3d | 2023-04-28 | 2023-04-30 | 93 SS | 395d | 0d |
| 116 |  | Transporte de material excedente (dique provisional) D<=1km | resource dependent | 55d | 2023-05-01 | 2023-06-24 | 94 SS, 97 FF | 342d | 0d |
| 117 |  | Transporte de material excedente (dique provisional) D> 1km | resource dependent | 55d | 2023-05-01 | 2023-06-24 | 94 SS, 97 FF | 342d | 0d |
| 122 |  | Transporte de material de préstamo cantera de rio (cuerpo de terraplén) D<=1km | resource dependent | 20d | 2023-06-04 | 2023-06-23 | 101 SS | 343d |  |
| 123 |  | Transporte de material de préstamo cantera de rio (cuerpo de terraplén) D>1km | resource dependent | 20d | 2023-06-04 | 2023-06-23 | 101 SS | 343d |  |
| 124 |  | Transporte de material seleccionado para zanja D<=1km | resource dependent | 13d | 2023-06-26 | 2023-07-08 | 108 SS | 328d |  |
| 125 |  | Transporte de material seleccionado para zanja D>1km | resource dependent | 13d | 2023-06-26 | 2023-07-08 | 108 SS | 328d |  |
| 120 |  | Transporte de roca D<=1km | resource dependent | 68d | 2023-07-04 | 2023-09-09 | 110 SS, 111 FF | 265d |  |
| 121 |  | Transporte de roca D>1km | resource dependent | 68d | 2023-07-04 | 2023-09-09 | 110 SS, 111 FF | 265d |  |
| 118 |  | Transporte de material de préstamo (afirmado) D<=1km | resource dependent | 4d | 2023-09-10 | 2023-09-13 | 103 SS | 261d |  |
| 119 |  | Transporte de material de préstamo (afirmado) D>1km | resource dependent | 4d | 2023-09-10 | 2023-09-13 | 103 SS | 261d |  |

| ID | WBS | Activity | Type | Duration | Start | Finish | Predecessors | Total float | Free float |
| --- | --- | --- | --- | --- | --- | --- | --- | --- | --- |
|  | 4 | **DIQUE DI-PR-19B-D (PAQUETE 3)** |  |  | 2023-07-03 | 2023-11-28 |  |  |  |
|  | 1 | **Excavaciones** |  |  | 2023-07-03 | 2023-09-29 |  |  |  |
| 128 |  | Desbroce | resource dependent | 4d | 2023-07-03 | 2023-07-06 | 4 SS, 760 | 0d |  |
| 133 |  | Conformación de material excedente en DMO | resource dependent | 6d | 2023-07-03 | 2023-07-08 | 146 FS-4d, 147 FS-4d | 328d |  |
| 129 |  | Excavación de cimentación | resource dependent | 25d | 2023-07-07 | 2023-07-31 | 97, 128 | 0d |  |
| 132 |  | Conformación de material excedente en DME | resource dependent | 85d | 2023-07-07 | 2023-09-29 | 148 FS-85d, 149 FS-85d | 245d |  |
| 130 |  | Perfilado y conformación de Plataforma de fundación | resource dependent | 14d | 2023-07-19 | 2023-08-01 | 129 FS-13d | 0d |  |
| 131 |  | Excavación de uña | resource dependent | 37d | 2023-08-01 | 2023-09-06 | 129 | 7d | 0d |
|  | 2 | **Rellenos** |  |  | 2023-07-20 | 2023-11-28 |  |  |  |
| 135 |  | Relleno con material granular (incluye extracción de material, zarandeo y combinación de material) | resource dependent | 25d | 2023-07-20 | 2023-08-13 | 130 FS-13d | 0d |  |
| 138 |  | Perfilado de Talud del dique | resource dependent | 10d | 2023-08-05 | 2023-08-14 | 135 FS-9d | 0d |  |
| 136 |  | Relleno sin compactar | resource dependent | 11d | 2023-11-13 | 2023-11-23 | 144 FS-11d | 185d | 0d |
| 137 |  | Relleno afirmado | resource dependent | 5d | 2023-11-24 | 2023-11-28 | 136, 144 | 185d | 0d |
|  | 3 | **Geotextil** |  |  | 2023-08-06 | 2023-08-27 |  |  |  |
| 141 |  | Zanja de anclaje | resource dependent | 21d | 2023-08-06 | 2023-08-26 | 138 FS-9d | 0d |  |
| 140 |  | Instalación de Geotextil 400 gr/m2 | resource dependent | 21d | 2023-08-07 | 2023-08-27 | 141 FS-20d | 0d |  |
|  | 4 | **Colocación de roca** |  |  | 2023-08-19 | 2023-11-23 |  |  |  |
| 143 |  | Colocación de roca en uña | resource dependent | 52d | 2023-08-19 | 2023-10-09 | 110, 300, 140 FS-9d | 0d |  |
| 144 |  | Colocación de roca en Talud | resource dependent | 75d | 2023-09-10 | 2023-11-23 | 111, 143 FS-30d | 0d |  |
|  | 5 | **Transportes** |  |  | 2023-07-03 | 2023-11-28 |  |  |  |
| 146 |  | Transporte de material orgánico (a DMO) D<=1km | resource dependent | 4d | 2023-07-03 | 2023-07-06 | 128 SS | 328d | 0d |
| 147 |  | Transporte de material orgánico (a DMO) D>1km | resource dependent | 4d | 2023-07-03 | 2023-07-06 | 128 SS | 328d | 0d |
| 148 |  | Transporte de material excedente (dique provisional) D<=1km | resource dependent | 85d | 2023-07-07 | 2023-09-29 | 129 SS, 131 FF | 245d | 0d |
| 149 |  | Transporte de material excedente (dique provisional) D> 1km | resource dependent | 85d | 2023-07-07 | 2023-09-29 | 129 SS, 131 FF | 245d | 0d |
| 154 |  | Transporte de material de préstamo cantera de rio (cuerpo de terraplén) D<=1km | resource dependent | 49d | 2023-07-20 | 2023-09-06 | 135 SS | 268d |  |
| 155 |  | Transporte de material de préstamo cantera de rio (cuerpo de terraplén) D>1km | resource dependent | 49d | 2023-07-20 | 2023-09-06 | 135 SS | 268d |  |
| 156 |  | Transporte de material seleccionado para zanja D<= 1km | resource dependent | 21d | 2023-08-06 | 2023-08-26 | 141 SS | 279d |  |
| 157 |  | Transporte de material seleccionado para zanja D> 1km | resource dependent | 21d | 2023-08-06 | 2023-08-26 | 141 SS | 279d |  |
| 152 |  | Transporte de roca D<=1km | resource dependent | 97d | 2023-08-19 | 2023-11-23 | 143 SS, 144 FF | 190d |  |
| 153 |  | Transporte de roca D>1km | resource dependent | 97d | 2023-08-19 | 2023-11-23 | 143 SS, 144 FF | 190d |  |
| 150 |  | Transporte de material de préstamo (afirmado) D<=1km | resource dependent | 5d | 2023-11-24 | 2023-11-28 | 137 SS | 185d |  |
| 151 |  | Transporte de material de préstamo (afirmado) D>1km | resource dependent | 5d | 2023-11-24 | 2023-11-28 | 137 SS | 185d |  |

| ID | WBS | Activity | Type | Duration | Start | Finish | Predecessors | Total float | Free float |
| --- | --- | --- | --- | --- | --- | --- | --- | --- | --- |
|  | 5 | **ESPIGON 18.1** |  |  | 2023-09-05 | 2023-11-20 |  |  |  |
|  | 1 | **Excavaciones** |  |  | 2023-09-05 | 2023-09-11 |  |  |  |
| 160 |  | Desbroce | resource dependent | 2d | 2023-09-05 | 2023-09-06 | 128 FS+60d | 7d | 0d |
| 163 |  | Conformación de material excedente en DMO | resource dependent | 2d | 2023-09-05 | 2023-09-06 | 168 FS-2d, 169 FS-2d | 268d |  |
| 161 |  | Excavación de cimentación | resource dependent | 5d | 2023-09-07 | 2023-09-11 | 131 | 7d | 0d |
| 162 |  | Conformación de material excedente en DME | resource dependent | 5d | 2023-09-07 | 2023-09-11 | 170 FS-5d, 171 FS-5d | 263d |  |
|  | 2 | **Colocación de roca** |  |  | 2023-10-10 | 2023-11-20 |  |  |  |
| 165 |  | Colocación de roca en uña | resource dependent | 16d | 2023-10-10 | 2023-10-25 | 143, 161 | 0d |  |
| 166 |  | Colocación de roca en Talud | resource dependent | 26d | 2023-10-26 | 2023-11-20 | 165 | 0d |  |
|  | 3 | **Transportes** |  |  | 2023-09-05 | 2023-11-20 |  |  |  |
| 168 |  | Transporte de material orgánico (a DMO) D<=1km | resource dependent | 2d | 2023-09-05 | 2023-09-06 | 160 SS | 268d | 0d |
| 169 |  | Transporte de material orgánico (a DMO) D>1km | resource dependent | 2d | 2023-09-05 | 2023-09-06 | 160 SS | 268d | 0d |
| 170 |  | Transporte de material excedente (dique provisional) D<=1km | resource dependent | 5d | 2023-09-07 | 2023-09-11 | 161 SS | 263d | 0d |
| 171 |  | Transporte de material excedente (dique provisional) D> 1km | resource dependent | 5d | 2023-09-07 | 2023-09-11 | 161 SS | 263d | 0d |
| 172 |  | Transporte de roca D<=1km | resource dependent | 42d | 2023-10-10 | 2023-11-20 | 165 SS, 166 FF | 193d |  |
| 173 |  | Transporte de roca D>1km | resource dependent | 42d | 2023-10-10 | 2023-11-20 | 165 SS, 166 FF | 193d |  |
|  | 6 | **ESPIGON 18.2** |  |  | 2023-11-04 | 2023-12-11 |  |  |  |
|  | 1 | **Excavaciones** |  |  | 2023-11-04 | 2023-11-09 |  |  |  |
| 176 |  | Desbroce | resource dependent | 2d | 2023-11-04 | 2023-11-05 | 192 FS+53d | 11d | 0d |
| 179 |  | Conformación de material excedente en DMO | resource dependent | 2d | 2023-11-04 | 2023-11-05 | 184 FS-2d, 185 FS-2d | 208d |  |
| 177 |  | Excavación de cimentación | resource dependent | 4d | 2023-11-06 | 2023-11-09 | 176, 198 | 11d | 0d |
| 178 |  | Conformación de material excedente en DME | resource dependent | 4d | 2023-11-06 | 2023-11-09 | 186 FS-4d, 187 FS-4d | 204d |  |
|  | 2 | **Colocación de roca** |  |  | 2023-11-21 | 2023-12-11 |  |  |  |
| 181 |  | Colocación de roca en uña | resource dependent | 9d | 2023-11-21 | 2023-11-29 | 166, 177 | 0d |  |
| 182 |  | Colocación de roca en Talud | resource dependent | 12d | 2023-11-30 | 2023-12-11 | 181 | 0d |  |

| ID | WBS | Activity | Type | Duration | Start | Finish | Predecessors | Total float | Free float |
| --- | --- | --- | --- | --- | --- | --- | --- | --- | --- |
|  | 3 | **Transportes** |  |  | 2023-11-04 | 2023-12-11 |  |  |  |
| 184 |  | Transporte de material orgánico (a DMO) D<=1km | resource dependent | 2d | 2023-11-04 | 2023-11-05 | 176 SS | 208d | 0d |
| 185 |  | Transporte de material orgánico (a DMO) D>1km | resource dependent | 2d | 2023-11-04 | 2023-11-05 | 176 SS | 208d | 0d |
| 186 |  | Transporte de material excedente (dique provisional) D<=1km | resource dependent | 4d | 2023-11-06 | 2023-11-09 | 177 SS | 204d | 0d |
| 187 |  | Transporte de material excedente (dique provisional) D> 1km | resource dependent | 4d | 2023-11-06 | 2023-11-09 | 177 SS | 204d | 0d |
| 188 |  | Transporte de roca D<=1km | resource dependent | 21d | 2023-11-21 | 2023-12-11 | 181 SS, 182 FF | 172d |  |
| 189 |  | Transporte de roca D>1km | resource dependent | 21d | 2023-11-21 | 2023-12-11 | 181 SS, 182 FF | 172d |  |
|  | 7 | **DIQUE DI-PR-18-D (PAQUETE 3)** |  |  | 2023-09-09 | 2024-05-31 |  |  |  |
|  | 1 | **Excavaciones** |  |  | 2023-09-09 | 2023-11-05 |  |  |  |
| 192 |  | Desbroce | resource dependent | 3d | 2023-09-09 | 2023-09-11 | 160 FS+2d | 7d | 0d |
| 197 |  | Conformación de material excedente en DMO | resource dependent | 4d | 2023-09-09 | 2023-09-12 | 215 FS-3d, 216 FS-3d | 262d |  |
| 193 |  | Excavación de cimentación | resource dependent | 20d | 2023-09-12 | 2023-10-01 | 161, 192 | 7d | 0d |
| 196 |  | Conformación de material excedente en DME | resource dependent | 55d | 2023-09-12 | 2023-11-05 | 217 FS-55d, 218 FS-55d | 208d |  |
| 194 |  | Perfilado y conformación de Plataforma de fundación | resource dependent | 10d | 2023-09-29 | 2023-10-08 | 193 FS-3d | 7d | 0d |
| 195 |  | Excavación de uña | resource dependent | 30d | 2023-10-02 | 2023-10-31 | 193 | 11d | 0d |
| 198 |  | Excavación Localizada - Sobreexcavación | resource dependent | 5d | 2023-11-01 | 2023-11-05 | 195 | 11d | 0d |
|  | 2 | **Rellenos** |  |  | 2023-10-02 | 2024-05-31 |  |  |  |
| 200 |  | Relleno con material granular (incluye extracción de material, zarandeo y combinación de material) | resource dependent | 27d | 2023-10-02 | 2023-10-28 | 194 FS-7d | 7d | 0d |
| 203 |  | Perfilado de Talud del dique | resource dependent | 18d | 2023-10-23 | 2023-11-09 | 200 FS-6d | 7d | 0d |
| 204 |  | Relleno con material seleccionado (incluye extracción de material, zarandeo y combinación de material) en sobreexcavación | resource dependent | 23d | 2023-10-29 | 2023-11-20 | 200 | 189d | 0d |
| 205 |  | Grava para Drenaje | resource dependent | 4d | 2023-11-21 | 2023-11-24 | 204 | 189d |  |
| 201 |  | Relleno sin compactar | resource dependent | 20d | 2024-05-09 | 2024-05-28 | 211 FS-5d, 210 FS+12d | 0d |  |
| 202 |  | Relleno afirmado | resource dependent | 3d | 2024-05-29 | 2024-05-31 | 201 | 0d |  |
|  | 3 | **Geotextil** |  |  | 2023-11-10 | 2023-11-23 |  |  |  |
| 208 |  | Zanja de anclaje | resource dependent | 13d | 2023-11-10 | 2023-11-22 | 203 | 7d | 0d |
| 207 |  | Instalación de Geotextil 400 gr/m2 | resource dependent | 13d | 2023-11-11 | 2023-11-23 | 208 FS-12d | 7d |  |

| ID | WBS | Activity | Type | Duration | Start | Finish | Predecessors | Total float | Free float |
| --- | --- | --- | --- | --- | --- | --- | --- | --- | --- |
|  | 4 | **Colocación de roca** |  |  | 2023-11-01 | 2024-05-13 |  |  |  |
| 213 |  | Malla gavión de 1m x 1m x 5m | resource dependent | 5d | 2023-11-01 | 2023-11-05 | 195 | 11d | 0d |
| 212 |  | Protección de talud con colchón reno 6m largo x e= 0.30cm | resource dependent | 10d | 2023-11-06 | 2023-11-15 | 213 | 11d |  |
| 210 |  | Colocación de roca en uña | resource dependent | 155d | 2023-11-24 | 2024-04-26 | 144, 324, 207 FS-7d, 212 FS-3d | 0d |  |
| 211 |  | Colocación de roca en Talud | resource dependent | 154d | 2023-12-12 | 2024-05-13 | 182 | 0d |  |
|  | 5 | **Transportes** |  |  | 2023-09-09 | 2024-05-31 |  |  |  |
| 215 |  | Transporte de material orgánico (a DMO) D<=1km | resource dependent | 3d | 2023-09-09 | 2023-09-11 | 192 SS | 262d | 0d |
| 216 |  | Transporte de material orgánico (a DMO) D>1km | resource dependent | 3d | 2023-09-09 | 2023-09-11 | 192 SS | 262d | 0d |
| 217 |  | Transporte de material excedente (dique provisional) D<=1km | resource dependent | 55d | 2023-09-12 | 2023-11-05 | 193 SS, 198 FF | 208d | 0d |
| 218 |  | Transporte de material excedente (dique provisional) D> 1km | resource dependent | 55d | 2023-09-12 | 2023-11-05 | 193 SS, 198 FF | 208d | 0d |
| 223 |  | Transporte de material de préstamo cantera de rio (cuerpo de terraplén) D<=1km | resource dependent | 27d | 2023-10-02 | 2023-10-28 | 200 SS | 216d |  |
| 224 |  | Transporte de material de préstamo cantera de rio (cuerpo de terraplén) D>1km | resource dependent | 27d | 2023-10-02 | 2023-10-28 | 200 SS | 216d |  |
| 225 |  | Transporte de material seleccionado para zanja D<= 1km | resource dependent | 13d | 2023-11-10 | 2023-11-22 | 208 SS | 191d |  |
| 226 |  | Transporte de material seleccionado para zanja D> 1km | resource dependent | 13d | 2023-11-10 | 2023-11-22 | 208 SS | 191d |  |
| 221 |  | Transporte de roca D<=1km | resource dependent | 172d | 2023-11-24 | 2024-05-13 | 210 SS, 211 FF | 18d |  |
| 222 |  | Transporte de roca D>1km | resource dependent | 172d | 2023-11-24 | 2024-05-13 | 210 SS, 211 FF | 18d |  |
| 219 |  | Transporte de material de préstamo (afirmado) D<=1km | resource dependent | 3d | 2024-05-29 | 2024-05-31 | 202 SS | 0d |  |
| 220 |  | Transporte de material de préstamo (afirmado) D>1km | resource dependent | 3d | 2024-05-29 | 2024-05-31 | 202 SS | 0d |  |
|  | 8 | **Obras Civiles DI-PR-24-D (PAQUETE 2)** |  |  | 2023-04-22 | 2023-05-30 |  |  |  |
| 228 |  | Trazo y replanteo de interferencia | resource dependent | 3d | 2023-04-22 | 2023-04-24 | 3 SS+20d, 23 FS-10d | 1d | 0d |
| 230 |  | Limpieza de terreno manual | resource dependent | 2d | 2023-04-22 | 2023-04-23 | 3 SS+20d, 23 FS-10d | 0d |  |
| 229 |  | Desvío provisional con tubería | resource dependent | 4d | 2023-04-24 | 2023-04-27 | 230 | 0d |  |
| 231 |  | Excavaciones no clasificada para estructuras | resource dependent | 2d | 2023-04-28 | 2023-04-29 | 229 | 0d |  |
| 232 |  | Excavacion no clasificada de zanja | resource dependent | 2d | 2023-04-30 | 2023-05-01 | 231 | 0d |  |
| 234 |  | Suministro de roca (Alcantarillas) | resource dependent | 4d | 2023-05-02 | 2023-05-05 | 232 | 0d |  |
| 245 |  | Cama de arena e=0.20m | resource dependent | 2d | 2023-05-02 | 2023-05-03 | 232 | 0d |  |
| 246 |  | Tubería HDPE Corrugada Ø=1200mm (Suministro e instalación) | resource dependent | 6d | 2023-05-02 | 2023-05-07 | 245 FS-2d | 0d |  |
| 235 |  | Colocación de roca en uña (Alcantarillas) | resource dependent | 2d | 2023-05-06 | 2023-05-07 | 234 | 0d |  |
| 233 |  | Relleno estructural | resource dependent | 5d | 2023-05-08 | 2023-05-12 | 246, 235 | 0d |  |
| 236 |  | Concreto de Nivelacion (f'c=100 kg/cm2) | resource dependent | 2d | 2023-05-13 | 2023-05-14 | 233 | 0d |  |
| 241 |  | Encofrado y Desencofrado Cara Oculta | resource dependent | 4d | 2023-05-13 | 2023-05-16 | 233 | 0d |  |
| 242 |  | Acero de refuerzo f'y=4200kg/cm2 | resource dependent | 6d | 2023-05-13 | 2023-05-18 | 233 | 0d |  |
| 237 |  | Concreto Clase F (f'c=140 kg/cm2) | resource dependent | 2d | 2023-05-15 | 2023-05-16 | 236 | 0d |  |
| 238 |  | Concreto Clase C (f'c=280 kg/cm2) Premezclado - Cimientos reforzados | resource dependent | 2d | 2023-05-17 | 2023-05-18 | 237, 241, 242 FS-2d | 0d |  |
| 240 |  | Encofrado y Desencofrado Caravista | resource dependent | 3d | 2023-05-17 | 2023-05-19 | 241 | 0d |  |
| 239 |  | Concreto Clase C (f'c=280 kg/cm2) Premezclado - Muros de contencion | resource dependent | 3d | 2023-05-19 | 2023-05-21 | 238, 240 FS-1d | 0d |  |
| 243 |  | Emboquillado de piedra e=0.30m | resource dependent | 2d | 2023-05-22 | 2023-05-23 | 239 | 371d | 0d |
| 249 |  | Waterstop (anillos de estanqueidad) | resource dependent | 2d | 2023-05-22 | 2023-05-23 | 239, 246 | 0d |  |
| 244 |  | Emboquillado de piedra e=0.50m | resource dependent | 3d | 2023-05-24 | 2023-05-26 | 243 | 371d |  |
| 247 |  | Compuertas Charnela Ø1200 (Suministro e instalacion) | resource dependent | 2d | 2023-05-24 | 2023-05-25 | 249 | 0d |  |
| 248 |  | Sello en juntas | resource dependent | 2d | 2023-05-26 | 2023-05-27 | 247 | 0d |  |
| 250 |  | Pintura bituminosa | resource dependent | 3d | 2023-05-28 | 2023-05-30 | 248 | 0d |  |

| ID | WBS | Activity | Type | Duration | Start | Finish | Predecessors | Total float | Free float |
| --- | --- | --- | --- | --- | --- | --- | --- | --- | --- |
|  | 9 | **Obras Civiles DI-PR-13-D (PAQUETE 2)** |  |  | 2023-04-25 | 2023-07-03 |  |  |  |
| 252 |  | Trazo y replanteo de interferencia | resource dependent | 23d | 2023-04-25 | 2023-05-17 | 228 | 380d |  |
| 255 |  | Limpieza de terreno manual | resource dependent | 2d | 2023-04-25 | 2023-04-26 | 228, 230 | 1d |  |
| 253 |  | Desvío provisional con tubería | resource dependent | 4d | 2023-04-28 | 2023-05-01 | 255, 229 | 0d |  |
| 254 |  | Desvío provisional en tierras | resource dependent | 10d | 2023-05-02 | 2023-05-11 | 253 | 0d |  |
| 256 |  | Excavaciones no clasificada para estructuras | resource dependent | 2d | 2023-05-12 | 2023-05-13 | 254 | 0d |  |
| 257 |  | Excavacion no clasificada de zanja | resource dependent | 16d | 2023-05-14 | 2023-05-29 | 256 | 0d |  |
| 259 |  | Suministro de roca (Alcantarillas) | resource dependent | 3d | 2023-05-30 | 2023-06-01 | 257 | 0d |  |
| 271 |  | Cama de arena e=0.20m | resource dependent | 3d | 2023-05-30 | 2023-06-01 | 257 | 0d |  |
| 260 |  | Colocación de roca en uña (Alcantarillas) | resource dependent | 2d | 2023-06-02 | 2023-06-03 | 259 | 0d |  |
| 272 |  | Tubería HDPE Corrugada Ø=1200mm (Suministro e instalación) | resource dependent | 2d | 2023-06-02 | 2023-06-03 | 271 | 0d |  |
| 258 |  | Relleno estructural | resource dependent | 7d | 2023-06-04 | 2023-06-10 | 260, 272 | 0d |  |
| 261 |  | Concreto de Nivelacion (f'c=100 kg/cm2) | resource dependent | 2d | 2023-06-11 | 2023-06-12 | 258, 239 | 0d |  |
| 266 |  | Encofrado y Desencofrado Cara Oculta | resource dependent | 5d | 2023-06-11 | 2023-06-15 | 258 | 0d |  |
| 267 |  | Acero de refuerzo f'y=4200kg/cm2 | resource dependent | 9d | 2023-06-11 | 2023-06-19 | 258 | 0d |  |
| 262 |  | Concreto Clase F (f'c=140 kg/cm2) | resource dependent | 3d | 2023-06-13 | 2023-06-15 | 261 | 0d |  |
| 263 |  | Concreto Clase C (f'c=280 kg/cm2) Premezclado - Cimientos reforzados | resource dependent | 2d | 2023-06-16 | 2023-06-17 | 262, 266, 267 FS-4d | 0d |  |
| 265 |  | Encofrado y Desencofrado Caravista | resource dependent | 4d | 2023-06-16 | 2023-06-19 | 266 | 0d |  |
| 264 |  | Concreto Clase C (f'c=280 kg/cm2) Premezclado - Muros de contencion | resource dependent | 3d | 2023-06-18 | 2023-06-20 | 263, 265 FS-2d | 0d |  |
| 268 |  | Emboquillado de piedra e=0.20m | resource dependent | 2d | 2023-06-21 | 2023-06-22 | 264 | 0d |  |
| 275 |  | Waterstop (anillos de estanqueidad) | resource dependent | 2d | 2023-06-21 | 2023-06-22 | 264, 272 | 2d | 0d |
| 277 |  | Relleno con material granular (incluye extracción de material, zarandeo y combinación de material) | resource dependent | 5d | 2023-06-21 | 2023-06-25 | 264 | 341d |  |
| 269 |  | Emboquillado de piedra e=0.30m | resource dependent | 3d | 2023-06-23 | 2023-06-25 | 268 | 0d |  |
| 273 |  | Compuertas Charnela Ø1200 (Suministro e instalacion) | resource dependent | 2d | 2023-06-23 | 2023-06-24 | 275 | 2d | 0d |
| 274 |  | Sello en juntas | resource dependent | 2d | 2023-06-25 | 2023-06-26 | 273 | 2d |  |
| 270 |  | Emboquillado de piedra e=0.50m | resource dependent | 3d | 2023-06-26 | 2023-06-28 | 269 | 0d |  |
| 276 |  | Pintura bituminosa | resource dependent | 5d | 2023-06-29 | 2023-07-03 | 270, 274 | 0d |  |

| ID | WBS | Activity | Type | Duration | Start | Finish | Predecessors | Total float | Free float |
| --- | --- | --- | --- | --- | --- | --- | --- | --- | --- |
|  | 8 | **FRENTE 2** |  |  | 2023-04-22 | 2024-05-24 |  |  |  |
|  | 1 | **DIQUE DI-PR-12-I (PAQUETE 2)** |  |  | 2023-04-22 | 2023-11-01 |  |  |  |
|  | 1 | **Excavaciones** |  |  | 2023-04-22 | 2023-08-03 |  |  |  |
| 328 |  | Desbroce | resource dependent | 7d | 2023-04-22 | 2023-04-28 | 3 SS+20d, 23 FS-10d, 748 | 7d | 0d |
| 334 |  | Conformación de material excedente en DMO | resource dependent | 13d | 2023-04-22 | 2023-05-04 | 351 FS-7d, 352 FS-7d | 393d |  |
| 329 |  | Remoción de dique existente | resource dependent | 14d | 2023-04-29 | 2023-05-12 | 328 | 7d | 0d |
| 333 |  | Conformación de material excedente en DME | resource dependent | 97d | 2023-04-29 | 2023-08-03 | 353 FS-97d, 354 FS-97d | 302d |  |
| 330 |  | Excavación de cimentación | resource dependent | 27d | 2023-05-13 | 2023-06-08 | 329 | 7d | 0d |
| 331 |  | Perfilado y conformación de Plataforma de fundación | resource dependent | 33d | 2023-05-20 | 2023-06-21 | 330 FS-20d | 7d | 0d |
| 332 |  | Excavación de uña | resource dependent | 53d | 2023-06-09 | 2023-07-31 | 330 | 17d | 0d |
| 335 |  | Excavación Localizada - Sobreexcavación | resource dependent | 3d | 2023-08-01 | 2023-08-03 | 332 | 17d | 0d |
|  | 2 | **Rellenos** |  |  | 2023-05-30 | 2023-11-01 |  |  |  |
| 337 |  | Relleno con material granular (incluye extracción de material, zarandeo y combinación de material) | resource dependent | 47d | 2023-05-30 | 2023-07-15 | 331 FS-23d | 7d | 0d |
| 340 |  | Perfilado de Talud del dique | resource dependent | 19d | 2023-07-04 | 2023-07-22 | 337 FS-12d | 7d | 0d |
| 341 |  | Relleno con material seleccionado (incluye extracción de material, zarandeo y combinación de material) en sobreexcavación | resource dependent | 46d | 2023-07-16 | 2023-08-30 | 337 | 254d | 0d |
| 342 |  | Grava para Drenaje | resource dependent | 21d | 2023-08-31 | 2023-09-20 | 341 | 254d |  |
| 338 |  | Relleno sin compactar | resource dependent | 31d | 2023-09-21 | 2023-10-21 | 348 FS-31d | 212d | 0d |
| 339 |  | Relleno afirmado | resource dependent | 11d | 2023-10-22 | 2023-11-01 | 338 | 212d | 0d |
|  | 3 | **Geotextil** |  |  | 2023-07-11 | 2023-08-29 |  |  |  |
| 345 |  | Zanja de anclaje | resource dependent | 49d | 2023-07-11 | 2023-08-28 | 340 FS-12d | 7d | 0d |
| 344 |  | Instalación de Geotextil 400 gr/m2 | resource dependent | 49d | 2023-07-12 | 2023-08-29 | 345 FS-48d | 7d | 0d |
|  | 4 | **Colocación de roca** |  |  | 2023-05-13 | 2023-10-21 |  |  |  |
| 349 |  | Extracción y Selección de Rocas Reutilizables (50% de roca utilizable) | resource dependent | 66d | 2023-05-13 | 2023-07-17 | 329 | 7d | 0d |
| 347 |  | Colocación de roca en uña | resource dependent | 81d | 2023-07-18 | 2023-10-06 | 344 FS-43d, 491, 349 | 7d | 0d |
| 348 |  | Colocación de roca en Talud | resource dependent | 65d | 2023-08-18 | 2023-10-21 | 347 FS-50d | 7d | 0d |

| ID | WBS | Activity | Type | Duration | Start | Finish | Predecessors | Total float | Free float |
| --- | --- | --- | --- | --- | --- | --- | --- | --- | --- |
|  | 5 | **Transportes** |  |  | 2023-04-22 | 2023-11-01 |  |  |  |
| 351 |  | Transporte de material orgánico (a DMO) D<=1km | resource dependent | 7d | 2023-04-22 | 2023-04-28 | 328 SS | 393d | 0d |
| 352 |  | Transporte de material orgánico (a DMO) D>1km | resource dependent | 7d | 2023-04-22 | 2023-04-28 | 328 SS | 393d | 0d |
| 353 |  | Transporte de material excedente (dique provisional) D<=1km | resource dependent | 97d | 2023-04-29 | 2023-08-03 | 329 SS, 335 FF | 302d | 0d |
| 354 |  | Transporte de material excedente (dique provisional) D> 1km | resource dependent | 97d | 2023-04-29 | 2023-08-03 | 329 SS, 335 FF | 302d | 0d |
| 359 |  | Transporte de material de préstamo cantera de rio (cuerpo de terraplén) D<=1km | resource dependent | 47d | 2023-05-30 | 2023-07-15 | 337 SS | 321d |  |
| 360 |  | Transporte de material de préstamo cantera de rio (cuerpo de terraplén) D>1km | resource dependent | 47d | 2023-05-30 | 2023-07-15 | 337 SS | 321d |  |
| 361 |  | Transporte de material seleccionado para zanja D<=1km | resource dependent | 49d | 2023-07-11 | 2023-08-28 | 345 SS | 277d |  |
| 362 |  | Transporte de material seleccionado para zanja D>1km | resource dependent | 49d | 2023-07-11 | 2023-08-28 | 345 SS | 277d |  |
| 357 |  | Transporte de roca D<=1km | resource dependent | 96d | 2023-07-18 | 2023-10-21 | 347 SS, 348 FF | 223d |  |
| 358 |  | Transporte de roca D>1km | resource dependent | 96d | 2023-07-18 | 2023-10-21 | 347 SS, 348 FF | 223d |  |
| 355 |  | Transporte de material de préstamo (afirmado) D<=1km | resource dependent | 11d | 2023-10-22 | 2023-11-01 | 339 SS | 212d |  |
| 356 |  | Transporte de material de préstamo (afirmado) D>1km | resource dependent | 11d | 2023-10-22 | 2023-11-01 | 339 SS | 212d |  |
|  | 2 | **DIQUE DI-PR-13-D (PAQUETE 3)** |  |  | 2023-07-31 | 2024-01-03 |  |  |  |
|  | 1 | **Excavaciones** |  |  | 2023-07-31 | 2023-09-30 |  |  |  |
| 365 |  | Desbroce | resource dependent | 4d | 2023-07-31 | 2023-08-03 | 494 | 17d | 0d |
| 371 |  | Conformación de material excedente en DMO | resource dependent | 7d | 2023-07-31 | 2023-08-06 | 388 FS-4d, 389 FS-4d | 299d |  |
| 366 |  | Remoción de dique existente | resource dependent | 17d | 2023-08-04 | 2023-08-20 | 335, 365 | 17d | 0d |
| 370 |  | Conformación de material excedente en DME | resource dependent | 58d | 2023-08-04 | 2023-09-30 | 390 FS-58d, 391 FS-58d | 244d |  |
| 367 |  | Excavación de cimentación | resource dependent | 19d | 2023-08-21 | 2023-09-08 | 366 | 17d | 0d |
| 368 |  | Perfilado y conformación de Plataforma de fundación | resource dependent | 16d | 2023-08-29 | 2023-09-13 | 367 FS-11d | 213d | 0d |
| 369 |  | Excavación de uña | resource dependent | 20d | 2023-09-09 | 2023-09-28 | 367 | 17d | 0d |
| 372 |  | Excavación Localizada - Sobreexcavación | resource dependent | 2d | 2023-09-29 | 2023-09-30 | 369 | 17d | 0d |
|  | 2 | **Rellenos** |  |  | 2023-09-14 | 2024-01-03 |  |  |  |
| 374 |  | Relleno con material granular (incluye extracción de material, zarandeo y combinación de material) | resource dependent | 25d | 2023-09-14 | 2023-10-08 | 368 | 213d | 0d |
| 377 |  | Perfilado de Talud del dique | resource dependent | 13d | 2023-10-01 | 2023-10-13 | 374 FS-8d | 213d | 0d |
| 378 |  | Relleno con material seleccionado (incluye extracción de material, zarandeo y combinación de material) en sobreexcavación | resource dependent | 19d | 2023-10-09 | 2023-10-27 | 374 | 215d | 0d |
| 379 |  | Grava para Drenaje | resource dependent | 2d | 2023-10-28 | 2023-10-29 | 378 | 215d |  |
| 375 |  | Relleno sin compactar | resource dependent | 18d | 2023-12-12 | 2023-12-29 | 385 FS-18d | 149d | 0d |
| 376 |  | Relleno afirmado | resource dependent | 5d | 2023-12-30 | 2024-01-03 | 375 | 149d | 0d |

| ID | WBS | Activity | Type | Duration | Start | Finish | Predecessors | Total float | Free float |
| --- | --- | --- | --- | --- | --- | --- | --- | --- | --- |
|  | 3 | **Geotextil** |  |  | 2023-10-06 | 2023-10-31 |  |  |  |
| 382 |  | Zanja de anclaje | resource dependent | 25d | 2023-10-06 | 2023-10-30 | 377 FS-8d | 213d | 0d |
| 381 |  | Instalación de Geotextil 400 gr/m2 | resource dependent | 25d | 2023-10-07 | 2023-10-31 | 382 FS-24d | 213d |  |
|  | 4 | **Colocación de roca** |  |  | 2023-08-21 | 2023-12-29 |  |  |  |
| 386 |  | Extracción y Selección de Rocas Reutilizables (50% de roca utilizable) | resource dependent | 51d | 2023-08-21 | 2023-10-10 | 366 | 17d | 0d |
| 384 |  | Colocación de roca en uña | resource dependent | 61d | 2023-10-07 | 2023-12-06 | 347, 518, 386 FS-4d | 17d | 0d |
| 385 |  | Colocación de roca en Talud | resource dependent | 69d | 2023-10-22 | 2023-12-29 | 348 | 7d | 0d |
|  | 5 | **Transportes** |  |  | 2023-07-31 | 2024-01-03 |  |  |  |
| 388 |  | Transporte de material orgánico (a DMO) D<=1km | resource dependent | 4d | 2023-07-31 | 2023-08-03 | 365 SS | 299d | 0d |
| 389 |  | Transporte de material orgánico (a DMO) D>1km | resource dependent | 4d | 2023-07-31 | 2023-08-03 | 365 SS | 299d | 0d |
| 390 |  | Transporte de material excedente (dique provisional) D<=1km | resource dependent | 58d | 2023-08-04 | 2023-09-30 | 366 SS, 372 FF | 244d | 0d |
| 391 |  | Transporte de material excedente (dique provisional) D> 1km | resource dependent | 58d | 2023-08-04 | 2023-09-30 | 366 SS, 372 FF | 244d | 0d |
| 396 |  | Transporte de material de préstamo cantera de rio (cuerpo de terraplén) D<=1km | resource dependent | 25d | 2023-09-14 | 2023-10-08 | 374 SS | 236d |  |
| 397 |  | Transporte de material de préstamo cantera de rio (cuerpo de terraplén) D>1km | resource dependent | 25d | 2023-09-14 | 2023-10-08 | 374 SS | 236d |  |
| 398 |  | Transporte de material seleccionado para zanja D<= 1km | resource dependent | 25d | 2023-10-06 | 2023-10-30 | 382 SS | 214d |  |
| 399 |  | Transporte de material seleccionado para zanja D> 1km | resource dependent | 25d | 2023-10-06 | 2023-10-30 | 382 SS | 214d |  |
| 394 |  | Transporte de roca D<=1km | resource dependent | 84d | 2023-10-07 | 2023-12-29 | 384 SS, 385 FF | 154d |  |
| 395 |  | Transporte de roca D>1km | resource dependent | 84d | 2023-10-07 | 2023-12-29 | 384 SS, 385 FF | 154d |  |
| 392 |  | Transporte de material de préstamo (afirmado) D<=1km | resource dependent | 5d | 2023-12-30 | 2024-01-03 | 376 SS | 149d |  |
| 393 |  | Transporte de material de préstamo (afirmado) D>1km | resource dependent | 5d | 2023-12-30 | 2024-01-03 | 376 SS | 149d |  |
|  | 5 | **Obras Civiles DI-PR-12-I (PAQUETE 2)** |  |  | 2023-04-22 | 2023-07-17 |  |  |  |
| 465 |  | Trazo y replanteo de interferencia | resource dependent | 32d | 2023-04-22 | 2023-05-23 | 3 SS+20d, 23 FS-10d | 374d |  |
| 468 |  | Limpieza de terreno manual | resource dependent | 4d | 2023-04-22 | 2023-04-25 | 3 SS+20d, 23 FS-10d | 7d | 0d |
| 466 |  | Desvío provisional con tubería | resource dependent | 9d | 2023-04-26 | 2023-05-04 | 468 | 7d | 0d |
| 467 |  | Desvío provisional en tierras | resource dependent | 13d | 2023-05-05 | 2023-05-17 | 466 | 7d | 0d |
| 469 |  | Excavaciones no clasificada para estructuras | resource dependent | 3d | 2023-05-18 | 2023-05-20 | 467 | 7d | 0d |
| 470 |  | Excavacion no clasificada de zanja | resource dependent | 12d | 2023-05-21 | 2023-06-01 | 469 | 7d | 0d |
| 472 |  | Suministro de roca (Alcantarillas) | resource dependent | 5d | 2023-06-02 | 2023-06-06 | 470 | 7d | 0d |
| 484 |  | Cama de arena e=0.20m | resource dependent | 5d | 2023-06-02 | 2023-06-06 | 470 | 31d | 0d |
| 473 |  | Colocación de roca en uña (Alcantarillas) | resource dependent | 2d | 2023-06-07 | 2023-06-08 | 472 | 7d | 0d |
| 485 |  | Tubería HDPE Corrugada Ø=900mm (Suministro e instalación) | resource dependent | 2d | 2023-06-07 | 2023-06-08 | 484 | 31d | 0d |
| 471 |  | Relleno estructural | resource dependent | 11d | 2023-06-09 | 2023-06-19 | 473 | 7d | 0d |
| 486 |  | Tubería HDPE Corrugada Ø=1200mm (Suministro e instalación) | resource dependent | 2d | 2023-06-09 | 2023-06-10 | 485 | 31d | 24d |
| 474 |  | Concreto de Nivelacion (f'c=100 kg/cm2) | resource dependent | 2d | 2023-06-20 | 2023-06-21 | 471 | 7d | 0d |
| 479 |  | Encofrado y Desencofrado Cara Oculta | resource dependent | 7d | 2023-06-20 | 2023-06-26 | 471 | 7d | 0d |
| 480 |  | Acero de refuerzo f'y=4200kg/cm2 | resource dependent | 12d | 2023-06-20 | 2023-07-01 | 471 | 7d | 0d |
| 475 |  | Concreto Clase F (f'c=140 kg/cm2) | resource dependent | 3d | 2023-06-22 | 2023-06-24 | 474 | 7d | 0d |
| 476 |  | Concreto Clase C (f'c=280 kg/cm2) Premezclado - Cimientos reforzados | resource dependent | 3d | 2023-06-25 | 2023-06-27 | 475, 479 FS-2d, 480 FS-7d | 7d | 0d |
| 478 |  | Encofrado y Desencofrado Caravista | resource dependent | 5d | 2023-06-27 | 2023-07-01 | 479 | 7d | 0d |
| 477 |  | Concreto Clase C (f'c=280 kg/cm2) Premezclado - Muros de contencion | resource dependent | 5d | 2023-06-28 | 2023-07-02 | 476, 478 FS-4d | 7d | 0d |
| 481 |  | Emboquillado de piedra e=0.20m | resource dependent | 2d | 2023-07-03 | 2023-07-04 | 477 | 325d | 0d |
| 490 |  | Waterstop (anillos de estanqueidad) | resource dependent | 2d | 2023-07-03 | 2023-07-04 | 477 | 7d | 0d |
| 492 |  | Relleno con material granular (incluye extracción de material, zarandeo y combinación de material) | resource dependent | 11d | 2023-07-03 | 2023-07-13 | 477 | 323d |  |
| 482 |  | Emboquillado de piedra e=0.30m | resource dependent | 5d | 2023-07-05 | 2023-07-09 | 481 | 325d | 0d |
| 487 |  | Compuertas Charnela Ø900 (Suministro e instalacion) | resource dependent | 4d | 2023-07-05 | 2023-07-08 | 490, 486 | 7d | 0d |
| 488 |  | Compuertas Charnela Ø1200 (Suministro e instalacion) | resource dependent | 3d | 2023-07-09 | 2023-07-11 | 487 | 7d | 0d |
| 483 |  | Emboquillado de piedra e=0.50m | resource dependent | 2d | 2023-07-10 | 2023-07-11 | 482 | 325d |  |
| 489 |  | Sello en juntas | resource dependent | 2d | 2023-07-12 | 2023-07-13 | 488 | 7d | 0d |
| 491 |  | Pintura bituminosa | resource dependent | 4d | 2023-07-14 | 2023-07-17 | 489 | 7d | 0d |

| ID | WBS | Activity | Type | Duration | Start | Finish | Predecessors | Total float | Free float |
| --- | --- | --- | --- | --- | --- | --- | --- | --- | --- |
|  | 6 | **Obras Civiles DI-PR-13-D (PAQUETE 3)** |  |  | 2023-07-03 | 2023-10-06 |  |  |  |
| 494 |  | Trazo y replanteo de interferencia | resource dependent | 28d | 2023-07-03 | 2023-07-30 | 4 SS | 17d | 0d |
| 497 |  | Limpieza de terreno manual | resource dependent | 3d | 2023-07-03 | 2023-07-05 | 4 SS | 17d | 0d |
| 495 |  | Desvío provisional con tubería | resource dependent | 12d | 2023-07-06 | 2023-07-17 | 497 | 17d | 0d |
| 496 |  | Desvío provisional en tierras | resource dependent | 10d | 2023-07-18 | 2023-07-27 | 495 | 17d | 0d |
| 498 |  | Excavaciones no clasificada para estructuras | resource dependent | 3d | 2023-07-28 | 2023-07-30 | 496 | 17d | 0d |
| 499 |  | Excavacion no clasificada de zanja | resource dependent | 14d | 2023-07-31 | 2023-08-13 | 498 | 17d | 0d |
| 501 |  | Suministro de roca (Alcantarillas) | resource dependent | 14d | 2023-08-14 | 2023-08-27 | 499 | 17d | 0d |
| 512 |  | Cama de arena e=0.20m | resource dependent | 4d | 2023-08-14 | 2023-08-17 | 499 | 52d | 0d |
| 513 |  | Tubería HDPE Corrugada Ø=900mm (Suministro e instalación) | resource dependent | 2d | 2023-08-18 | 2023-08-19 | 512 | 52d | 0d |
| 514 |  | Tubería HDPE Corrugada Ø=1200mm (Suministro e instalación) | resource dependent | 2d | 2023-08-20 | 2023-08-21 | 513 | 52d | 35d |
| 502 |  | Colocación de roca en uña (Alcantarillas) | resource dependent | 6d | 2023-08-28 | 2023-09-02 | 501 | 17d | 0d |
| 500 |  | Relleno estructural | resource dependent | 10d | 2023-09-03 | 2023-09-12 | 502 | 17d | 0d |
| 503 |  | Concreto de Nivelacion (f'c=100 kg/cm2) | resource dependent | 3d | 2023-09-11 | 2023-09-13 | 500 FS-2d | 17d | 0d |
| 507 |  | Encofrado y Desencofrado Cara Oculta | resource dependent | 6d | 2023-09-11 | 2023-09-16 | 500 FS-2d | 17d | 0d |
| 508 |  | Acero de refuerzo f'y=4200kg/cm2 | resource dependent | 10d | 2023-09-12 | 2023-09-21 | 500 FS-1d | 17d | 0d |
| 504 |  | Concreto Clase C (f'c=280 kg/cm2) Premezclado - Cimientos reforzados | resource dependent | 4d | 2023-09-14 | 2023-09-17 | 503, 507 FS-3d, 508 FS-8d | 17d | 0d |
| 506 |  | Encofrado y Desencofrado Caravista | resource dependent | 5d | 2023-09-17 | 2023-09-21 | 507 | 17d | 0d |
| 505 |  | Concreto Clase C (f'c=280 kg/cm2) Premezclado - Muros de contencion | resource dependent | 6d | 2023-09-18 | 2023-09-23 | 504, 506 FS-4d | 17d | 0d |
| 509 |  | Emboquillado de piedra e=0.20m | resource dependent | 2d | 2023-09-24 | 2023-09-25 | 505 | 240d | 0d |
| 517 |  | Waterstop (anillos de estanqueidad) | resource dependent | 2d | 2023-09-24 | 2023-09-25 | 505 | 17d | 0d |
| 519 |  | Relleno con material granular (incluye extracción de material, zarandeo y combinación de material) | resource dependent | 3d | 2023-09-24 | 2023-09-26 | 505 | 248d |  |
| 520 |  | Concreto clase D (fc=210 kg/cm2) premezclado-cimientos reforzados | resource dependent | 2d | 2023-09-24 | 2023-09-25 | 505 | 238d | 0d |
| 521 |  | Baranda metálica en acero ø 1 1/2" h=1.00m | resource dependent | 2d | 2023-09-25 | 2023-09-26 | 520 FS-1d | 248d |  |
| 510 |  | Emboquillado de piedra e=0.30m | resource dependent | 6d | 2023-09-26 | 2023-10-01 | 509 | 240d | 0d |
| 515 |  | Compuertas Charnela Ø1200 (Suministro e instalacion) | resource dependent | 2d | 2023-09-26 | 2023-09-27 | 514, 517 | 17d | 0d |
| 522 |  | Compuerta plana mural 1.40mx1.40m (suministro e instalación) | resource dependent | 2d | 2023-09-26 | 2023-09-27 | 520 | 238d | 0d |
| 523 |  | Rejilla metalica de 1.80mx(2.68m-3.03m) (suministro e instalación) | resource dependent | 5d | 2023-09-27 | 2023-10-01 | 522 FS-1d | 238d | 0d |
| 516 |  | Sello en juntas | resource dependent | 2d | 2023-09-28 | 2023-09-29 | 515 | 17d | 0d |
| 524 |  | Compuerta plana mural 1.10mx1.10m (suministro e instalacion) | resource dependent | 6d | 2023-09-28 | 2023-10-03 | 523 FS-4d | 238d | 0d |
| 518 |  | Pintura bituminosa | resource dependent | 7d | 2023-09-30 | 2023-10-06 | 516 | 17d | 0d |
| 511 |  | Emboquillado de piedra e=0.50m | resource dependent | 3d | 2023-10-02 | 2023-10-04 | 510 | 240d |  |
| 525 |  | Rejilla metalica de 1.80mx(2.23m-2.52m) (suministro e instalación) | resource dependent | 5d | 2023-10-02 | 2023-10-06 | 524 FS-2d | 238d |  |

| ID | WBS | Activity | Type | Duration | Start | Finish | Predecessors | Total float | Free float |
| --- | --- | --- | --- | --- | --- | --- | --- | --- | --- |
|  | 7 | **Obras Civiles DI-PR-17-D (PAQUETE 3)** |  |  | 2023-08-04 | 2023-10-11 |  |  |  |
| 527 |  | Trazo y replanteo de interferencia | resource dependent | 14d | 2023-08-04 | 2023-08-17 | 365 | 17d | 0d |
| 529 |  | Limpieza de terreno manual | resource dependent | 14d | 2023-08-04 | 2023-08-17 | 365 | 73d | 0d |
| 528 |  | Desvío provisional en tierras | resource dependent | 41d | 2023-08-18 | 2023-09-27 | 527, 529 | 73d | 0d |
| 530 |  | Excavacion no clasificada de zanja | resource dependent | 12d | 2023-09-28 | 2023-10-09 | 528 | 73d | 0d |
| 531 |  | Relleno estructural | resource dependent | 2d | 2023-10-10 | 2023-10-11 | 530 | 73d | 56d |
|  | 3 | **DIQUE DI-PR-17-D (PAQUETE 3)** |  |  | 2023-09-29 | 2024-03-16 |  |  |  |
|  | 1 | **Excavaciones** |  |  | 2023-09-29 | 2023-10-30 |  |  |  |
| 402 |  | Desbroce | resource dependent | 2d | 2023-09-29 | 2023-09-30 | 533 FS+38d | 17d | 0d |
| 403 |  | Remoción de dique existente | resource dependent | 17d | 2023-10-01 | 2023-10-17 | 372, 402 | 17d | 0d |
| 404 |  | Excavación de cimentación | resource dependent | 6d | 2023-10-18 | 2023-10-23 | 403 | 17d | 0d |
| 405 |  | Perfilado y conformación de Plataforma de fundación | resource dependent | 7d | 2023-10-24 | 2023-10-30 | 404 | 17d | 0d |
| 406 |  | Excavación de uña | resource dependent | 6d | 2023-10-24 | 2023-10-29 | 404 | 215d | 0d |
|  | 2 | **Rellenos** |  |  | 2023-10-31 | 2024-03-16 |  |  |  |
| 408 |  | Relleno con material granular (incluye extracción de material, zarandeo y combinación de material) | resource dependent | 24d | 2023-10-31 | 2023-11-23 | 405 | 17d | 0d |
| 411 |  | Perfilado de Talud del dique | resource dependent | 6d | 2023-11-24 | 2023-11-29 | 408 | 17d | 0d |
| 409 |  | Relleno sin compactar | resource dependent | 5d | 2024-03-09 | 2024-03-13 | 417 FS-5d | 76d | 0d |
| 410 |  | Relleno afirmado | resource dependent | 3d | 2024-03-14 | 2024-03-16 | 409 | 76d | 0d |
|  | 3 | **Geotextil** |  |  | 2023-11-30 | 2023-12-10 |  |  |  |
| 414 |  | Zanja de anclaje | resource dependent | 10d | 2023-11-30 | 2023-12-09 | 411 | 17d | 0d |
| 413 |  | Instalación de Geotextil 400 gr/m2 | resource dependent | 10d | 2023-12-01 | 2023-12-10 | 414 FS-9d | 17d | 0d |
|  | 4 | **Colocación de roca** |  |  | 2023-10-18 | 2024-03-13 |  |  |  |
| 418 |  | Extracción y Selección de Rocas Reutilizables (50% de roca utilizable) | resource dependent | 50d | 2023-10-18 | 2023-12-06 | 403 | 17d | 0d |
| 416 |  | Colocación de roca en uña | resource dependent | 98d | 2023-12-07 | 2024-03-13 | 384, 531, 413 FS-4d, 418 | 17d | 0d |
| 417 |  | Colocación de roca en Talud | resource dependent | 75d | 2023-12-30 | 2024-03-13 | 385 | 7d | 0d |

| ID | WBS | Activity | Type | Duration | Start | Finish | Predecessors | Total float | Free float |
| --- | --- | --- | --- | --- | --- | --- | --- | --- | --- |
|  | 5 | **Transportes** |  |  | 2023-09-29 | 2024-03-16 |  |  |  |
| 420 |  | Transporte de material orgánico (a DMO) D<=1km | resource dependent | 2d | 2023-09-29 | 2023-09-30 | 402 SS | 244d |  |
| 421 |  | Transporte de material orgánico (a DMO) D>1km | resource dependent | 2d | 2023-09-29 | 2023-09-30 | 402 SS | 244d |  |
| 422 |  | Transporte de material excedente (dique provisional) D<=1km | resource dependent | 29d | 2023-10-01 | 2023-10-29 | 403 SS, 406 FF | 215d |  |
| 423 |  | Transporte de material excedente (dique provisional) D> 1km | resource dependent | 29d | 2023-10-01 | 2023-10-29 | 403 SS, 406 FF | 215d |  |
| 428 |  | Transporte de material de préstamo cantera de rio (cuerpo de terraplén) D<=1km | resource dependent | 24d | 2023-10-31 | 2023-11-23 | 408 SS | 190d |  |
| 429 |  | Transporte de material de préstamo cantera de rio (cuerpo de terraplén) D>1km | resource dependent | 24d | 2023-10-31 | 2023-11-23 | 408 SS | 190d |  |
| 430 |  | Transporte de material seleccionado para zanja D<= 1km | resource dependent | 10d | 2023-11-30 | 2023-12-09 | 414 SS | 174d |  |
| 431 |  | Transporte de material seleccionado para zanja D> 1km | resource dependent | 10d | 2023-11-30 | 2023-12-09 | 414 SS | 174d |  |
| 426 |  | Transporte de roca D<=1km | resource dependent | 98d | 2023-12-07 | 2024-03-13 | 416 SS, 417 FF | 79d |  |
| 427 |  | Transporte de roca D>1km | resource dependent | 98d | 2023-12-07 | 2024-03-13 | 416 SS, 417 FF | 79d |  |
| 424 |  | Transporte de material de préstamo (afirmado) D<=1km | resource dependent | 3d | 2024-03-14 | 2024-03-16 | 410 SS | 76d |  |
| 425 |  | Transporte de material de préstamo (afirmado) D>1km | resource dependent | 3d | 2024-03-14 | 2024-03-16 | 410 SS | 76d |  |
|  | 4 | **DIQUE DI-PR-16-D (PAQUETE 3)** |  |  | 2024-02-03 | 2024-05-24 |  |  |  |
|  | 1 | **Excavaciones** |  |  | 2024-02-03 | 2024-02-27 |  |  |  |
| 434 |  | Desbroce | resource dependent | 2d | 2024-02-03 | 2024-02-04 | 402 FS+125d | 17d | 0d |
| 435 |  | Remoción de dique existente | resource dependent | 6d | 2024-02-05 | 2024-02-10 | 434 | 17d | 0d |
| 436 |  | Excavación de cimentación | resource dependent | 3d | 2024-02-11 | 2024-02-13 | 435 | 17d | 0d |
| 437 |  | Perfilado y conformación de Plataforma de fundación | resource dependent | 4d | 2024-02-14 | 2024-02-17 | 436 | 17d | 0d |
| 438 |  | Excavación de uña | resource dependent | 11d | 2024-02-14 | 2024-02-24 | 436 | 94d | 0d |
| 439 |  | Excavación Localizada - Sobreexcavación | resource dependent | 3d | 2024-02-25 | 2024-02-27 | 438 | 94d | 0d |
|  | 2 | **Rellenos** |  |  | 2024-02-18 | 2024-05-24 |  |  |  |
| 441 |  | Relleno con material granular (incluye extracción de material, zarandeo y combinación de material) | resource dependent | 9d | 2024-02-18 | 2024-02-26 | 437 | 17d | 0d |
| 444 |  | Perfilado de Talud del dique | resource dependent | 3d | 2024-02-27 | 2024-02-29 | 441 | 17d | 0d |
| 445 |  | Relleno con material seleccionado (incluye extracción de material, zarandeo y combinación de material) en sobreexcavación | resource dependent | 31d | 2024-02-27 | 2024-03-28 | 441 | 64d |  |
| 442 |  | Relleno sin compactar | resource dependent | 7d | 2024-05-15 | 2024-05-21 | 451 | 7d | 0d |
| 443 |  | Relleno afirmado | resource dependent | 3d | 2024-05-22 | 2024-05-24 | 442 | 7d | 0d |

| ID | WBS | Activity | Type | Duration | Start | Finish | Predecessors | Total float | Free float |
| --- | --- | --- | --- | --- | --- | --- | --- | --- | --- |
|  | 3 | **Geotextil** |  |  | 2024-03-01 | 2024-03-13 |  |  |  |
| 448 |  | Zanja de anclaje | resource dependent | 12d | 2024-03-01 | 2024-03-12 | 444 | 17d | 0d |
| 447 |  | Instalación de Geotextil 400 gr/m2 | resource dependent | 12d | 2024-03-02 | 2024-03-13 | 448 FS-11d | 17d | 0d |
|  | 4 | **Colocación de roca** |  |  | 2024-02-11 | 2024-05-14 |  |  |  |
| 452 |  | Extracción y Selección de Rocas Reutilizables (50% de roca utilizable) | resource dependent | 44d | 2024-02-11 | 2024-03-25 | 435 | 17d | 0d |
| 450 |  | Colocación de roca en uña | resource dependent | 58d | 2024-03-14 | 2024-05-10 | 416, 559, 447, 452 FS-12d | 17d | 0d |
| 451 |  | Colocación de roca en Talud | resource dependent | 62d | 2024-03-14 | 2024-05-14 | 417 | 7d | 0d |
|  | 5 | **Transportes** |  |  | 2024-02-03 | 2024-05-24 |  |  |  |
| 454 |  | Transporte de material orgánico (a DMO) D<=1km | resource dependent | 2d | 2024-02-03 | 2024-02-04 | 434 SS | 117d |  |
| 455 |  | Transporte de material orgánico (a DMO) D>1km | resource dependent | 2d | 2024-02-03 | 2024-02-04 | 434 SS | 117d |  |
| 456 |  | Transporte de material excedente (dique provisional) D<=1km | resource dependent | 23d | 2024-02-05 | 2024-02-27 | 435 SS, 439 FF | 94d |  |
| 457 |  | Transporte de material excedente (dique provisional) D> 1km | resource dependent | 23d | 2024-02-05 | 2024-02-27 | 435 SS, 439 FF | 94d |  |
| 462 |  | Transporte de material de préstamo cantera de rio (cuerpo de terraplén) D<=1km | resource dependent | 9d | 2024-02-18 | 2024-02-26 | 441 SS | 95d |  |
| 463 |  | Transporte de material seleccionado para zanja D<= 1km | resource dependent | 12d | 2024-03-01 | 2024-03-12 | 448 SS | 80d |  |
| 460 |  | Transporte de roca D<=1km | resource dependent | 62d | 2024-03-14 | 2024-05-14 | 450 SS, 451 FF | 17d |  |
| 461 |  | Transporte de roca D>1km | resource dependent | 62d | 2024-03-14 | 2024-05-14 | 450 SS, 451 FF | 17d |  |
| 458 |  | Transporte de material de préstamo (afirmado) D<=1km | resource dependent | 3d | 2024-05-22 | 2024-05-24 | 443 SS | 7d |  |
| 459 |  | Transporte de material de préstamo (afirmado) D>1km | resource dependent | 3d | 2024-05-22 | 2024-05-24 | 443 SS | 7d |  |
|  | 8 | **Obras Civiles DI-PR-16-D (PAQUETE 3)** |  |  | 2023-08-18 | 2023-10-26 |  |  |  |
| 533 |  | Trazo y replanteo de interferencia | resource dependent | 4d | 2023-08-18 | 2023-08-21 | 527 | 17d | 0d |
| 536 |  | Limpieza de terreno manual | resource dependent | 2d | 2023-08-18 | 2023-08-19 | 529 | 156d | 0d |
| 534 |  | Desvío provisional con tubería | resource dependent | 7d | 2023-08-20 | 2023-08-26 | 536 | 156d | 0d |
| 535 |  | Desvío provisional en tierras | resource dependent | 2d | 2023-08-27 | 2023-08-28 | 534 | 156d | 0d |
| 537 |  | Excavaciones no clasificada para estructuras | resource dependent | 4d | 2023-08-29 | 2023-09-01 | 535 | 156d | 0d |
| 538 |  | Excavacion no clasificada de zanja | resource dependent | 2d | 2023-09-02 | 2023-09-03 | 537 | 156d | 0d |
| 540 |  | Suministro de roca (Alcantarillas) | resource dependent | 10d | 2023-09-04 | 2023-09-13 | 538 | 156d | 0d |
| 541 |  | Colocación de roca en uña (Alcantarillas) | resource dependent | 3d | 2023-09-14 | 2023-09-16 | 540 | 156d | 0d |
| 539 |  | Relleno estructural | resource dependent | 7d | 2023-09-17 | 2023-09-23 | 541 | 156d | 0d |
| 547 |  | Encofrado y Desencofrado Cara Oculta | resource dependent | 9d | 2023-09-22 | 2023-09-30 | 539 FS-2d | 156d | 0d |
| 548 |  | Acero de refuerzo f'y=4200kg/cm2 | resource dependent | 14d | 2023-09-23 | 2023-10-06 | 539 FS-1d | 157d | 1d |
| 542 |  | Concreto de Nivelacion (f'c=100 kg/cm2) | resource dependent | 2d | 2023-09-24 | 2023-09-25 | 539 | 156d | 0d |
| 543 |  | Concreto Clase F (f'c=140 kg/cm2) | resource dependent | 3d | 2023-09-26 | 2023-09-28 | 542 | 156d | 0d |
| 544 |  | Concreto Clase C (f'c=280 kg/cm2) Premezclado - Cimientos reforzados | resource dependent | 3d | 2023-09-29 | 2023-10-01 | 543, 547 FS-2d, 548 FS-9d | 156d | 0d |
| 546 |  | Encofrado y Desencofrado Caravista | resource dependent | 6d | 2023-10-01 | 2023-10-06 | 547 | 157d | 1d |
| 545 |  | Concreto Clase C (f'c=280 kg/cm2) Premezclado - Muros de contencion | resource dependent | 6d | 2023-10-02 | 2023-10-07 | 544, 546 FS-6d | 156d | 0d |
| 554 |  | Suministro e instalacion de geotextil | resource dependent | 2d | 2023-10-06 | 2023-10-07 | 545 FS-2d | 237d |  |
| 549 |  | Emboquillado de piedra e=0.20m | resource dependent | 2d | 2023-10-08 | 2023-10-09 | 545 | 233d | 0d |
| 552 |  | Waterstop (anillos de estanqueidad) | resource dependent | 2d | 2023-10-08 | 2023-10-09 | 545 | 228d | 0d |
| 555 |  | Concreto clase D (fc=210 kg/cm2) premezclado-cimientos reforzados | resource dependent | 2d | 2023-10-08 | 2023-10-09 | 545 | 156d | 0d |
| 556 |  | Baranda metálica en acero ø 1 1/2" h=1.00m | resource dependent | 2d | 2023-10-09 | 2023-10-10 | 555 FS-1d | 234d |  |
| 550 |  | Emboquillado de piedra e=0.30m | resource dependent | 2d | 2023-10-10 | 2023-10-11 | 549 | 233d |  |
| 551 |  | Sello en juntas | resource dependent | 2d | 2023-10-10 | 2023-10-11 | 552 | 228d | 0d |
| 560 |  | Tubería astm a53 sch-40 dn300mm hd | resource dependent | 3d | 2023-10-10 | 2023-10-12 | 555 | 156d | 0d |
| 553 |  | Pintura bituminosa | resource dependent | 5d | 2023-10-12 | 2023-10-16 | 551 | 228d |  |
| 561 |  | Unión flexible tipo desser dn300mm hd | resource dependent | 2d | 2023-10-13 | 2023-10-14 | 560 | 156d | 0d |
| 562 |  | Niple espiga-espiga con brida rompeagua de ffd dn300mm l=0.50m | resource dependent | 2d | 2023-10-15 | 2023-10-16 | 561 | 156d | 0d |
| 557 |  | Compuerta plana tipo tarjeta 0.60mx0.30m(suministro e instalación) | resource dependent | 3d | 2023-10-17 | 2023-10-19 | 562 | 156d | 0d |
| 558 |  | Compuerta plana mural 2.20mx2.20m (suministro e instalación) | resource dependent | 2d | 2023-10-20 | 2023-10-21 | 557 | 156d | 0d |
| 559 |  | Rejilla metálica 2.00mx(2.30m-2.30m) (suministro e instalacion) | resource dependent | 5d | 2023-10-22 | 2023-10-26 | 558 | 156d | 139d |

| ID | WBS | Activity | Type | Duration | Start | Finish | Predecessors | Total float | Free float |
| --- | --- | --- | --- | --- | --- | --- | --- | --- | --- |
|  | 9 | **FRENTE 3** |  |  | 2023-07-03 | 2024-05-31 |  |  |  |
|  | 1 | **DIQUE DI-PR-19A-3-D (PAQUETE 3)** |  |  | 2023-07-03 | 2023-12-11 |  |  |  |
|  | 1 | **Excavaciones** |  |  | 2023-07-03 | 2023-09-06 |  |  |  |
| 566 |  | Desbroce | resource dependent | 5d | 2023-07-03 | 2023-07-07 | 4 SS | 0d |  |
| 572 |  | Conformación de material excedente en DMO | resource dependent | 11d | 2023-07-03 | 2023-07-13 | 588 FS-5d, 589 FS-5d | 323d |  |
| 567 |  | Remoción de dique existente | resource dependent | 20d | 2023-07-08 | 2023-07-27 | 566 | 0d |  |
| 571 |  | Conformación de material excedente en DME | resource dependent | 61d | 2023-07-08 | 2023-09-06 | 590 FS-61d, 591 FS-61d | 268d |  |
| 568 |  | Excavación de cimentación | resource dependent | 12d | 2023-07-28 | 2023-08-08 | 567 | 0d |  |
| 569 |  | Perfilado y conformación de Plataforma de fundación | resource dependent | 18d | 2023-07-29 | 2023-08-15 | 568 FS-11d | 0d |  |
| 570 |  | Excavación de uña | resource dependent | 25d | 2023-08-09 | 2023-09-02 | 568 | 0d |  |
| 573 |  | Excavación Localizada - Sobreexcavación | resource dependent | 4d | 2023-09-03 | 2023-09-06 | 570 | 0d |  |
|  | 2 | **Rellenos** |  |  | 2023-07-31 | 2023-12-11 |  |  |  |
| 575 |  | Relleno con material granular (incluye extracción de material, zarandeo y combinac | resource dependent | 20d | 2023-07-31 | 2023-08-19 | 569 FS-16d | 0d |  |
| 578 |  | Perfilado de Talud del dique | resource dependent | 10d | 2023-08-12 | 2023-08-21 | 575 FS-8d | 0d |  |
| 579 |  | Relleno con material seleccionado (incluye extracción de material, zarandeo y combinación de material) en sobreexcavación | resource dependent | 60d | 2023-08-20 | 2023-10-18 | 575 | 226d |  |
| 576 |  | Relleno sin compactar | resource dependent | 16d | 2023-11-21 | 2023-12-06 | 585 | 172d | 0d |
| 577 |  | Relleno afirmado | resource dependent | 5d | 2023-12-07 | 2023-12-11 | 576 | 172d | 0d |
|  | 3 | **Geotextil** |  |  | 2023-08-13 | 2023-09-10 |  |  |  |
| 582 |  | Zanja de anclaje | resource dependent | 28d | 2023-08-13 | 2023-09-09 | 578 FS-9d | 0d |  |
| 581 |  | Instalación de Geotextil 400 gr/m2 | resource dependent | 28d | 2023-08-14 | 2023-09-10 | 582 FS-27d | 0d |  |
|  | 4 | **Colocación de roca** |  |  | 2023-07-28 | 2023-11-20 |  |  |  |
| 586 |  | Extracción y Selección de Rocas Reutilizables (50% de roca utilizable) | resource dependent | 39d | 2023-07-28 | 2023-09-04 | 567 | 0d |  |
| 584 |  | Colocación de roca en uña | resource dependent | 69d | 2023-08-17 | 2023-10-24 | 581 FS-25d, 675 | 0d |  |
| 585 |  | Colocación de roca en Talud | resource dependent | 77d | 2023-09-05 | 2023-11-20 | 586, 584 FS-50d | 0d |  |

| ID | WBS | Activity | Type | Duration | Start | Finish | Predecessors | Total float | Free float |
| --- | --- | --- | --- | --- | --- | --- | --- | --- | --- |
|  | 5 | **Transportes** |  |  | 2023-07-03 | 2023-12-11 |  |  |  |
| 588 |  | Transporte de material orgánico (a DMO) D<=1km | resource dependent | 5d | 2023-07-03 | 2023-07-07 | 566 SS | 323d | 0d |
| 589 |  | Transporte de material orgánico (a DMO) D>1km | resource dependent | 5d | 2023-07-03 | 2023-07-07 | 566 SS | 323d | 0d |
| 590 |  | Transporte de material excedente (dique provisional) D<=1km | resource dependent | 61d | 2023-07-08 | 2023-09-06 | 567 SS, 573 FF | 268d | 0d |
| 591 |  | Transporte de material excedente (dique provisional) D>1km | resource dependent | 61d | 2023-07-08 | 2023-09-06 | 567 SS, 573 FF | 268d | 0d |
| 596 |  | Transporte de material de préstamo cantera de rio (cuerpo de terraplén) D<=1km | resource dependent | 20d | 2023-07-31 | 2023-08-19 | 575 SS | 286d |  |
| 597 |  | Transporte de material de préstamo cantera de rio (cuerpo de terraplén) D>1km | resource dependent | 20d | 2023-07-31 | 2023-08-19 | 575 SS | 286d |  |
| 598 |  | Transporte de material seleccionado para zanja D<= 1km | resource dependent | 28d | 2023-08-13 | 2023-09-09 | 582 SS | 265d |  |
| 599 |  | Transporte de material seleccionado para zanja D>1km | resource dependent | 28d | 2023-08-13 | 2023-09-09 | 582 SS | 265d |  |
| 594 |  | Transporte de roca D<=1km | resource dependent | 96d | 2023-08-17 | 2023-11-20 | 584 SS, 585 FF | 193d |  |
| 595 |  | Transporte de roca D>1km | resource dependent | 96d | 2023-08-17 | 2023-11-20 | 584 SS, 585 FF | 193d |  |
| 592 |  | Transporte de material de préstamo (afirmado) D<=1km | resource dependent | 5d | 2023-12-07 | 2023-12-11 | 577 SS | 172d |  |
| 593 |  | Transporte de material de préstamo (afirmado) D>1km | resource dependent | 5d | 2023-12-07 | 2023-12-11 | 577 SS | 172d |  |
|  | 2 | **DIQUE DI-PR-19A-2-D (PAQUETE 3)** |  |  | 2023-08-31 | 2024-04-15 |  |  |  |
|  | 1 | **Excavaciones** |  |  | 2023-08-31 | 2023-11-15 |  |  |  |
| 602 |  | Desbroce | resource dependent | 7d | 2023-08-31 | 2023-09-06 | 566 FS+54d | 0d |  |
| 608 |  | Conformación de material excedente en DMO | resource dependent | 14d | 2023-08-31 | 2023-09-13 | 624 FS-7d, 625 FS-7d | 261d |  |
| 603 |  | Remoción de dique existente | resource dependent | 11d | 2023-09-07 | 2023-09-17 | 573, 602 | 0d |  |
| 607 |  | Conformación de material excedente en DME | resource dependent | 70d | 2023-09-07 | 2023-11-15 | 626 FS-70d, 627 FS-70d | 198d |  |
| 604 |  | Excavación de cimentación | resource dependent | 30d | 2023-09-18 | 2023-10-17 | 603 | 0d |  |
| 605 |  | Perfilado y conformación de Plataforma de fundación | resource dependent | 27d | 2023-09-26 | 2023-10-22 | 604 FS-22d | 0d |  |
| 606 |  | Excavación de uña | resource dependent | 26d | 2023-10-18 | 2023-11-12 | 604 | 0d |  |
| 609 |  | Excavación Localizada - Sobreexcavación | resource dependent | 3d | 2023-11-13 | 2023-11-15 | 606 | 0d |  |
|  | 2 | **Rellenos** |  |  | 2023-10-01 | 2024-04-15 |  |  |  |
| 611 |  | Relleno con material granular (incluye extracción de material, zarandeo y combinac | resource dependent | 35d | 2023-10-01 | 2023-11-04 | 605 FS-22d | 0d |  |
| 614 |  | Perfilado de Talud del dique | resource dependent | 16d | 2023-10-22 | 2023-11-06 | 611 FS-14d | 0d |  |
| 615 |  | Relleno con material seleccionado (incluye extracción de material, zarandeo y combinación de material) en sobreexcavación | resource dependent | 51d | 2023-11-05 | 2023-12-25 | 611 | 158d |  |
| 612 |  | Relleno sin compactar | resource dependent | 24d | 2024-03-13 | 2024-04-05 | 621 | 46d | 0d |
| 613 |  | Relleno afirmado | resource dependent | 10d | 2024-04-06 | 2024-04-15 | 612 | 46d | 0d |

| ID | WBS | Activity | Type | Duration | Start | Finish | Predecessors | Total float | Free float |
| --- | --- | --- | --- | --- | --- | --- | --- | --- | --- |
|  | 3 | **Geotextil** |  |  | 2023-10-23 | 2023-12-04 |  |  |  |
| 618 |  | Zanja de anclaje | resource dependent | 42d | 2023-10-23 | 2023-12-03 | 614 FS-15d | 0d |  |
| 617 |  | Instalación de Geotextil 400 gr/m2 | resource dependent | 42d | 2023-10-24 | 2023-12-04 | 618 FS-41d | 0d |  |
|  | 4 | **Colocación de roca** |  |  | 2023-09-18 | 2024-03-12 |  |  |  |
| 622 |  | Extracción y Selección de Rocas Reutilizables (50% de roca utilizable) | resource dependent | 53d | 2023-09-18 | 2023-11-09 | 603 | 204d |  |
| 620 |  | Colocación de roca en uña | resource dependent | 112d | 2023-10-25 | 2024-02-13 | 584, 617 FS-41d, 709 | 0d |  |
| 621 |  | Colocación de roca en Talud | resource dependent | 113d | 2023-11-21 | 2024-03-12 | 585 | 0d |  |
|  | 5 | **Transportes** |  |  | 2023-08-31 | 2024-04-15 |  |  |  |
| 624 |  | Transporte de material orgánico (a DMO) D<=1km | resource dependent | 7d | 2023-08-31 | 2023-09-06 | 602 SS | 261d | 0d |
| 625 |  | Transporte de material orgánico (a DMO) D>1km | resource dependent | 7d | 2023-08-31 | 2023-09-06 | 602 SS | 261d | 0d |
| 626 |  | Transporte de material excedente (dique provisional) D<=1km | resource dependent | 70d | 2023-09-07 | 2023-11-15 | 603 SS, 609 FF | 198d | 0d |
| 627 |  | Transporte de material excedente (dique provisional) D> 1km | resource dependent | 70d | 2023-09-07 | 2023-11-15 | 603 SS, 609 FF | 198d | 0d |
| 632 |  | Transporte de material de préstamo cantera de rio (cuerpo de terraplén) D<=1km | resource dependent | 35d | 2023-10-01 | 2023-11-04 | 611 SS | 209d |  |
| 633 |  | Transporte de material de préstamo cantera de rio (cuerpo de terraplén) D>1km | resource dependent | 35d | 2023-10-01 | 2023-11-04 | 611 SS | 209d |  |
| 634 |  | Transporte de material seleccionado para zanja D<= 1km | resource dependent | 42d | 2023-10-23 | 2023-12-03 | 618 SS | 180d |  |
| 635 |  | Transporte de material seleccionado para zanja D> 1km | resource dependent | 42d | 2023-10-23 | 2023-12-03 | 618 SS | 180d |  |
| 630 |  | Transporte de roca D<=1km | resource dependent | 140d | 2023-10-25 | 2024-03-12 | 620 SS, 621 FF | 80d |  |
| 631 |  | Transporte de roca D>1km | resource dependent | 140d | 2023-10-25 | 2024-03-12 | 620 SS, 621 FF | 80d |  |
| 628 |  | Transporte de material de préstamo (afirmado) D<=1km | resource dependent | 10d | 2024-04-06 | 2024-04-15 | 613 SS | 46d |  |
| 629 |  | Transporte de material de préstamo (afirmado) D>1km | resource dependent | 10d | 2024-04-06 | 2024-04-15 | 613 SS | 46d |  |
|  | 3 | **DIQUE DI-PR-19A-1-D (PAQUETE 3)** |  |  | 2023-11-13 | 2024-05-31 |  |  |  |
|  | 1 | **Excavaciones** |  |  | 2023-11-13 | 2023-12-17 |  |  |  |
| 638 |  | Desbroce | resource dependent | 3d | 2023-11-13 | 2023-11-15 | 602 FS+67d | 0d |  |
| 639 |  | Excavación de cimentación | resource dependent | 13d | 2023-11-16 | 2023-11-28 | 609, 638 | 0d |  |
| 640 |  | Perfilado y conformación de Plataforma de fundación | resource dependent | 10d | 2023-11-29 | 2023-12-08 | 639 | 0d |  |
| 641 |  | Excavación de uña | resource dependent | 16d | 2023-11-29 | 2023-12-14 | 639 | 166d | 0d |
| 642 |  | Excavación Localizada - Sobreexcavación | resource dependent | 3d | 2023-12-15 | 2023-12-17 | 641 | 166d | 0d |

| ID | WBS | Activity | Type | Duration | Start | Finish | Predecessors | Total float |
| --- | --- | --- | --- | --- | --- | --- | --- | --- |
|  | 2 | **Rellenos** |  |  | 2023-12-09 | 2024-05-31 |  |  |
| 644 |  | Relleno con material granular (incluye extracción de material, zarandeo y combinac | resource dependent | 35d | 2023-12-09 | 2024-01-12 | 640 | 0d |
| 647 |  | Perfilado de Talud del dique | resource dependent | 9d | 2024-01-13 | 2024-01-21 | 644 | 0d |
| 648 |  | Relleno con material seleccionado (incluye extracción de material, zarandeo y combinación de material) en sobreexcavación | resource dependent | 48d | 2024-01-13 | 2024-02-29 | 644 | 92d |
| 645 |  | Relleno sin compactar | resource dependent | 9d | 2024-05-20 | 2024-05-28 | 654 | 0d |
| 646 |  | Relleno afirmado | resource dependent | 3d | 2024-05-29 | 2024-05-31 | 645 | 0d |
|  | 3 | **Geotextil** |  |  | 2024-01-22 | 2024-02-21 |  |  |
| 651 |  | Zanja de anclaje | resource dependent | 30d | 2024-01-22 | 2024-02-20 | 647 | 0d |
| 650 |  | Instalación de Geotextil 400 gr/m2 | resource dependent | 30d | 2024-01-23 | 2024-02-21 | 651 FS-29d | 0d |
|  | 4 | **Colocación de roca** |  |  | 2024-02-14 | 2024-05-19 |  |  |
| 653 |  | Colocación de roca en uña | resource dependent | 72d | 2024-02-14 | 2024-04-25 | 620, 650 FS-8d, 735 | 0d |
| 654 |  | Colocación de roca en Talud | resource dependent | 68d | 2024-03-13 | 2024-05-19 | 621, 653 FS-44d | 0d |
|  | 5 | **Transportes** |  |  | 2023-11-13 | 2024-05-31 |  |  |
| 656 |  | Transporte de material orgánico (a DMO) D<=1km | resource dependent | 3d | 2023-11-13 | 2023-11-15 | 638 SS | 198d |
| 657 |  | Transporte de material orgánico (a DMO) D>1km | resource dependent | 3d | 2023-11-13 | 2023-11-15 | 638 SS | 198d |
| 658 |  | Transporte de material excedente (dique provisional) D<=1km | resource dependent | 32d | 2023-11-16 | 2023-12-17 | 639 SS, 642 FF | 166d |
| 659 |  | Transporte de material excedente (dique provisional) D> 1km | resource dependent | 32d | 2023-11-16 | 2023-12-17 | 639 SS, 642 FF | 166d |
| 664 |  | Transporte de material de préstamo cantera de rio (cuerpo de terraplén) D<=1km | resource dependent | 35d | 2023-12-09 | 2024-01-12 | 644 SS | 140d |
| 665 |  | Transporte de material de préstamo cantera de rio (cuerpo de terraplén) D>1km | resource dependent | 35d | 2023-12-09 | 2024-01-12 | 644 SS | 140d |
| 666 |  | Transporte de material seleccionado para zanja D<= 1km | resource dependent | 30d | 2024-01-22 | 2024-02-20 | 651 SS | 101d |
| 667 |  | Transporte de material seleccionado para zanja D> 1km | resource dependent | 30d | 2024-01-22 | 2024-02-20 | 651 SS | 101d |
| 662 |  | Transporte de roca D<=1km | resource dependent | 96d | 2024-02-14 | 2024-05-19 | 653 SS, 654 FF | 12d |
| 663 |  | Transporte de roca D>1km | resource dependent | 96d | 2024-02-14 | 2024-05-19 | 653 SS, 654 FF | 12d |
| 660 |  | Transporte de material de préstamo (afirmado) D<=1km | resource dependent | 3d | 2024-05-29 | 2024-05-31 | 646 SS | 0d |
| 661 |  | Transporte de material de préstamo (afirmado) D>1km | resource dependent | 3d | 2024-05-29 | 2024-05-31 | 646 SS | 0d |

| ID | WBS | Activity | Type | Duration | Start | Finish | Predecessors | Total float | Free float |
| --- | --- | --- | --- | --- | --- | --- | --- | --- | --- |
|  | 4 | **Obras Civiles DI-PR-19A-3-D (PAQUETE 3)** |  |  | 2023-07-03 | 2023-08-16 |  |  |  |
| 669 |  | Trazo y replanteo de interferencia | resource dependent | 30d | 2023-07-03 | 2023-08-01 | 4 SS | 304d |  |
| 671 |  | Limpieza de terreno manual | resource dependent | 3d | 2023-07-03 | 2023-07-05 | 4 SS | 0d |  |
| 670 |  | Desvío provisional en tierras | resource dependent | 14d | 2023-07-06 | 2023-07-19 | 671 | 0d |  |
| 672 |  | Excavacion no clasificada de zanja | resource dependent | 19d | 2023-07-20 | 2023-08-07 | 670 | 0d |  |
| 673 |  | Relleno estructural | resource dependent | 3d | 2023-08-08 | 2023-08-10 | 672 | 0d |  |
| 674 |  | Emboquillado de piedra e=0.20m | resource dependent | 4d | 2023-08-11 | 2023-08-14 | 673 | 0d |  |
| 675 |  | Sello en juntas | resource dependent | 2d | 2023-08-15 | 2023-08-16 | 674 | 0d |  |
|  | 5 | **Obras Civiles DI-PR-19A-2-D (PAQUETE 3)** |  |  | 2023-07-03 | 2023-10-24 |  |  |  |
| 677 |  | Trazo y replanteo de interferencia | resource dependent | 48d | 2023-07-03 | 2023-08-19 | 4 SS | 122d | 0d |
| 680 |  | Limpieza de terreno manual | resource dependent | 4d | 2023-07-03 | 2023-07-06 | 4 SS | 0d |  |
| 678 |  | Desvío provisional con tubería | resource dependent | 9d | 2023-07-07 | 2023-07-15 | 680 | 0d |  |
| 679 |  | Desvío provisional en tierras | resource dependent | 9d | 2023-07-16 | 2023-07-24 | 678 | 0d |  |
| 681 |  | Excavaciones no clasificada para estructuras | resource dependent | 4d | 2023-07-25 | 2023-07-28 | 679 | 0d |  |
| 682 |  | Excavacion no clasificada de zanja | resource dependent | 11d | 2023-07-29 | 2023-08-08 | 681 | 0d |  |
| 684 |  | Suministro de roca (Alcantarillas) | resource dependent | 11d | 2023-08-09 | 2023-08-19 | 682 | 0d |  |
| 695 |  | Cama de arena e=0.20m | resource dependent | 6d | 2023-08-09 | 2023-08-14 | 682 | 268d | 0d |
| 696 |  | Tubería HDPE Corrugada Ø=600mm (Suministro e instalación) | resource dependent | 2d | 2023-08-15 | 2023-08-16 | 695 | 268d | 0d |
| 697 |  | Tubería HDPE Corrugada Ø=900mm (Suministro e instalación) | resource dependent | 2d | 2023-08-17 | 2023-08-18 | 696 | 268d | 0d |
| 698 |  | Tubería HDPE Corrugada Ø=1200mm (Suministro e instalación) | resource dependent | 2d | 2023-08-19 | 2023-08-20 | 697 | 268d | 38d |
| 685 |  | Colocación de roca en uña (Alcantarillas) | resource dependent | 5d | 2023-08-20 | 2023-08-24 | 684 | 0d |  |
| 683 |  | Relleno estructural | resource dependent | 14d | 2023-08-25 | 2023-09-07 | 685 | 0d |  |
| 686 |  | Concreto de Nivelacion (f'c=100 kg/cm2) | resource dependent | 4d | 2023-09-08 | 2023-09-11 | 683 | 0d |  |
| 690 |  | Encofrado y Desencofrado Cara Oculta | resource dependent | 7d | 2023-09-08 | 2023-09-14 | 683 | 0d |  |
| 691 |  | Acero de refuerzo f'y=4200kg/cm2 | resource dependent | 14d | 2023-09-08 | 2023-09-21 | 683 | 0d |  |
| 687 |  | Concreto Clase C (f'c=280 kg/cm2) Premezclado - Cimientos reforzados | resource dependent | 5d | 2023-09-12 | 2023-09-16 | 686, 690 FS-3d, 691 FS-10d | 0d |  |
| 689 |  | Encofrado y Desencofrado Caravista | resource dependent | 6d | 2023-09-15 | 2023-09-20 | 690 | 0d |  |
| 688 |  | Concreto Clase C (f'c=280 kg/cm2) Premezclado - Muros de contencion | resource dependent | 9d | 2023-09-17 | 2023-09-25 | 687, 689 FS-4d | 0d |  |
| 692 |  | Emboquillado de piedra e=0.20m | resource dependent | 9d | 2023-09-26 | 2023-10-04 | 688 | 224d | 0d |
| 702 |  | Waterstop (anillos de estanqueidad) | resource dependent | 2d | 2023-09-26 | 2023-09-27 | 688 | 230d | 0d |
| 704 |  | Relleno con material granular (incluye extracción de material, zarandeo y combinac | resource dependent | 13d | 2023-09-27 | 2023-10-09 | 688 FS+1d | 0d |  |
| 699 |  | Compuertas Charnela Ø900 (Suministro e instalacion) | resource dependent | 2d | 2023-09-28 | 2023-09-29 | 702, 698 | 230d | 0d |
| 700 |  | Compuertas Charnela Ø1200 (Suministro e instalacion) | resource dependent | 4d | 2023-09-30 | 2023-10-03 | 699 | 230d | 0d |
| 701 |  | Sello en juntas | resource dependent | 2d | 2023-10-04 | 2023-10-05 | 700 | 230d | 0d |
| 693 |  | Emboquillado de piedra e=0.30m | resource dependent | 9d | 2023-10-05 | 2023-10-13 | 692 | 224d | 0d |
| 703 |  | Pintura bituminosa | resource dependent | 9d | 2023-10-06 | 2023-10-14 | 701 | 230d |  |
| 705 |  | Concreto clase D (fc=210 kg/cm2) premezclado-cimientos reforzados | resource dependent | 2d | 2023-10-10 | 2023-10-11 | 704 | 0d |  |
| 706 |  | Baranda metálica en acero ø 1 1/2" h=1.00m | resource dependent | 2d | 2023-10-12 | 2023-10-13 | 705 | 0d |  |
| 694 |  | Emboquillado de piedra e=0.50m | resource dependent | 7d | 2023-10-14 | 2023-10-20 | 693 | 224d |  |
| 707 |  | Rejilla metálica 1.80mx(2.39m-2.70m) (suministro e instalacion) | resource dependent | 3d | 2023-10-14 | 2023-10-16 | 706 | 0d |  |
| 708 |  | Compuerta plana mural 1.10mx1.10m (suministro e instalacion) | resource dependent | 5d | 2023-10-17 | 2023-10-21 | 707 | 0d |  |
| 709 |  | Compuerta metálica tipo tarjeta 600x600 mm (suministro e instalacion) | resource dependent | 3d | 2023-10-22 | 2023-10-24 | 708 | 0d |  |

| ID | WBS | Activity | Type | Duration | Start | Finish | Predecessors | Total float | Free float |
| --- | --- | --- | --- | --- | --- | --- | --- | --- | --- |
|  | 6 | **Obras Civiles DI-PR-19A-1-D (PAQUETE 3)** |  |  | 2023-08-20 | 2023-10-14 |  |  |  |
| 711 |  | Trazo y replanteo de interferencia | resource dependent | 12d | 2023-08-20 | 2023-08-31 | 677 | 274d |  |
| 714 |  | Limpieza de terreno manual | resource dependent | 2d | 2023-08-20 | 2023-08-21 | 677 | 122d | 0d |
| 712 |  | Desvío provisional con tubería | resource dependent | 9d | 2023-08-22 | 2023-08-30 | 714 | 122d | 0d |
| 713 |  | Desvío provisional en tierras | resource dependent | 5d | 2023-08-31 | 2023-09-04 | 712 | 122d | 0d |
| 715 |  | Excavaciones no clasificada para estructuras | resource dependent | 2d | 2023-09-05 | 2023-09-06 | 713 | 122d | 0d |
| 716 |  | Excavacion no clasificada de zanja | resource dependent | 3d | 2023-09-07 | 2023-09-09 | 715 | 122d | 0d |
| 718 |  | Suministro de roca (Alcantarillas) | resource dependent | 4d | 2023-09-10 | 2023-09-13 | 716 | 122d | 0d |
| 729 |  | Cama de arena e=0.20m | resource dependent | 2d | 2023-09-10 | 2023-09-11 | 716 | 142d | 0d |
| 730 |  | Tubería HDPE Corrugada Ø=1200mm (Suministro e instalación) | resource dependent | 2d | 2023-09-12 | 2023-09-13 | 729 | 142d | 20d |
| 719 |  | Colocación de roca en uña (Alcantarillas) | resource dependent | 2d | 2023-09-14 | 2023-09-15 | 718 | 122d | 0d |
| 717 |  | Relleno estructural | resource dependent | 6d | 2023-09-16 | 2023-09-21 | 719 | 122d | 0d |
| 720 |  | Concreto de Nivelacion (f'c=100 kg/cm2) | resource dependent | 3d | 2023-09-22 | 2023-09-24 | 717 | 122d | 0d |
| 724 |  | Encofrado y Desencofrado Cara Oculta | resource dependent | 5d | 2023-09-22 | 2023-09-26 | 717 | 122d | 0d |
| 725 |  | Acero de refuerzo f'y=4200kg/cm2 | resource dependent | 9d | 2023-09-22 | 2023-09-30 | 717 | 122d | 0d |
| 721 |  | Concreto Clase C (f'c=280 kg/cm2) Premezclado - Cimientos reforzados | resource dependent | 3d | 2023-09-25 | 2023-09-27 | 720, 724 FS-2d, 725 FS-6d | 122d | 0d |
| 723 |  | Encofrado y Desencofrado Caravista | resource dependent | 4d | 2023-09-27 | 2023-09-30 | 724 | 122d | 0d |
| 722 |  | Concreto Clase C (f'c=280 kg/cm2) Premezclado - Muros de contencion | resource dependent | 4d | 2023-09-28 | 2023-10-01 | 721, 723 FS-3d | 122d | 0d |
| 726 |  | Emboquillado de piedra e=0.20m | resource dependent | 3d | 2023-10-02 | 2023-10-04 | 722 | 235d | 0d |
| 733 |  | Waterstop (anillos de estanqueidad) | resource dependent | 2d | 2023-10-02 | 2023-10-03 | 722 | 122d | 0d |
| 731 |  | Compuertas Charnela Ø1200 (Suministro e instalacion) | resource dependent | 2d | 2023-10-04 | 2023-10-05 | 733, 730 | 122d | 0d |
| 727 |  | Emboquillado de piedra e=0.30m | resource dependent | 3d | 2023-10-05 | 2023-10-07 | 726 | 235d | 0d |
| 732 |  | Sello en juntas | resource dependent | 2d | 2023-10-06 | 2023-10-07 | 731 | 122d | 0d |
| 728 |  | Emboquillado de piedra e=0.50m | resource dependent | 2d | 2023-10-08 | 2023-10-09 | 727 | 235d |  |
| 734 |  | Pintura bituminosa | resource dependent | 4d | 2023-10-08 | 2023-10-11 | 732 | 122d | 0d |
| 735 |  | Compuerta plana tipo tarjeta 0.60mx0.30m(suministro e instalación) | resource dependent | 3d | 2023-10-12 | 2023-10-14 | 734 | 122d |  |

| ID | WBS | Activity | Type | Duration | Start | Finish | Predecessors | Total float | Free float |
| --- | --- | --- | --- | --- | --- | --- | --- | --- | --- |
|  | 10 | **Obras Civiles Botadero** |  |  | 2023-04-02 | 2023-05-16 |  |  |  |
| 737 |  | Remoción de residuos solidos | resource dependent | 45d | 2023-04-02 | 2023-05-16 | 3 SS | 381d |  |
|  | 11 | **Accesos DI-PR-13-D (PAQUETE 2)** |  |  | 2023-04-16 | 2023-04-27 |  |  |  |
|  | 1 | **Superficie de rodadura** |  |  | 2023-04-16 | 2023-04-27 |  |  |  |
| 741 |  | Encofrado y desencofrado pavimento rígido e=0.15m | resource dependent | 6d | 2023-04-16 | 2023-04-21 | 3 SS+14d | 0d |  |
| 743 |  | Concreto Ciclopeo f'c=210 kg/cm2 + 30% PM | resource dependent | 2d | 2023-04-20 | 2023-04-21 | 3 SS+18d | 0d |  |
| 740 |  | Concreto clase C (f'c=280 kg/cm2) en losa | resource dependent | 4d | 2023-04-22 | 2023-04-25 | 741, 743 | 0d |  |
| 742 |  | Junta en Pavimentos con Pasadores | resource dependent | 2d | 2023-04-26 | 2023-04-27 | 740 | 0d |  |
|  | 12 | **Accesos DI-PR-12-I (PAQUETE 2)** |  |  | 2023-04-04 | 2023-04-21 |  |  |  |
|  | 1 | **Superficie de rodadura** |  |  | 2023-04-04 | 2023-04-21 |  |  |  |
| 747 |  | Encofrado y desencofrado pavimento rígido e=0.15m | resource dependent | 9d | 2023-04-04 | 2023-04-12 | 3 SS+2d | 7d | 0d |
| 749 |  | Concreto Ciclopeo f'c=210 kg/cm2 + 30% PM | resource dependent | 2d | 2023-04-11 | 2023-04-12 | 3 SS+9d | 7d | 0d |
| 746 |  | Concreto clase C (f'c=280 kg/cm2) en losa | resource dependent | 6d | 2023-04-13 | 2023-04-18 | 747, 749 | 7d | 0d |
| 748 |  | Junta en Pavimentos con Pasadores | resource dependent | 3d | 2023-04-19 | 2023-04-21 | 746 | 7d | 0d |
|  | 13 | **Accesos DI-PR-19A-D (PAQUETE 3)** |  |  | 2023-07-03 | 2023-07-16 |  |  |  |
|  | 1 | **Superficie de rodadura** |  |  | 2023-07-03 | 2023-07-16 |  |  |  |
| 753 |  | Encofrado y desencofrado pavimento rígido e=0.15m | resource dependent | 7d | 2023-07-03 | 2023-07-09 | 4 SS | 320d | 0d |
| 755 |  | Concreto Ciclopeo f'c=210 kg/cm2 + 30% PM | resource dependent | 2d | 2023-07-03 | 2023-07-04 | 4 SS | 325d | 5d |
| 752 |  | Concreto clase C (f'c=280 kg/cm2) en losa | resource dependent | 5d | 2023-07-10 | 2023-07-14 | 753, 755 | 320d | 0d |
| 754 |  | Junta en Pavimentos con Pasadores | resource dependent | 2d | 2023-07-15 | 2023-07-16 | 752 | 320d |  |
|  | 14 | **Accesos DI-PR-19B-D (PAQUETE 3)** |  |  | 2023-06-23 | 2023-07-02 |  |  |  |
|  | 1 | **Superficie de rodadura** |  |  | 2023-06-23 | 2023-07-02 |  |  |  |
| 759 |  | Encofrado y desencofrado pavimento rígido e=0.15m | resource dependent | 5d | 2023-06-23 | 2023-06-27 | 4 SS-10d | 0d |  |
| 761 |  | Concreto Ciclopeo f'c=210 kg/cm2 + 30% PM | resource dependent | 2d | 2023-06-26 | 2023-06-27 | 4 SS-7d | 0d |  |
| 758 |  | Concreto clase C (f'c=280 kg/cm2) en losa | resource dependent | 3d | 2023-06-28 | 2023-06-30 | 759, 761 | 0d |  |
| 760 |  | Junta en Pavimentos con Pasadores | resource dependent | 2d | 2023-07-01 | 2023-07-02 | 758 | 0d |  |
