# HABILITACIÓN DE ACCESOS Y PLATAFORMAS, Y MOVIMIENTO DE TIERRAS II PARTE - CUENCA HUAURA

Schedule from MS Project, 2023-03-17 to 2024-05-31, 10 hours a day.

## Calendars

- 2314 DRH: Mon-Sun 07:00-13:00, 15:00-19:00.

## Schedule

| ID | WBS | Task | Type | Duration | Start | Finish | Predecessors | Total slack | Free slack |
| --- | --- | --- | --- | --- | --- | --- | --- | --- | --- |
| 1 | 1 | Hito 1: Inicio - KOM | milestone | 0d | 2023-03-17 | 2023-03-17 |  | 0d |  |
| 2 | 2 | Hito 2: Inicio de Habilitación y Mejoramiento de accesos | milestone | 0d | 2023-03-31 | 2023-03-31 | 1FS+15d | 0d |  |
| 3 | 3 | Hito: Inicio de Paquete 2 | milestone | 0d | 2023-04-01 | 2023-04-01 | 2FS+1d | 0d |  |
| 4 | 4 | Hito: Inicio de Paquete 3 | milestone | 0d | 2023-07-02 | 2023-07-02 | 3FS+92d | 0d |  |
| 5 | 5 | **Obras Provisionales** |  | 426d | 2023-04-02 | 2024-05-31 |  | 0d |  |
| 6 | 5.1 | Campamento Provisional de Obra |  | 30d | 2023-04-02 | 2023-05-01 | 3SS | 396d |  |
| 7 | 5.2 | Movilización y Desmovilización de maquinaria pesada |  | 426d | 2023-04-02 | 2024-05-31 | 3SS | 0d |  |
| 8 | 5.3 | Mejoramiento y Habilitación de caminos de acceso |  | 97d | 2023-04-07 | 2023-07-12 | 10FS-8d | 324d |  |
| 9 | 5.4 | Limpieza manual de material vegetal y de residuos |  | 33d | 2023-04-15 | 2023-05-17 | 10 | 380d |  |
| 10 | 5.5 | Desbroce en areas auxiliares |  | 13d | 2023-04-02 | 2023-04-14 | 3 | 324d | 0d |
| 11 | 5.6 | Mantenimiento de caminos de acceso |  | 426d | 2023-04-02 | 2024-05-31 | 3SS | 0d |  |
| 12 | 5.7 | Habilitacion de plataformas |  | 24d | 2023-04-07 | 2023-04-30 | 10FS-8d | 381d | 0d |
| 13 | 5.8 | Tubería HDPE corrugada ø=450mm, para caminos de acceso (o similar) |  | 2d | 2023-04-15 | 2023-04-16 | 10 | 381d | 0d |
| 14 | 5.9 | Tubería HDPE Corrugada Ø=630mm, para caminos de acceso (o similar) |  | 2d | 2023-04-17 | 2023-04-18 | 13 | 381d | 0d |
| 15 | 5.10 | Tubería HDPE corrugada ø=900mm, para caminos de acceso (o similar) |  | 5d | 2023-04-19 | 2023-04-23 | 14 | 381d | 0d |
| 16 | 5.11 | Tubería HDPE Corrugada Ø=1000mm, para caminos de acceso (o similar) |  | 9d | 2023-04-24 | 2023-05-02 | 15 | 381d | 0d |
| 17 | 5.12 | Tubería HDPE Corrugada Ø=1200mm, para caminos de acceso (o similar) |  | 11d | 2023-05-03 | 2023-05-13 | 16 | 381d | 0d |
| 18 | 5.13 | Concreto ciclopeo f'c=175 kg/cm2 + 30% P.G. para proteccion de estructuras |  | 3d | 2023-05-10 | 2023-05-12 | 17FS-4d | 381d | 0d |
| 19 | 5.14 | Concreto estructural (f'c=280 kg/cm2) para proteccion de estructuras |  | 4d | 2023-05-13 | 2023-05-16 | 20, 21, 17FS-1d, 18 | 381d |  |
| 20 | 5.15 | Acero corrugado fy= 4200 kg/cm2 grado 60 para proteccion de estructuras |  | 12d | 2023-05-01 | 2023-05-12 | 12 | 381d | 0d |
| 21 | 5.16 | Encofrado y desencofrado para proteccion de estructuras |  | 13d | 2023-04-30 | 2023-05-12 | 12FS-1d | 381d | 0d |
| 22 | 6 | **Topografía** |  | 30d | 2023-04-02 | 2023-05-01 |  | 0d |  |
| 23 | 6.1 | Trazo y replanteo inicial |  | 30d | 2023-04-02 | 2023-05-01 | 3SS | 0d |  |
| 24 | 7 | **FRENTE 1** |  | 406d | 2023-04-22 | 2024-05-31 |  | 0d |  |
| 25 | 7.1 | **DIQUE DI-PR-25-I (PAQUETE 2)** |  | 41d | 2023-04-22 | 2023-06-01 |  | 0d |  |
| 26 | 7.1.1 | **Excavaciones** |  | 12d | 2023-04-22 | 2023-05-03 |  | 0d |  |
| 27 | 7.1.1.1 | Desbroce |  | 2d | 2023-04-22 | 2023-04-23 | 3FS+20d, 23FS-10d | 0d |  |
| 28 | 7.1.1.2 | Excavación de cimentación |  | 4d | 2023-04-24 | 2023-04-27 | 27 | 0d |  |
| 29 | 7.1.1.3 | Perfilado y conformación de Plataforma de fundación |  | 2d | 2023-04-28 | 2023-04-29 | 28 | 0d |  |
| 30 | 7.1.1.4 | Excavación de uña |  | 4d | 2023-04-28 | 2023-05-01 | 28 | 0d |  |
| 31 | 7.1.1.5 | Conformación de material excedente en DME |  | 3d | 2023-04-24 | 2023-04-26 | 49FS-10d | 401d |  |
| 32 | 7.1.1.6 | Conformación de material excedente en DMO |  | 2d | 2023-04-22 | 2023-04-23 | 48FS-2d | 404d |  |
| 33 | 7.1.1.7 | Excavación Localizada - Sobreexcavación |  | 2d | 2023-05-02 | 2023-05-03 | 30 | 0d |  |

| ID | WBS | Task | Duration | Start | Finish | Predecessors | Total slack | Free slack |
| --- | --- | --- | --- | --- | --- | --- | --- | --- |
| 34 | 7.1.2 | **Rellenos** | 33d | 2023-04-30 | 2023-06-01 |  | 0d |  |
| 35 | 7.1.2.1 | Relleno con material granular (incluye extracción de material, zarandeo y combinación de material) | 6d | 2023-04-30 | 2023-05-05 | 29 | 0d |  |
| 36 | 7.1.2.2 | Relleno sin compactar | 2d | 2023-05-29 | 2023-05-30 | 46FS-2d | 365d | 0d |
| 37 | 7.1.2.3 | Relleno afirmado | 2d | 2023-05-31 | 2023-06-01 | 46, 36 | 365d | 0d |
| 38 | 7.1.2.4 | Perfilado de Talud del dique | 2d | 2023-05-06 | 2023-05-07 | 35 | 0d |  |
| 39 | 7.1.2.5 | Relleno con material seleccionado (incluye extracción de material, zarandeo y combinación de material) en sobreexcavación | 3d | 2023-05-06 | 2023-05-08 | 35 | 387d | 0d |
| 40 | 7.1.2.6 | Grava para Drenaje | 2d | 2023-05-09 | 2023-05-10 | 39 | 387d |  |
| 41 | 7.1.3 | **Geotextil** | 4d | 2023-05-08 | 2023-05-11 |  | 0d |  |
| 42 | 7.1.3.1 | Instalación de Geotextil 400 gr/m2 | 3d | 2023-05-09 | 2023-05-11 | 43FS-2d | 0d |  |
| 43 | 7.1.3.2 | Zanja de anclaje | 3d | 2023-05-08 | 2023-05-10 | 38 | 0d |  |
| 44 | 7.1.4 | **Colocación de roca** | 19d | 2023-05-12 | 2023-05-30 |  | 0d |  |
| 45 | 7.1.4.1 | Colocación de roca en uña | 12d | 2023-05-12 | 2023-05-23 | 42 | 0d |  |
| 46 | 7.1.4.2 | Colocación de roca en Talud | 7d | 2023-05-24 | 2023-05-30 | 45 | 0d |  |
| 47 | 7.1.5 | **Transportes** | 41d | 2023-04-22 | 2023-06-01 |  | 365d |  |
| 48 | 7.1.5.1 | Transporte de material orgánico (a DMO) D<=1km | 2d | 2023-04-22 | 2023-04-23 | 27SS | 404d | 0d |
| 49 | 7.1.5.2 | Transporte de material excedente (dique provisional) D<=1km | 10d | 2023-04-24 | 2023-05-03 | 28SS, 33FF | 394d | 0d |
| 50 | 7.1.5.3 | Transporte de material de préstamo (afirmado) D<=1km | 2d | 2023-05-31 | 2023-06-01 | 37SS | 365d |  |
| 51 | 7.1.5.4 | Transporte de material de préstamo (afirmado) D>1km | 2d | 2023-05-31 | 2023-06-01 | 37SS | 365d |  |
| 52 | 7.1.5.5 | Transporte de roca D<=1km | 19d | 2023-05-12 | 2023-05-30 | 45SS, 46FF | 367d |  |
| 53 | 7.1.5.6 | Transporte de roca D>1km | 19d | 2023-05-12 | 2023-05-30 | 45SS, 46FF | 367d |  |
| 54 | 7.1.5.7 | Transporte de material de préstamo cantera de rio (cuerpo de terraplén) D<=1km | 6d | 2023-04-30 | 2023-05-05 | 35SS | 392d |  |
| 55 | 7.1.5.8 | Transporte de material de préstamo cantera de rio (cuerpo de terraplén) D>1km | 6d | 2023-04-30 | 2023-05-05 | 35SS | 392d |  |
| 56 | 7.1.5.9 | Transporte de material seleccionado para zanja D<=1km | 3d | 2023-05-08 | 2023-05-10 | 43SS | 387d |  |
| 57 | 7.1.5.10 | Transporte de material seleccionado para zanja D>1km | 3d | 2023-05-08 | 2023-05-10 | 43SS | 387d |  |

| ID | WBS | Task | Duration | Start | Finish | Predecessors | Total slack | Free slack |
| --- | --- | --- | --- | --- | --- | --- | --- | --- |
| 58 | 7.2 | **DIQUE DI-PR-24-D (PAQUETE 2)** | 92d | 2023-04-24 | 2023-07-24 |  | 0d |  |
| 59 | 7.2.1 | **Excavaciones** | 35d | 2023-04-24 | 2023-05-28 |  | 0d |  |
| 60 | 7.2.1.1 | Desbroce | 4d | 2023-04-24 | 2023-04-27 | 27 | 0d |  |
| 61 | 7.2.1.2 | Excavación de cimentación | 12d | 2023-05-04 | 2023-05-15 | 33, 60 | 0d |  |
| 62 | 7.2.1.3 | Perfilado y conformación de Plataforma de fundación | 4d | 2023-05-13 | 2023-05-16 | 61FS-3d | 0d |  |
| 63 | 7.2.1.4 | Excavación de uña | 11d | 2023-05-16 | 2023-05-26 | 61, 33 | 369d | 0d |
| 64 | 7.2.1.5 | Conformación de material excedente en DME | 25d | 2023-05-04 | 2023-05-28 | 82FS-25d | 369d |  |
| 65 | 7.2.1.6 | Conformación de material excedente en DMO | 4d | 2023-04-24 | 2023-04-27 | 81FS-2d | 400d |  |
| 66 | 7.2.1.7 | Excavación Localizada - Sobreexcavación | 2d | 2023-05-27 | 2023-05-28 | 63 | 369d | 0d |
| 67 | 7.2.2 | **Rellenos** | 72d | 2023-05-14 | 2023-07-24 |  | 0d |  |
| 68 | 7.2.2.1 | Relleno con material granular (incluye extracción de material, zarandeo y combinación de material) | 14d | 2023-05-14 | 2023-05-27 | 62FS-3d | 0d |  |
| 69 | 7.2.2.2 | Relleno sin compactar | 4d | 2023-07-19 | 2023-07-22 | 79FS-4d | 312d | 0d |
| 70 | 7.2.2.3 | Relleno afirmado | 2d | 2023-07-23 | 2023-07-24 | 79, 69 | 312d | 0d |
| 71 | 7.2.2.4 | Perfilado de Talud del dique | 4d | 2023-05-25 | 2023-05-28 | 68FS-3d | 0d |  |
| 72 | 7.2.2.5 | Relleno con material seleccionado (incluye extracción de material, zarandeo y combinación de material) en sobreexcavación | 5d | 2023-05-28 | 2023-06-01 | 68 | 361d | 0d |
| 73 | 7.2.2.6 | Grava para Drenaje | 4d | 2023-06-02 | 2023-06-05 | 72 | 361d |  |
| 74 | 7.2.3 | **Geotextil** | 3d | 2023-05-29 | 2023-05-31 |  | 0d |  |
| 75 | 7.2.3.1 | Instalación de Geotextil 400 gr/m2 | 2d | 2023-05-30 | 2023-05-31 | 76FS-1d | 0d |  |
| 76 | 7.2.3.2 | Zanja de anclaje | 2d | 2023-05-29 | 2023-05-30 | 71 | 0d |  |
| 77 | 7.2.4 | **Colocación de roca** | 53d | 2023-05-31 | 2023-07-22 |  | 0d |  |
| 78 | 7.2.4.1 | Colocación de roca en uña | 34d | 2023-05-31 | 2023-07-03 | 46, 75FS-1d, 250 | 0d |  |
| 79 | 7.2.4.2 | Colocación de roca en Talud | 19d | 2023-07-04 | 2023-07-22 | 78 | 0d |  |
| 80 | 7.2.5 | **Transportes** | 92d | 2023-04-24 | 2023-07-24 |  | 312d |  |
| 81 | 7.2.5.1 | Transporte de material orgánico (a DMO) D<=1km | 2d | 2023-04-24 | 2023-04-25 | 60SS | 400d | 0d |
| 82 | 7.2.5.2 | Transporte de material excedente (dique provisional) D<=1km | 25d | 2023-05-04 | 2023-05-28 | 61SS, 66FF | 369d | 0d |
| 83 | 7.2.5.3 | Transporte de material de préstamo (afirmado) D<=1km | 2d | 2023-07-23 | 2023-07-24 | 70SS | 312d |  |
| 84 | 7.2.5.4 | Transporte de material de préstamo (afirmado) D>1km | 2d | 2023-07-23 | 2023-07-24 | 70SS | 312d |  |
| 85 | 7.2.5.5 | Transporte de roca D<=1km | 53d | 2023-05-31 | 2023-07-22 | 78SS, 79FF | 314d |  |
| 86 | 7.2.5.6 | Transporte de roca D>1km | 53d | 2023-05-31 | 2023-07-22 | 78SS, 79FF | 314d |  |
| 87 | 7.2.5.7 | Transporte de material de préstamo cantera de rio (cuerpo de terraplén) D<=1km | 14d | 2023-05-14 | 2023-05-27 | 68SS | 370d |  |
| 88 | 7.2.5.8 | Transporte de material de préstamo cantera de rio (cuerpo de terraplén) D>1km | 14d | 2023-05-14 | 2023-05-27 | 68SS | 370d |  |
| 89 | 7.2.5.9 | Transporte de material seleccionado para zanja D<=1km | 2d | 2023-05-29 | 2023-05-30 | 76SS | 367d |  |
| 90 | 7.2.5.10 | Transporte de material seleccionado para zanja D>1km | 2d | 2023-05-29 | 2023-05-30 | 76SS | 367d |  |

| ID | WBS | Task | Duration | Start | Finish | Predecessors | Total slack | Free slack |
| --- | --- | --- | --- | --- | --- | --- | --- | --- |
| 91 | 7.3 | **DIQUE DI-PR-13-D (PAQUETE 2)** | 139d | 2023-04-28 | 2023-09-13 |  | 0d |  |
| 92 | 7.3.1 | **Excavaciones** | 58d | 2023-04-28 | 2023-06-24 |  | 0d |  |
| 93 | 7.3.1.1 | Desbroce | 3d | 2023-04-28 | 2023-04-30 | 60, 742 | 0d |  |
| 94 | 7.3.1.2 | Remoción de dique existente | 20d | 2023-05-01 | 2023-05-20 | 93 | 0d |  |
| 95 | 7.3.1.3 | Excavación de cimentación | 18d | 2023-05-21 | 2023-06-07 | 61, 94 | 0d |  |
| 96 | 7.3.1.4 | Perfilado y conformación de Plataforma de fundación | 10d | 2023-06-01 | 2023-06-10 | 95FS-7d | 0d |  |
| 97 | 7.3.1.5 | Excavación de uña | 17d | 2023-06-08 | 2023-06-24 | 95 | 12d | 0d |
| 98 | 7.3.1.6 | Conformación de material excedente en DME | 44d | 2023-05-12 | 2023-06-24 | 116FS-44d, 117FS-44d | 342d |  |
| 99 | 7.3.1.7 | Conformación de material excedente en DMO | 5d | 2023-04-28 | 2023-05-02 | 114FS-3d, 115FS-3d | 395d |  |
| 100 | 7.3.2 | **Rellenos** | 102d | 2023-06-04 | 2023-09-13 |  | 0d |  |
| 101 | 7.3.2.1 | Relleno con material granular (incluye extracción de material, zarandeo y combinación de material) | 20d | 2023-06-04 | 2023-06-23 | 96FS-7d | 0d |  |
| 102 | 7.3.2.2 | Relleno sin compactar | 9d | 2023-09-01 | 2023-09-09 | 111FS-9d | 261d | 0d |
| 103 | 7.3.2.3 | Relleno afirmado | 4d | 2023-09-10 | 2023-09-13 | 111, 102 | 261d | 0d |
| 104 | 7.3.2.4 | Perfilado de Talud del dique | 7d | 2023-06-19 | 2023-06-25 | 101FS-5d | 0d |  |
| 105 | 7.3.2.5 | Grava para Drenaje | 5d | 2023-06-24 | 2023-06-28 | 101 | 338d |  |
| 106 | 7.3.3 | **Geotextil** | 14d | 2023-06-26 | 2023-07-09 |  | 0d |  |
| 107 | 7.3.3.1 | Instalación de Geotextil 400 gr/m2 | 13d | 2023-06-27 | 2023-07-09 | 108FS-12d | 0d |  |
| 108 | 7.3.3.2 | Zanja de anclaje | 13d | 2023-06-26 | 2023-07-08 | 104 | 0d |  |
| 109 | 7.3.4 | **Colocación de roca** | 112d | 2023-05-21 | 2023-09-09 |  | 0d |  |
| 110 | 7.3.4.1 | Colocación de roca en uña | 46d | 2023-07-04 | 2023-08-18 | 78, 107FS-6d, 276, 112 | 0d |  |
| 111 | 7.3.4.2 | Colocación de roca en Talud | 49d | 2023-07-23 | 2023-09-09 | 79 | 0d |  |
| 112 | 7.3.4.3 | Extracción y Selección de Rocas Reutilizables (50% de roca utilizable) | 30d | 2023-05-21 | 2023-06-19 | 94 | 14d |  |
| 113 | 7.3.5 | **Transportes** | 139d | 2023-04-28 | 2023-09-13 |  | 261d |  |
| 114 | 7.3.5.1 | Transporte de material orgánico (a DMO) D<=1km | 3d | 2023-04-28 | 2023-04-30 | 93SS | 395d | 0d |
| 115 | 7.3.5.2 | Transporte de material orgánico (a DMO) D>1km | 3d | 2023-04-28 | 2023-04-30 | 93SS | 395d | 0d |
| 116 | 7.3.5.3 | Transporte de material excedente (dique provisional) D<=1km | 55d | 2023-05-01 | 2023-06-24 | 94SS, 97FF | 342d | 0d |
| 117 | 7.3.5.4 | Transporte de material excedente (dique provisional) D> 1km | 55d | 2023-05-01 | 2023-06-24 | 94SS, 97FF | 342d | 0d |
| 118 | 7.3.5.5 | Transporte de material de préstamo (afirmado) D<=1km | 4d | 2023-09-10 | 2023-09-13 | 103SS | 261d |  |
| 119 | 7.3.5.6 | Transporte de material de préstamo (afirmado) D>1km | 4d | 2023-09-10 | 2023-09-13 | 103SS | 261d |  |
| 120 | 7.3.5.7 | Transporte de roca D<=1km | 68d | 2023-07-04 | 2023-09-09 | 110SS, 111FF | 265d |  |
| 121 | 7.3.5.8 | Transporte de roca D>1km | 68d | 2023-07-04 | 2023-09-09 | 110SS, 111FF | 265d |  |
| 122 | 7.3.5.9 | Transporte de material de préstamo cantera de rio (cuerpo de terraplén) D<=1km | 20d | 2023-06-04 | 2023-06-23 | 101SS | 343d |  |
| 123 | 7.3.5.10 | Transporte de material de préstamo cantera de rio (cuerpo de terraplén) D>1km | 20d | 2023-06-04 | 2023-06-23 | 101SS | 343d |  |
| 124 | 7.3.5.11 | Transporte de material seleccionado para zanja D<=1km | 13d | 2023-06-26 | 2023-07-08 | 108SS | 328d |  |
| 125 | 7.3.5.12 | Transporte de material seleccionado para zanja D>1km | 13d | 2023-06-26 | 2023-07-08 | 108SS | 328d |  |

| ID | WBS | Task | Duration | Start | Finish | Predecessors | Total slack | Free slack |
| --- | --- | --- | --- | --- | --- | --- | --- | --- |
| 126 | 7.4 | **DIQUE DI-PR-19B-D (PAQUETE 3)** | 149d | 2023-07-03 | 2023-11-28 |  | 0d |  |
| 127 | 7.4.1 | **Excavaciones** | 89d | 2023-07-03 | 2023-09-29 |  | 0d |  |
| 128 | 7.4.1.1 | Desbroce | 4d | 2023-07-03 | 2023-07-06 | 4, 760 | 0d |  |
| 129 | 7.4.1.2 | Excavación de cimentación | 25d | 2023-07-07 | 2023-07-31 | 97, 128 | 0d |  |
| 130 | 7.4.1.3 | Perfilado y conformación de Plataforma de fundación | 14d | 2023-07-19 | 2023-08-01 | 129FS-13d | 0d |  |
| 131 | 7.4.1.4 | Excavación de uña | 37d | 2023-08-01 | 2023-09-06 | 129 | 7d | 0d |
| 132 | 7.4.1.5 | Conformación de material excedente en DME | 85d | 2023-07-07 | 2023-09-29 | 148FS-85d, 149FS-85d | 245d |  |
| 133 | 7.4.1.6 | Conformación de material excedente en DMO | 6d | 2023-07-03 | 2023-07-08 | 146FS-4d, 147FS-4d | 328d |  |
| 134 | 7.4.2 | **Rellenos** | 132d | 2023-07-20 | 2023-11-28 |  | 0d |  |
| 135 | 7.4.2.1 | Relleno con material granular (incluye extracción de material, zarandeo y combinación de material) | 25d | 2023-07-20 | 2023-08-13 | 130FS-13d | 0d |  |
| 136 | 7.4.2.2 | Relleno sin compactar | 11d | 2023-11-13 | 2023-11-23 | 144FS-11d | 185d | 0d |
| 137 | 7.4.2.3 | Relleno afirmado | 5d | 2023-11-24 | 2023-11-28 | 136, 144 | 185d | 0d |
| 138 | 7.4.2.4 | Perfilado de Talud del dique | 10d | 2023-08-05 | 2023-08-14 | 135FS-9d | 0d |  |
| 139 | 7.4.3 | **Geotextil** | 22d | 2023-08-06 | 2023-08-27 |  | 0d |  |
| 140 | 7.4.3.1 | Instalación de Geotextil 400 gr/m2 | 21d | 2023-08-07 | 2023-08-27 | 141FS-20d | 0d |  |
| 141 | 7.4.3.2 | Zanja de anclaje | 21d | 2023-08-06 | 2023-08-26 | 138FS-9d | 0d |  |
| 142 | 7.4.4 | **Colocación de roca** | 97d | 2023-08-19 | 2023-11-23 |  | 0d |  |
| 143 | 7.4.4.1 | Colocación de roca en uña | 52d | 2023-08-19 | 2023-10-09 | 110, 300, 140FS-9d | 0d |  |
| 144 | 7.4.4.2 | Colocación de roca en Talud | 75d | 2023-09-10 | 2023-11-23 | 111, 143FS-30d | 0d |  |
| 145 | 7.4.5 | **Transportes** | 149d | 2023-07-03 | 2023-11-28 |  | 185d |  |
| 146 | 7.4.5.1 | Transporte de material orgánico (a DMO) D<=1km | 4d | 2023-07-03 | 2023-07-06 | 128SS | 328d | 0d |
| 147 | 7.4.5.2 | Transporte de material orgánico (a DMO) D>1km | 4d | 2023-07-03 | 2023-07-06 | 128SS | 328d | 0d |
| 148 | 7.4.5.3 | Transporte de material excedente (dique provisional) D<=1km | 85d | 2023-07-07 | 2023-09-29 | 129SS, 131FF | 245d | 0d |
| 149 | 7.4.5.4 | Transporte de material excedente (dique provisional) D> 1km | 85d | 2023-07-07 | 2023-09-29 | 129SS, 131FF | 245d | 0d |
| 150 | 7.4.5.5 | Transporte de material de préstamo (afirmado) D<=1km | 5d | 2023-11-24 | 2023-11-28 | 137SS | 185d |  |
| 151 | 7.4.5.6 | Transporte de material de préstamo (afirmado) D>1km | 5d | 2023-11-24 | 2023-11-28 | 137SS | 185d |  |
| 152 | 7.4.5.7 | Transporte de roca D<=1km | 97d | 2023-08-19 | 2023-11-23 | 143SS, 144FF | 190d |  |
| 153 | 7.4.5.8 | Transporte de roca D>1km | 97d | 2023-08-19 | 2023-11-23 | 143SS, 144FF | 190d |  |
| 154 | 7.4.5.9 | Transporte de material de préstamo cantera de rio (cuerpo de terraplén) D<=1km | 49d | 2023-07-20 | 2023-09-06 | 135SS | 268d |  |
| 155 | 7.4.5.10 | Transporte de material de préstamo cantera de rio (cuerpo de terraplén) D>1km | 49d | 2023-07-20 | 2023-09-06 | 135SS | 268d |  |
| 156 | 7.4.5.11 | Transporte de material seleccionado para zanja D<= 1km | 21d | 2023-08-06 | 2023-08-26 | 141SS | 279d |  |
| 157 | 7.4.5.12 | Transporte de material seleccionado para zanja D> 1km | 21d | 2023-08-06 | 2023-08-26 | 141SS | 279d |  |

| ID | WBS | Task | Duration | Start | Finish | Predecessors | Total slack | Free slack |
| --- | --- | --- | --- | --- | --- | --- | --- | --- |
| 158 | 7.5 | **ESPIGON 18.1** | 77d | 2023-09-05 | 2023-11-20 |  | 7d |  |
| 159 | 7.5.1 | **Excavaciones** | 7d | 2023-09-05 | 2023-09-11 |  | 7d |  |
| 160 | 7.5.1.1 | Desbroce | 2d | 2023-09-05 | 2023-09-06 | 128FS+60d | 7d | 0d |
| 161 | 7.5.1.2 | Excavación de cimentación | 5d | 2023-09-07 | 2023-09-11 | 131 | 7d | 0d |
| 162 | 7.5.1.3 | Conformación de material excedente en DME | 5d | 2023-09-07 | 2023-09-11 | 170FS-5d, 171FS-5d | 263d |  |
| 163 | 7.5.1.4 | Conformación de material excedente en DMO | 2d | 2023-09-05 | 2023-09-06 | 168FS-2d, 169FS-2d | 268d |  |
| 164 | 7.5.2 | **Colocación de roca** | 42d | 2023-10-10 | 2023-11-20 |  | 0d |  |
| 165 | 7.5.2.1 | Colocación de roca en uña | 16d | 2023-10-10 | 2023-10-25 | 143, 161 | 0d |  |
| 166 | 7.5.2.2 | Colocación de roca en Talud | 26d | 2023-10-26 | 2023-11-20 | 165 | 0d |  |
| 167 | 7.5.3 | **Transportes** | 77d | 2023-09-05 | 2023-11-20 |  | 193d |  |
| 168 | 7.5.3.1 | Transporte de material orgánico (a DMO) D<=1km | 2d | 2023-09-05 | 2023-09-06 | 160SS | 268d | 0d |
| 169 | 7.5.3.2 | Transporte de material orgánico (a DMO) D>1km | 2d | 2023-09-05 | 2023-09-06 | 160SS | 268d | 0d |
| 170 | 7.5.3.3 | Transporte de material excedente (dique provisional) D<=1km | 5d | 2023-09-07 | 2023-09-11 | 161SS | 263d | 0d |
| 171 | 7.5.3.4 | Transporte de material excedente (dique provisional) D> 1km | 5d | 2023-09-07 | 2023-09-11 | 161SS | 263d | 0d |
| 172 | 7.5.3.5 | Transporte de roca D<=1km | 42d | 2023-10-10 | 2023-11-20 | 165SS, 166FF | 193d |  |
| 173 | 7.5.3.6 | Transporte de roca D>1km | 42d | 2023-10-10 | 2023-11-20 | 165SS, 166FF | 193d |  |
| 174 | 7.6 | **ESPIGON 18.2** | 38d | 2023-11-04 | 2023-12-11 |  | 11d |  |
| 175 | 7.6.1 | **Excavaciones** | 6d | 2023-11-04 | 2023-11-09 |  | 11d |  |
| 176 | 7.6.1.1 | Desbroce | 2d | 2023-11-04 | 2023-11-05 | 192FS+53d | 11d | 0d |
| 177 | 7.6.1.2 | Excavación de cimentación | 4d | 2023-11-06 | 2023-11-09 | 176, 198 | 11d | 0d |
| 178 | 7.6.1.3 | Conformación de material excedente en DME | 4d | 2023-11-06 | 2023-11-09 | 186FS-4d, 187FS-4d | 204d |  |
| 179 | 7.6.1.4 | Conformación de material excedente en DMO | 2d | 2023-11-04 | 2023-11-05 | 184FS-2d, 185FS-2d | 208d |  |
| 180 | 7.6.2 | **Colocación de roca** | 21d | 2023-11-21 | 2023-12-11 |  | 0d |  |
| 181 | 7.6.2.1 | Colocación de roca en uña | 9d | 2023-11-21 | 2023-11-29 | 166, 177 | 0d |  |
| 182 | 7.6.2.2 | Colocación de roca en Talud | 12d | 2023-11-30 | 2023-12-11 | 181 | 0d |  |

| ID | WBS | Task | Duration | Start | Finish | Predecessors | Total slack | Free slack |
| --- | --- | --- | --- | --- | --- | --- | --- | --- |
| 183 | 7.6.3 | **Transportes** | 38d | 2023-11-04 | 2023-12-11 |  | 172d |  |
| 184 | 7.6.3.1 | Transporte de material orgánico (a DMO) D<=1km | 2d | 2023-11-04 | 2023-11-05 | 176SS | 208d | 0d |
| 185 | 7.6.3.2 | Transporte de material orgánico (a DMO) D>1km | 2d | 2023-11-04 | 2023-11-05 | 176SS | 208d | 0d |
| 186 | 7.6.3.3 | Transporte de material excedente (dique provisional) D<=1km | 4d | 2023-11-06 | 2023-11-09 | 177SS | 204d | 0d |
| 187 | 7.6.3.4 | Transporte de material excedente (dique provisional) D> 1km | 4d | 2023-11-06 | 2023-11-09 | 177SS | 204d | 0d |
| 188 | 7.6.3.5 | Transporte de roca D<=1km | 21d | 2023-11-21 | 2023-12-11 | 181SS, 182FF | 172d |  |
| 189 | 7.6.3.6 | Transporte de roca D>1km | 21d | 2023-11-21 | 2023-12-11 | 181SS, 182FF | 172d |  |
| 190 | 7.7 | **DIQUE DI-PR-18-D (PAQUETE 3)** | 266d | 2023-09-09 | 2024-05-31 |  | 0d |  |
| 191 | 7.7.1 | **Excavaciones** | 58d | 2023-09-09 | 2023-11-05 |  | 7d |  |
| 192 | 7.7.1.1 | Desbroce | 3d | 2023-09-09 | 2023-09-11 | 160FS+2d | 7d | 0d |
| 193 | 7.7.1.2 | Excavación de cimentación | 20d | 2023-09-12 | 2023-10-01 | 161, 192 | 7d | 0d |
| 194 | 7.7.1.3 | Perfilado y conformación de Plataforma de fundación | 10d | 2023-09-29 | 2023-10-08 | 193FS-3d | 7d | 0d |
| 195 | 7.7.1.4 | Excavación de uña | 30d | 2023-10-02 | 2023-10-31 | 193 | 11d | 0d |
| 196 | 7.7.1.5 | Conformación de material excedente en DME | 55d | 2023-09-12 | 2023-11-05 | 217FS-55d, 218FS-55d | 208d |  |
| 197 | 7.7.1.6 | Conformación de material excedente en DMO | 4d | 2023-09-09 | 2023-09-12 | 215FS-3d, 216FS-3d | 262d |  |
| 198 | 7.7.1.7 | Excavación Localizada - Sobreexcavación | 5d | 2023-11-01 | 2023-11-05 | 195 | 11d | 0d |
| 199 | 7.7.2 | **Rellenos** | 243d | 2023-10-02 | 2024-05-31 |  | 0d |  |
| 200 | 7.7.2.1 | Relleno con material granular (incluye extracción de material, zarandeo y combinación de material) | 27d | 2023-10-02 | 2023-10-28 | 194FS-7d | 7d | 0d |
| 201 | 7.7.2.2 | Relleno sin compactar | 20d | 2024-05-09 | 2024-05-28 | 211FS-5d, 210FS+12d | 0d |  |
| 202 | 7.7.2.3 | Relleno afirmado | 3d | 2024-05-29 | 2024-05-31 | 201 | 0d |  |
| 203 | 7.7.2.4 | Perfilado de Talud del dique | 18d | 2023-10-23 | 2023-11-09 | 200FS-6d | 7d | 0d |
| 204 | 7.7.2.5 | Relleno con material seleccionado (incluye extracción de material, zarandeo y combinación de material) en sobreexcavación | 23d | 2023-10-29 | 2023-11-20 | 200 | 189d | 0d |
| 205 | 7.7.2.6 | Grava para Drenaje | 4d | 2023-11-21 | 2023-11-24 | 204 | 189d |  |
| 206 | 7.7.3 | **Geotextil** | 14d | 2023-11-10 | 2023-11-23 |  | 7d |  |
| 207 | 7.7.3.1 | Instalación de Geotextil 400 gr/m2 | 13d | 2023-11-11 | 2023-11-23 | 208FS-12d | 7d |  |
| 208 | 7.7.3.2 | Zanja de anclaje | 13d | 2023-11-10 | 2023-11-22 | 203 | 7d | 0d |

| ID | WBS | Task | Duration | Start | Finish | Predecessors | Total slack | Free slack |
| --- | --- | --- | --- | --- | --- | --- | --- | --- |
| 209 | 7.7.4 | **Colocación de roca** | 195d | 2023-11-01 | 2024-05-13 |  | 0d |  |
| 210 | 7.7.4.1 | Colocación de roca en uña | 155d | 2023-11-24 | 2024-04-26 | 144, 324, 207FS-7d, 212FS-3d | 0d |  |
| 211 | 7.7.4.2 | Colocación de roca en Talud | 154d | 2023-12-12 | 2024-05-13 | 182 | 0d |  |
| 212 | 7.7.4.3 | Protección de talud con colchón reno 6m largo x e= 0.30cm | 10d | 2023-11-06 | 2023-11-15 | 213 | 11d |  |
| 213 | 7.7.4.4 | Malla gavión de 1m x 1m x 5m | 5d | 2023-11-01 | 2023-11-05 | 195 | 11d | 0d |
| 214 | 7.7.5 | **Transportes** | 266d | 2023-09-09 | 2024-05-31 |  | 0d |  |
| 215 | 7.7.5.1 | Transporte de material orgánico (a DMO) D<=1km | 3d | 2023-09-09 | 2023-09-11 | 192SS | 262d | 0d |
| 216 | 7.7.5.2 | Transporte de material orgánico (a DMO) D>1km | 3d | 2023-09-09 | 2023-09-11 | 192SS | 262d | 0d |
| 217 | 7.7.5.3 | Transporte de material excedente (dique provisional) D<=1km | 55d | 2023-09-12 | 2023-11-05 | 193SS, 198FF | 208d | 0d |
| 218 | 7.7.5.4 | Transporte de material excedente (dique provisional) D> 1km | 55d | 2023-09-12 | 2023-11-05 | 193SS, 198FF | 208d | 0d |
| 219 | 7.7.5.5 | Transporte de material de préstamo (afirmado) D<=1km | 3d | 2024-05-29 | 2024-05-31 | 202SS | 0d |  |
| 220 | 7.7.5.6 | Transporte de material de préstamo (afirmado) D>1km | 3d | 2024-05-29 | 2024-05-31 | 202SS | 0d |  |
| 221 | 7.7.5.7 | Transporte de roca D<=1km | 172d | 2023-11-24 | 2024-05-13 | 210SS, 211FF | 18d |  |
| 222 | 7.7.5.8 | Transporte de roca D>1km | 172d | 2023-11-24 | 2024-05-13 | 210SS, 211FF | 18d |  |
| 223 | 7.7.5.9 | Transporte de material de préstamo cantera de rio (cuerpo de terraplén) D<=1km | 27d | 2023-10-02 | 2023-10-28 | 200SS | 216d |  |
| 224 | 7.7.5.10 | Transporte de material de préstamo cantera de rio (cuerpo de terraplén) D>1km | 27d | 2023-10-02 | 2023-10-28 | 200SS | 216d |  |
| 225 | 7.7.5.11 | Transporte de material seleccionado para zanja D<= 1km | 13d | 2023-11-10 | 2023-11-22 | 208SS | 191d |  |
| 226 | 7.7.5.12 | Transporte de material seleccionado para zanja D> 1km | 13d | 2023-11-10 | 2023-11-22 | 208SS | 191d |  |
| 227 | 7.8 | **Obras Civiles DI-PR-24-D (PAQUETE 2)** | 39d | 2023-04-22 | 2023-05-30 |  | 0d |  |
| 228 | 7.8.1 | Trazo y replanteo de interferencia | 3d | 2023-04-22 | 2023-04-24 | 3FS+20d, 23FS-10d | 1d | 0d |
| 229 | 7.8.2 | Desvío provisional con tubería | 4d | 2023-04-24 | 2023-04-27 | 230 | 0d |  |
| 230 | 7.8.3 | Limpieza de terreno manual | 2d | 2023-04-22 | 2023-04-23 | 3FS+20d, 23FS-10d | 0d |  |
| 231 | 7.8.4 | Excavaciones no clasificada para estructuras | 2d | 2023-04-28 | 2023-04-29 | 229 | 0d |  |
| 232 | 7.8.5 | Excavacion no clasificada de zanja | 2d | 2023-04-30 | 2023-05-01 | 231 | 0d |  |
| 233 | 7.8.6 | Relleno estructural | 5d | 2023-05-08 | 2023-05-12 | 246, 235 | 0d |  |
| 234 | 7.8.7 | Suministro de roca (Alcantarillas) | 4d | 2023-05-02 | 2023-05-05 | 232 | 0d |  |
| 235 | 7.8.8 | Colocación de roca en uña (Alcantarillas) | 2d | 2023-05-06 | 2023-05-07 | 234 | 0d |  |
| 236 | 7.8.9 | Concreto de Nivelacion (f'c=100 kg/cm2) | 2d | 2023-05-13 | 2023-05-14 | 233 | 0d |  |
| 237 | 7.8.10 | Concreto Clase F (f'c=140 kg/cm2) | 2d | 2023-05-15 | 2023-05-16 | 236 | 0d |  |
| 238 | 7.8.11 | Concreto Clase C (f'c=280 kg/cm2) Premezclado - Cimientos reforzados | 2d | 2023-05-17 | 2023-05-18 | 237, 241, 242FS-2d | 0d |  |
| 239 | 7.8.12 | Concreto Clase C (f'c=280 kg/cm2) Premezclado - Muros de contencion | 3d | 2023-05-19 | 2023-05-21 | 238, 240FS-1d | 0d |  |
| 240 | 7.8.13 | Encofrado y Desencofrado Caravista | 3d | 2023-05-17 | 2023-05-19 | 241 | 0d |  |
| 241 | 7.8.14 | Encofrado y Desencofrado Cara Oculta | 4d | 2023-05-13 | 2023-05-16 | 233 | 0d |  |
| 242 | 7.8.15 | Acero de refuerzo f'y=4200kg/cm2 | 6d | 2023-05-13 | 2023-05-18 | 233 | 0d |  |
| 243 | 7.8.16 | Emboquillado de piedra e=0.30m | 2d | 2023-05-22 | 2023-05-23 | 239 | 371d | 0d |
| 244 | 7.8.17 | Emboquillado de piedra e=0.50m | 3d | 2023-05-24 | 2023-05-26 | 243 | 371d |  |
| 245 | 7.8.18 | Cama de arena e=0.20m | 2d | 2023-05-02 | 2023-05-03 | 232 | 0d |  |
| 246 | 7.8.19 | Tubería HDPE Corrugada Ø=1200mm (Suministro e instalación) | 6d | 2023-05-02 | 2023-05-07 | 245FS-2d | 0d |  |
| 247 | 7.8.20 | Compuertas Charnela Ø1200 (Suministro e instalacion) | 2d | 2023-05-24 | 2023-05-25 | 249 | 0d |  |
| 248 | 7.8.21 | Sello en juntas | 2d | 2023-05-26 | 2023-05-27 | 247 | 0d |  |
| 249 | 7.8.22 | Waterstop (anillos de estanqueidad) | 2d | 2023-05-22 | 2023-05-23 | 239, 246 | 0d |  |
| 250 | 7.8.23 | Pintura bituminosa | 3d | 2023-05-28 | 2023-05-30 | 248 | 0d |  |

| ID | WBS | Task | Duration | Start | Finish | Predecessors | Total slack | Free slack |
| --- | --- | --- | --- | --- | --- | --- | --- | --- |
| 251 | 7.9 | **Obras Civiles DI-PR-13-D (PAQUETE 2)** | 70d | 2023-04-25 | 2023-07-03 |  | 1d |  |
| 252 | 7.9.1 | Trazo y replanteo de interferencia | 23d | 2023-04-25 | 2023-05-17 | 228 | 380d |  |
| 253 | 7.9.2 | Desvío provisional con tubería | 4d | 2023-04-28 | 2023-05-01 | 255, 229 | 0d |  |
| 254 | 7.9.3 | Desvío provisional en tierras | 10d | 2023-05-02 | 2023-05-11 | 253 | 0d |  |
| 255 | 7.9.4 | Limpieza de terreno manual | 2d | 2023-04-25 | 2023-04-26 | 228, 230 | 1d |  |
| 256 | 7.9.5 | Excavaciones no clasificada para estructuras | 2d | 2023-05-12 | 2023-05-13 | 254 | 0d |  |
| 257 | 7.9.6 | Excavacion no clasificada de zanja | 16d | 2023-05-14 | 2023-05-29 | 256 | 0d |  |
| 258 | 7.9.7 | Relleno estructural | 7d | 2023-06-04 | 2023-06-10 | 260, 272 | 0d |  |
| 259 | 7.9.8 | Suministro de roca (Alcantarillas) | 3d | 2023-05-30 | 2023-06-01 | 257 | 0d |  |
| 260 | 7.9.9 | Colocación de roca en uña (Alcantarillas) | 2d | 2023-06-02 | 2023-06-03 | 259 | 0d |  |
| 261 | 7.9.10 | Concreto de Nivelacion (f'c=100 kg/cm2) | 2d | 2023-06-11 | 2023-06-12 | 258, 239 | 0d |  |
| 262 | 7.9.11 | Concreto Clase F (f'c=140 kg/cm2) | 3d | 2023-06-13 | 2023-06-15 | 261 | 0d |  |
| 263 | 7.9.12 | Concreto Clase C (f'c=280 kg/cm2) Premezclado - Cimientos reforzados | 2d | 2023-06-16 | 2023-06-17 | 262, 266, 267FS-4d | 0d |  |
| 264 | 7.9.13 | Concreto Clase C (f'c=280 kg/cm2) Premezclado - Muros de contencion | 3d | 2023-06-18 | 2023-06-20 | 263, 265FS-2d | 0d |  |
| 265 | 7.9.14 | Encofrado y Desencofrado Caravista | 4d | 2023-06-16 | 2023-06-19 | 266 | 0d |  |
| 266 | 7.9.15 | Encofrado y Desencofrado Cara Oculta | 5d | 2023-06-11 | 2023-06-15 | 258 | 0d |  |
| 267 | 7.9.16 | Acero de refuerzo f'y=4200kg/cm2 | 9d | 2023-06-11 | 2023-06-19 | 258 | 0d |  |
| 268 | 7.9.17 | Emboquillado de piedra e=0.20m | 2d | 2023-06-21 | 2023-06-22 | 264 | 0d |  |
| 269 | 7.9.18 | Emboquillado de piedra e=0.30m | 3d | 2023-06-23 | 2023-06-25 | 268 | 0d |  |
| 270 | 7.9.19 | Emboquillado de piedra e=0.50m | 3d | 2023-06-26 | 2023-06-28 | 269 | 0d |  |
| 271 | 7.9.20 | Cama de arena e=0.20m | 3d | 2023-05-30 | 2023-06-01 | 257 | 0d |  |
| 272 | 7.9.21 | Tubería HDPE Corrugada Ø=1200mm (Suministro e instalación) | 2d | 2023-06-02 | 2023-06-03 | 271 | 0d |  |
| 273 | 7.9.22 | Compuertas Charnela Ø1200 (Suministro e instalacion) | 2d | 2023-06-23 | 2023-06-24 | 275 | 2d | 0d |
| 274 | 7.9.23 | Sello en juntas | 2d | 2023-06-25 | 2023-06-26 | 273 | 2d |  |
| 275 | 7.9.24 | Waterstop (anillos de estanqueidad) | 2d | 2023-06-21 | 2023-06-22 | 264, 272 | 2d | 0d |
| 276 | 7.9.25 | Pintura bituminosa | 5d | 2023-06-29 | 2023-07-03 | 270, 274 | 0d |  |
| 277 | 7.9.26 | Relleno con material granular (incluye extracción de material, zarandeo y combinación de material) | 5d | 2023-06-21 | 2023-06-25 | 264 | 341d |  |

| ID | WBS | Task | Duration | Start | Finish | Predecessors | Total slack | Free slack |
| --- | --- | --- | --- | --- | --- | --- | --- | --- |
| 278 | 7.10 | **Obras Civiles DI-PR-19B-D (PAQUETE 3)** | 47d | 2023-07-03 | 2023-08-18 |  | 0d |  |
| 279 | 7.10.1 | Trazo y replanteo de interferencia | 7d | 2023-07-03 | 2023-07-09 | 4 | 75d | 0d |
| 280 | 7.10.2 | Desvío provisional con tubería | 5d | 2023-07-05 | 2023-07-09 | 282 | 0d |  |
| 281 | 7.10.3 | Desvío provisional en tierras | 2d | 2023-07-10 | 2023-07-11 | 280 | 0d |  |
| 282 | 7.10.4 | Limpieza de terreno manual | 2d | 2023-07-03 | 2023-07-04 | 4 | 0d |  |
| 283 | 7.10.5 | Excavaciones no clasificada para estructuras | 2d | 2023-07-12 | 2023-07-13 | 281 | 0d |  |
| 284 | 7.10.6 | Excavacion no clasificada de zanja | 3d | 2023-07-14 | 2023-07-16 | 283 | 0d |  |
| 285 | 7.10.7 | Relleno estructural | 7d | 2023-07-24 | 2023-07-30 | 287FS-3d, 296 | 0d |  |
| 286 | 7.10.8 | Suministro de roca (Alcantarillas) | 7d | 2023-07-17 | 2023-07-23 | 284 | 0d |  |
| 287 | 7.10.9 | Colocación de roca en uña (Alcantarillas) | 3d | 2023-07-24 | 2023-07-26 | 286 | 0d |  |
| 288 | 7.10.10 | Concreto de Nivelacion (f'c=100 kg/cm2) | 2d | 2023-07-31 | 2023-08-01 | 285, 264 | 0d |  |
| 289 | 7.10.11 | Concreto Clase C (f'c=280 kg/cm2) Premezclado - Cimientos reforzados | 3d | 2023-08-02 | 2023-08-04 | 288, 292FS-4d, 293FS-10d | 0d |  |
| 290 | 7.10.12 | Concreto Clase C (f'c=280 kg/cm2) Premezclado - Muros de contencion | 4d | 2023-08-05 | 2023-08-08 | 289, 291FS-4d | 0d |  |
| 291 | 7.10.13 | Encofrado y Desencofrado Caravista | 5d | 2023-08-02 | 2023-08-06 | 292 | 2d |  |
| 292 | 7.10.14 | Encofrado y Desencofrado Cara Oculta | 6d | 2023-07-27 | 2023-08-01 | 285FS-4d | 2d | 0d |
| 293 | 7.10.15 | Acero de refuerzo f'y=4200kg/cm2 | 12d | 2023-07-26 | 2023-08-06 | 285FS-5d | 5d |  |
| 294 | 7.10.16 | Emboquillado de piedra e=0.30m | 2d | 2023-08-09 | 2023-08-10 | 290 | 4d |  |
| 295 | 7.10.17 | Cama de arena e=0.20m | 3d | 2023-07-17 | 2023-07-19 | 284 | 2d | 0d |
| 296 | 7.10.18 | Tubería HDPE Corrugada Ø=900mm (Suministro e instalación) | 2d | 2023-07-20 | 2023-07-21 | 295 | 2d |  |
| 297 | 7.10.19 | Compuertas Charnela Ø900 (Suministro e instalacion) | 2d | 2023-08-11 | 2023-08-12 | 299 | 0d |  |
| 298 | 7.10.20 | Sello en juntas | 2d | 2023-08-13 | 2023-08-14 | 297 | 0d |  |
| 299 | 7.10.21 | Waterstop (anillos de estanqueidad) | 2d | 2023-08-09 | 2023-08-10 | 290, 296 | 0d |  |
| 300 | 7.10.22 | Pintura bituminosa | 4d | 2023-08-15 | 2023-08-18 | 294, 298 | 0d |  |
| 301 | 7.10.23 | Relleno con material granular (incluye extracción de material, zarandeo y combinación de material) | 3d | 2023-08-09 | 2023-08-11 | 290 | 294d |  |

| ID | WBS | Task | Duration | Start | Finish | Predecessors | Total slack | Free slack |
| --- | --- | --- | --- | --- | --- | --- | --- | --- |
| 302 | 7.11 | **Obras Civiles DI-PR-18-D (PAQUETE 3)** | 62d | 2023-07-10 | 2023-09-09 |  | 75d |  |
| 303 | 7.11.1 | Trazo y replanteo de interferencia | 9d | 2023-07-10 | 2023-07-18 | 279 | 318d |  |
| 304 | 7.11.2 | Desvío provisional con tubería | 7d | 2023-07-19 | 2023-07-25 | 305 | 75d | 0d |
| 305 | 7.11.3 | Limpieza de terreno manual | 9d | 2023-07-10 | 2023-07-18 | 279 | 75d | 0d |
| 306 | 7.11.4 | Excavaciones no clasificada para estructuras | 2d | 2023-07-26 | 2023-07-27 | 304 | 75d | 0d |
| 307 | 7.11.5 | Excavacion no clasificada de zanja | 2d | 2023-07-28 | 2023-07-29 | 306 | 75d | 0d |
| 308 | 7.11.6 | Relleno estructural | 11d | 2023-08-06 | 2023-08-16 | 310, 320 | 75d | 0d |
| 309 | 7.11.7 | Suministro de roca (Alcantarillas) | 5d | 2023-07-30 | 2023-08-03 | 307 | 75d | 0d |
| 310 | 7.11.8 | Colocación de roca en uña (Alcantarillas) | 2d | 2023-08-04 | 2023-08-05 | 309 | 75d | 0d |
| 311 | 7.11.9 | Concreto de Nivelacion (f'c=100 kg/cm2) | 4d | 2023-08-17 | 2023-08-20 | 290, 308 | 75d | 0d |
| 312 | 7.11.10 | Concreto Clase C (f'c=280 kg/cm2) Premezclado - Cimientos reforzados | 3d | 2023-08-21 | 2023-08-23 | 311, 315FS-1d, 316FS-7d | 75d | 0d |
| 313 | 7.11.11 | Concreto Clase C (f'c=280 kg/cm2) Premezclado - Muros de contencion | 5d | 2023-08-24 | 2023-08-28 | 312, 314FS-4d | 75d | 0d |
| 314 | 7.11.12 | Encofrado y Desencofrado Caravista | 6d | 2023-08-22 | 2023-08-27 | 315 | 75d | 0d |
| 315 | 7.11.13 | Encofrado y Desencofrado Cara Oculta | 5d | 2023-08-17 | 2023-08-21 | 308 | 75d | 0d |
| 316 | 7.11.14 | Acero de refuerzo f'y=4200kg/cm2 | 11d | 2023-08-17 | 2023-08-27 | 308 | 75d | 0d |
| 317 | 7.11.15 | Emboquillado de piedra e=0.30m | 6d | 2023-08-29 | 2023-09-03 | 313 | 265d | 0d |
| 318 | 7.11.16 | Emboquillado de piedra e=0.50m | 6d | 2023-09-04 | 2023-09-09 | 317 | 265d |  |
| 319 | 7.11.17 | Cama de arena e=0.20m | 3d | 2023-07-30 | 2023-08-01 | 307 | 77d | 0d |
| 320 | 7.11.18 | Tubería HDPE Corrugada Ø=1200mm (Suministro e instalación) | 2d | 2023-08-02 | 2023-08-03 | 319 | 77d | 2d |
| 321 | 7.11.19 | Compuertas Charnela Ø1200 (Suministro e instalacion) | 3d | 2023-08-31 | 2023-09-02 | 323 | 75d | 0d |
| 322 | 7.11.20 | Sello en juntas | 2d | 2023-09-03 | 2023-09-04 | 321 | 75d | 0d |
| 323 | 7.11.21 | Waterstop (anillos de estanqueidad) | 2d | 2023-08-29 | 2023-08-30 | 313, 320 | 75d | 0d |
| 324 | 7.11.22 | Pintura bituminosa | 5d | 2023-09-05 | 2023-09-09 | 322 | 75d |  |
| 325 | 8 | **FRENTE 2** | 399d | 2023-04-22 | 2024-05-24 |  | 7d |  |
| 326 | 8.1 | **DIQUE DI-PR-12-I (PAQUETE 2)** | 194d | 2023-04-22 | 2023-11-01 |  | 7d |  |
| 327 | 8.1.1 | **Excavaciones** | 104d | 2023-04-22 | 2023-08-03 |  | 7d |  |
| 328 | 8.1.1.1 | Desbroce | 7d | 2023-04-22 | 2023-04-28 | 3FS+20d, 23FS-10d, 748 | 7d | 0d |
| 329 | 8.1.1.2 | Remoción de dique existente | 14d | 2023-04-29 | 2023-05-12 | 328 | 7d | 0d |
| 330 | 8.1.1.3 | Excavación de cimentación | 27d | 2023-05-13 | 2023-06-08 | 329 | 7d | 0d |
| 331 | 8.1.1.4 | Perfilado y conformación de Plataforma de fundación | 33d | 2023-05-20 | 2023-06-21 | 330FS-20d | 7d | 0d |
| 332 | 8.1.1.5 | Excavación de uña | 53d | 2023-06-09 | 2023-07-31 | 330 | 17d | 0d |
| 333 | 8.1.1.6 | Conformación de material excedente en DME | 97d | 2023-04-29 | 2023-08-03 | 353FS-97d, 354FS-97d | 302d |  |
| 334 | 8.1.1.7 | Conformación de material excedente en DMO | 13d | 2023-04-22 | 2023-05-04 | 351FS-7d, 352FS-7d | 393d |  |
| 335 | 8.1.1.8 | Excavación Localizada - Sobreexcavación | 3d | 2023-08-01 | 2023-08-03 | 332 | 17d | 0d |

| ID | WBS | Task | Duration | Start | Finish | Predecessors | Total slack | Free slack |
| --- | --- | --- | --- | --- | --- | --- | --- | --- |
| 336 | 8.1.2 | **Rellenos** | 156d | 2023-05-30 | 2023-11-01 |  | 7d |  |
| 337 | 8.1.2.1 | Relleno con material granular (incluye extracción de material, zarandeo y combinación de material) | 47d | 2023-05-30 | 2023-07-15 | 331FS-23d | 7d | 0d |
| 338 | 8.1.2.2 | Relleno sin compactar | 31d | 2023-09-21 | 2023-10-21 | 348FS-31d | 212d | 0d |
| 339 | 8.1.2.3 | Relleno afirmado | 11d | 2023-10-22 | 2023-11-01 | 338 | 212d | 0d |
| 340 | 8.1.2.4 | Perfilado de Talud del dique | 19d | 2023-07-04 | 2023-07-22 | 337FS-12d | 7d | 0d |
| 341 | 8.1.2.5 | Relleno con material seleccionado (incluye extracción de material, zarandeo y combinación de material) en sobreexcavación | 46d | 2023-07-16 | 2023-08-30 | 337 | 254d | 0d |
| 342 | 8.1.2.6 | Grava para Drenaje | 21d | 2023-08-31 | 2023-09-20 | 341 | 254d |  |
| 343 | 8.1.3 | **Geotextil** | 50d | 2023-07-11 | 2023-08-29 |  | 7d |  |
| 344 | 8.1.3.1 | Instalación de Geotextil 400 gr/m2 | 49d | 2023-07-12 | 2023-08-29 | 345FS-48d | 7d | 0d |
| 345 | 8.1.3.2 | Zanja de anclaje | 49d | 2023-07-11 | 2023-08-28 | 340FS-12d | 7d | 0d |
| 346 | 8.1.4 | **Colocación de roca** | 162d | 2023-05-13 | 2023-10-21 |  | 7d |  |
| 347 | 8.1.4.1 | Colocación de roca en uña | 81d | 2023-07-18 | 2023-10-06 | 344FS-43d, 491, 349 | 7d | 0d |
| 348 | 8.1.4.2 | Colocación de roca en Talud | 65d | 2023-08-18 | 2023-10-21 | 347FS-50d | 7d | 0d |
| 349 | 8.1.4.3 | Extracción y Selección de Rocas Reutilizables (50% de roca utilizable) | 66d | 2023-05-13 | 2023-07-17 | 329 | 7d | 0d |
| 350 | 8.1.5 | **Transportes** | 194d | 2023-04-22 | 2023-11-01 |  | 212d |  |
| 351 | 8.1.5.1 | Transporte de material orgánico (a DMO) D<=1km | 7d | 2023-04-22 | 2023-04-28 | 328SS | 393d | 0d |
| 352 | 8.1.5.2 | Transporte de material orgánico (a DMO) D>1km | 7d | 2023-04-22 | 2023-04-28 | 328SS | 393d | 0d |
| 353 | 8.1.5.3 | Transporte de material excedente (dique provisional) D<=1km | 97d | 2023-04-29 | 2023-08-03 | 329SS, 335FF | 302d | 0d |
| 354 | 8.1.5.4 | Transporte de material excedente (dique provisional) D> 1km | 97d | 2023-04-29 | 2023-08-03 | 329SS, 335FF | 302d | 0d |
| 355 | 8.1.5.5 | Transporte de material de préstamo (afirmado) D<=1km | 11d | 2023-10-22 | 2023-11-01 | 339SS | 212d |  |
| 356 | 8.1.5.6 | Transporte de material de préstamo (afirmado) D>1km | 11d | 2023-10-22 | 2023-11-01 | 339SS | 212d |  |
| 357 | 8.1.5.7 | Transporte de roca D<=1km | 96d | 2023-07-18 | 2023-10-21 | 347SS, 348FF | 223d |  |
| 358 | 8.1.5.8 | Transporte de roca D>1km | 96d | 2023-07-18 | 2023-10-21 | 347SS, 348FF | 223d |  |
| 359 | 8.1.5.9 | Transporte de material de préstamo cantera de rio (cuerpo de terraplén) D<=1km | 47d | 2023-05-30 | 2023-07-15 | 337SS | 321d |  |
| 360 | 8.1.5.10 | Transporte de material de préstamo cantera de rio (cuerpo de terraplén) D>1km | 47d | 2023-05-30 | 2023-07-15 | 337SS | 321d |  |
| 361 | 8.1.5.11 | Transporte de material seleccionado para zanja D<=1km | 49d | 2023-07-11 | 2023-08-28 | 345SS | 277d |  |
| 362 | 8.1.5.12 | Transporte de material seleccionado para zanja D>1km | 49d | 2023-07-11 | 2023-08-28 | 345SS | 277d |  |

| ID | WBS | Task | Duration | Start | Finish | Predecessors | Total slack | Free slack |
| --- | --- | --- | --- | --- | --- | --- | --- | --- |
| 363 | 8.2 | **DIQUE DI-PR-13-D (PAQUETE 3)** | 157d | 2023-07-31 | 2024-01-03 |  | 17d |  |
| 364 | 8.2.1 | **Excavaciones** | 62d | 2023-07-31 | 2023-09-30 |  | 17d |  |
| 365 | 8.2.1.1 | Desbroce | 4d | 2023-07-31 | 2023-08-03 | 494 | 17d | 0d |
| 366 | 8.2.1.2 | Remoción de dique existente | 17d | 2023-08-04 | 2023-08-20 | 335, 365 | 17d | 0d |
| 367 | 8.2.1.3 | Excavación de cimentación | 19d | 2023-08-21 | 2023-09-08 | 366 | 17d | 0d |
| 368 | 8.2.1.4 | Perfilado y conformación de Plataforma de fundación | 16d | 2023-08-29 | 2023-09-13 | 367FS-11d | 213d | 0d |
| 369 | 8.2.1.5 | Excavación de uña | 20d | 2023-09-09 | 2023-09-28 | 367 | 17d | 0d |
| 370 | 8.2.1.6 | Conformación de material excedente en DME | 58d | 2023-08-04 | 2023-09-30 | 390FS-58d, 391FS-58d | 244d |  |
| 371 | 8.2.1.7 | Conformación de material excedente en DMO | 7d | 2023-07-31 | 2023-08-06 | 388FS-4d, 389FS-4d | 299d |  |
| 372 | 8.2.1.8 | Excavación Localizada - Sobreexcavación | 2d | 2023-09-29 | 2023-09-30 | 369 | 17d | 0d |
| 373 | 8.2.2 | **Rellenos** | 112d | 2023-09-14 | 2024-01-03 |  | 149d |  |
| 374 | 8.2.2.1 | Relleno con material granular (incluye extracción de material, zarandeo y combinación de material) | 25d | 2023-09-14 | 2023-10-08 | 368 | 213d | 0d |
| 375 | 8.2.2.2 | Relleno sin compactar | 18d | 2023-12-12 | 2023-12-29 | 385FS-18d | 149d | 0d |
| 376 | 8.2.2.3 | Relleno afirmado | 5d | 2023-12-30 | 2024-01-03 | 375 | 149d | 0d |
| 377 | 8.2.2.4 | Perfilado de Talud del dique | 13d | 2023-10-01 | 2023-10-13 | 374FS-8d | 213d | 0d |
| 378 | 8.2.2.5 | Relleno con material seleccionado (incluye extracción de material, zarandeo y combinación de material) en sobreexcavación | 19d | 2023-10-09 | 2023-10-27 | 374 | 215d | 0d |
| 379 | 8.2.2.6 | Grava para Drenaje | 2d | 2023-10-28 | 2023-10-29 | 378 | 215d |  |
| 380 | 8.2.3 | **Geotextil** | 26d | 2023-10-06 | 2023-10-31 |  | 213d |  |
| 381 | 8.2.3.1 | Instalación de Geotextil 400 gr/m2 | 25d | 2023-10-07 | 2023-10-31 | 382FS-24d | 213d |  |
| 382 | 8.2.3.2 | Zanja de anclaje | 25d | 2023-10-06 | 2023-10-30 | 377FS-8d | 213d | 0d |
| 383 | 8.2.4 | **Colocación de roca** | 131d | 2023-08-21 | 2023-12-29 |  | 7d |  |
| 384 | 8.2.4.1 | Colocación de roca en uña | 61d | 2023-10-07 | 2023-12-06 | 347, 518, 386FS-4d | 17d | 0d |
| 385 | 8.2.4.2 | Colocación de roca en Talud | 69d | 2023-10-22 | 2023-12-29 | 348 | 7d | 0d |
| 386 | 8.2.4.3 | Extracción y Selección de Rocas Reutilizables (50% de roca utilizable) | 51d | 2023-08-21 | 2023-10-10 | 366 | 17d | 0d |

| ID | WBS | Task | Duration | Start | Finish | Predecessors | Total slack | Free slack |
| --- | --- | --- | --- | --- | --- | --- | --- | --- |
| 387 | 8.2.5 | **Transportes** | 157d | 2023-07-31 | 2024-01-03 |  | 149d |  |
| 388 | 8.2.5.1 | Transporte de material orgánico (a DMO) D<=1km | 4d | 2023-07-31 | 2023-08-03 | 365SS | 299d | 0d |
| 389 | 8.2.5.2 | Transporte de material orgánico (a DMO) D>1km | 4d | 2023-07-31 | 2023-08-03 | 365SS | 299d | 0d |
| 390 | 8.2.5.3 | Transporte de material excedente (dique provisional) D<=1km | 58d | 2023-08-04 | 2023-09-30 | 366SS, 372FF | 244d | 0d |
| 391 | 8.2.5.4 | Transporte de material excedente (dique provisional) D> 1km | 58d | 2023-08-04 | 2023-09-30 | 366SS, 372FF | 244d | 0d |
| 392 | 8.2.5.5 | Transporte de material de préstamo (afirmado) D<=1km | 5d | 2023-12-30 | 2024-01-03 | 376SS | 149d |  |
| 393 | 8.2.5.6 | Transporte de material de préstamo (afirmado) D>1km | 5d | 2023-12-30 | 2024-01-03 | 376SS | 149d |  |
| 394 | 8.2.5.7 | Transporte de roca D<=1km | 84d | 2023-10-07 | 2023-12-29 | 384SS, 385FF | 154d |  |
| 395 | 8.2.5.8 | Transporte de roca D>1km | 84d | 2023-10-07 | 2023-12-29 | 384SS, 385FF | 154d |  |
| 396 | 8.2.5.9 | Transporte de material de préstamo cantera de rio (cuerpo de terraplén) D<=1km | 25d | 2023-09-14 | 2023-10-08 | 374SS | 236d |  |
| 397 | 8.2.5.10 | Transporte de material de préstamo cantera de rio (cuerpo de terraplén) D>1km | 25d | 2023-09-14 | 2023-10-08 | 374SS | 236d |  |
| 398 | 8.2.5.11 | Transporte de material seleccionado para zanja D<= 1km | 25d | 2023-10-06 | 2023-10-30 | 382SS | 214d |  |
| 399 | 8.2.5.12 | Transporte de material seleccionado para zanja D> 1km | 25d | 2023-10-06 | 2023-10-30 | 382SS | 214d |  |
| 400 | 8.3 | **DIQUE DI-PR-17-D (PAQUETE 3)** | 170d | 2023-09-29 | 2024-03-16 |  | 17d |  |
| 401 | 8.3.1 | **Excavaciones** | 32d | 2023-09-29 | 2023-10-30 |  | 17d |  |
| 402 | 8.3.1.1 | Desbroce | 2d | 2023-09-29 | 2023-09-30 | 533FS+38d | 17d | 0d |
| 403 | 8.3.1.2 | Remoción de dique existente | 17d | 2023-10-01 | 2023-10-17 | 372, 402 | 17d | 0d |
| 404 | 8.3.1.3 | Excavación de cimentación | 6d | 2023-10-18 | 2023-10-23 | 403 | 17d | 0d |
| 405 | 8.3.1.4 | Perfilado y conformación de Plataforma de fundación | 7d | 2023-10-24 | 2023-10-30 | 404 | 17d | 0d |
| 406 | 8.3.1.5 | Excavación de uña | 6d | 2023-10-24 | 2023-10-29 | 404 | 215d | 0d |
| 407 | 8.3.2 | **Rellenos** | 138d | 2023-10-31 | 2024-03-16 |  | 17d |  |
| 408 | 8.3.2.1 | Relleno con material granular (incluye extracción de material, zarandeo y combinación de material) | 24d | 2023-10-31 | 2023-11-23 | 405 | 17d | 0d |
| 409 | 8.3.2.2 | Relleno sin compactar | 5d | 2024-03-09 | 2024-03-13 | 417FS-5d | 76d | 0d |
| 410 | 8.3.2.3 | Relleno afirmado | 3d | 2024-03-14 | 2024-03-16 | 409 | 76d | 0d |
| 411 | 8.3.2.4 | Perfilado de Talud del dique | 6d | 2023-11-24 | 2023-11-29 | 408 | 17d | 0d |

| ID | WBS | Task | Duration | Start | Finish | Predecessors | Total slack | Free slack |
| --- | --- | --- | --- | --- | --- | --- | --- | --- |
| 412 | 8.3.3 | **Geotextil** | 11d | 2023-11-30 | 2023-12-10 |  | 17d |  |
| 413 | 8.3.3.1 | Instalación de Geotextil 400 gr/m2 | 10d | 2023-12-01 | 2023-12-10 | 414FS-9d | 17d | 0d |
| 414 | 8.3.3.2 | Zanja de anclaje | 10d | 2023-11-30 | 2023-12-09 | 411 | 17d | 0d |
| 415 | 8.3.4 | **Colocación de roca** | 148d | 2023-10-18 | 2024-03-13 |  | 17d |  |
| 416 | 8.3.4.1 | Colocación de roca en uña | 98d | 2023-12-07 | 2024-03-13 | 384, 531, 413FS-4d, 418 | 17d | 0d |
| 417 | 8.3.4.2 | Colocación de roca en Talud | 75d | 2023-12-30 | 2024-03-13 | 385 | 7d | 0d |
| 418 | 8.3.4.3 | Extracción y Selección de Rocas Reutilizables (50% de roca utilizable) | 50d | 2023-10-18 | 2023-12-06 | 403 | 17d | 0d |
| 419 | 8.3.5 | **Transportes** | 170d | 2023-09-29 | 2024-03-16 |  | 76d |  |
| 420 | 8.3.5.1 | Transporte de material orgánico (a DMO) D<=1km | 2d | 2023-09-29 | 2023-09-30 | 402SS | 244d |  |
| 421 | 8.3.5.2 | Transporte de material orgánico (a DMO) D>1km | 2d | 2023-09-29 | 2023-09-30 | 402SS | 244d |  |
| 422 | 8.3.5.3 | Transporte de material excedente (dique provisional) D<=1km | 29d | 2023-10-01 | 2023-10-29 | 403SS, 406FF | 215d |  |
| 423 | 8.3.5.4 | Transporte de material excedente (dique provisional) D> 1km | 29d | 2023-10-01 | 2023-10-29 | 403SS, 406FF | 215d |  |
| 424 | 8.3.5.5 | Transporte de material de préstamo (afirmado) D<=1km | 3d | 2024-03-14 | 2024-03-16 | 410SS | 76d |  |
| 425 | 8.3.5.6 | Transporte de material de préstamo (afirmado) D>1km | 3d | 2024-03-14 | 2024-03-16 | 410SS | 76d |  |
| 426 | 8.3.5.7 | Transporte de roca D<=1km | 98d | 2023-12-07 | 2024-03-13 | 416SS, 417FF | 79d |  |
| 427 | 8.3.5.8 | Transporte de roca D>1km | 98d | 2023-12-07 | 2024-03-13 | 416SS, 417FF | 79d |  |
| 428 | 8.3.5.9 | Transporte de material de préstamo cantera de rio (cuerpo de terraplén) D<=1km | 24d | 2023-10-31 | 2023-11-23 | 408SS | 190d |  |
| 429 | 8.3.5.10 | Transporte de material de préstamo cantera de rio (cuerpo de terraplén) D>1km | 24d | 2023-10-31 | 2023-11-23 | 408SS | 190d |  |
| 430 | 8.3.5.11 | Transporte de material seleccionado para zanja D<= 1km | 10d | 2023-11-30 | 2023-12-09 | 414SS | 174d |  |
| 431 | 8.3.5.12 | Transporte de material seleccionado para zanja D> 1km | 10d | 2023-11-30 | 2023-12-09 | 414SS | 174d |  |
| 432 | 8.4 | **DIQUE DI-PR-16-D (PAQUETE 3)** | 112d | 2024-02-03 | 2024-05-24 |  | 7d |  |
| 433 | 8.4.1 | **Excavaciones** | 25d | 2024-02-03 | 2024-02-27 |  | 17d |  |
| 434 | 8.4.1.1 | Desbroce | 2d | 2024-02-03 | 2024-02-04 | 402FS+125d | 17d | 0d |
| 435 | 8.4.1.2 | Remoción de dique existente | 6d | 2024-02-05 | 2024-02-10 | 434 | 17d | 0d |
| 436 | 8.4.1.3 | Excavación de cimentación | 3d | 2024-02-11 | 2024-02-13 | 435 | 17d | 0d |
| 437 | 8.4.1.4 | Perfilado y conformación de Plataforma de fundación | 4d | 2024-02-14 | 2024-02-17 | 436 | 17d | 0d |
| 438 | 8.4.1.5 | Excavación de uña | 11d | 2024-02-14 | 2024-02-24 | 436 | 94d | 0d |
| 439 | 8.4.1.6 | Excavación Localizada - Sobreexcavación | 3d | 2024-02-25 | 2024-02-27 | 438 | 94d | 0d |

| ID | WBS | Task | Duration | Start | Finish | Predecessors | Total slack | Free slack |
| --- | --- | --- | --- | --- | --- | --- | --- | --- |
| 440 | 8.4.2 | **Rellenos** | 97d | 2024-02-18 | 2024-05-24 |  | 7d |  |
| 441 | 8.4.2.1 | Relleno con material granular (incluye extracción de material, zarandeo y combinación de material) | 9d | 2024-02-18 | 2024-02-26 | 437 | 17d | 0d |
| 442 | 8.4.2.2 | Relleno sin compactar | 7d | 2024-05-15 | 2024-05-21 | 451 | 7d | 0d |
| 443 | 8.4.2.3 | Relleno afirmado | 3d | 2024-05-22 | 2024-05-24 | 442 | 7d | 0d |
| 444 | 8.4.2.4 | Perfilado de Talud del dique | 3d | 2024-02-27 | 2024-02-29 | 441 | 17d | 0d |
| 445 | 8.4.2.5 | Relleno con material seleccionado (incluye extracción de material, zarandeo y combinación de material) en sobreexcavación | 31d | 2024-02-27 | 2024-03-28 | 441 | 64d |  |
| 446 | 8.4.3 | **Geotextil** | 13d | 2024-03-01 | 2024-03-13 |  | 17d |  |
| 447 | 8.4.3.1 | Instalación de Geotextil 400 gr/m2 | 12d | 2024-03-02 | 2024-03-13 | 448FS-11d | 17d | 0d |
| 448 | 8.4.3.2 | Zanja de anclaje | 12d | 2024-03-01 | 2024-03-12 | 444 | 17d | 0d |
| 449 | 8.4.4 | **Colocación de roca** | 94d | 2024-02-11 | 2024-05-14 |  | 13d |  |
| 450 | 8.4.4.1 | Colocación de roca en uña | 58d | 2024-03-14 | 2024-05-10 | 416, 559, 447, 452FS-12d | 17d | 0d |
| 451 | 8.4.4.2 | Colocación de roca en Talud | 62d | 2024-03-14 | 2024-05-14 | 417 | 7d | 0d |
| 452 | 8.4.4.3 | Extracción y Selección de Rocas Reutilizables (50% de roca utilizable) | 44d | 2024-02-11 | 2024-03-25 | 435 | 17d | 0d |
| 453 | 8.4.5 | **Transportes** | 112d | 2024-02-03 | 2024-05-24 |  | 7d |  |
| 454 | 8.4.5.1 | Transporte de material orgánico (a DMO) D<=1km | 2d | 2024-02-03 | 2024-02-04 | 434SS | 117d |  |
| 455 | 8.4.5.2 | Transporte de material orgánico (a DMO) D>1km | 2d | 2024-02-03 | 2024-02-04 | 434SS | 117d |  |
| 456 | 8.4.5.3 | Transporte de material excedente (dique provisional) D<=1km | 23d | 2024-02-05 | 2024-02-27 | 435SS, 439FF | 94d |  |
| 457 | 8.4.5.4 | Transporte de material excedente (dique provisional) D> 1km | 23d | 2024-02-05 | 2024-02-27 | 435SS, 439FF | 94d |  |
| 458 | 8.4.5.5 | Transporte de material de préstamo (afirmado) D<=1km | 3d | 2024-05-22 | 2024-05-24 | 443SS | 7d |  |
| 459 | 8.4.5.6 | Transporte de material de préstamo (afirmado) D>1km | 3d | 2024-05-22 | 2024-05-24 | 443SS | 7d |  |
| 460 | 8.4.5.7 | Transporte de roca D<=1km | 62d | 2024-03-14 | 2024-05-14 | 450SS, 451FF | 17d |  |
| 461 | 8.4.5.8 | Transporte de roca D>1km | 62d | 2024-03-14 | 2024-05-14 | 450SS, 451FF | 17d |  |
| 462 | 8.4.5.9 | Transporte de material de préstamo cantera de rio (cuerpo de terraplén) D<=1km | 9d | 2024-02-18 | 2024-02-26 | 441SS | 95d |  |
| 463 | 8.4.5.10 | Transporte de material seleccionado para zanja D<= 1km | 12d | 2024-03-01 | 2024-03-12 | 448SS | 80d |  |

| ID | WBS | Task | Duration | Start | Finish | Predecessors | Total slack | Free slack |
| --- | --- | --- | --- | --- | --- | --- | --- | --- |
| 464 | 8.5 | **Obras Civiles DI-PR-12-I (PAQUETE 2)** | 87d | 2023-04-22 | 2023-07-17 |  | 7d |  |
| 465 | 8.5.1 | Trazo y replanteo de interferencia | 32d | 2023-04-22 | 2023-05-23 | 3FS+20d, 23FS-10d | 374d |  |
| 466 | 8.5.2 | Desvío provisional con tubería | 9d | 2023-04-26 | 2023-05-04 | 468 | 7d | 0d |
| 467 | 8.5.3 | Desvío provisional en tierras | 13d | 2023-05-05 | 2023-05-17 | 466 | 7d | 0d |
| 468 | 8.5.4 | Limpieza de terreno manual | 4d | 2023-04-22 | 2023-04-25 | 3FS+20d, 23FS-10d | 7d | 0d |
| 469 | 8.5.5 | Excavaciones no clasificada para estructuras | 3d | 2023-05-18 | 2023-05-20 | 467 | 7d | 0d |
| 470 | 8.5.6 | Excavacion no clasificada de zanja | 12d | 2023-05-21 | 2023-06-01 | 469 | 7d | 0d |
| 471 | 8.5.7 | Relleno estructural | 11d | 2023-06-09 | 2023-06-19 | 473 | 7d | 0d |
| 472 | 8.5.8 | Suministro de roca (Alcantarillas) | 5d | 2023-06-02 | 2023-06-06 | 470 | 7d | 0d |
| 473 | 8.5.9 | Colocación de roca en uña (Alcantarillas) | 2d | 2023-06-07 | 2023-06-08 | 472 | 7d | 0d |
| 474 | 8.5.10 | Concreto de Nivelacion (f'c=100 kg/cm2) | 2d | 2023-06-20 | 2023-06-21 | 471 | 7d | 0d |
| 475 | 8.5.11 | Concreto Clase F (f'c=140 kg/cm2) | 3d | 2023-06-22 | 2023-06-24 | 474 | 7d | 0d |
| 476 | 8.5.12 | Concreto Clase C (f'c=280 kg/cm2) Premezclado - Cimientos reforzados | 3d | 2023-06-25 | 2023-06-27 | 475, 479FS-2d, 480FS-7d | 7d | 0d |
| 477 | 8.5.13 | Concreto Clase C (f'c=280 kg/cm2) Premezclado - Muros de contencion | 5d | 2023-06-28 | 2023-07-02 | 476, 478FS-4d | 7d | 0d |
| 478 | 8.5.14 | Encofrado y Desencofrado Caravista | 5d | 2023-06-27 | 2023-07-01 | 479 | 7d | 0d |
| 479 | 8.5.15 | Encofrado y Desencofrado Cara Oculta | 7d | 2023-06-20 | 2023-06-26 | 471 | 7d | 0d |
| 480 | 8.5.16 | Acero de refuerzo f'y=4200kg/cm2 | 12d | 2023-06-20 | 2023-07-01 | 471 | 7d | 0d |
| 481 | 8.5.17 | Emboquillado de piedra e=0.20m | 2d | 2023-07-03 | 2023-07-04 | 477 | 325d | 0d |
| 482 | 8.5.18 | Emboquillado de piedra e=0.30m | 5d | 2023-07-05 | 2023-07-09 | 481 | 325d | 0d |
| 483 | 8.5.19 | Emboquillado de piedra e=0.50m | 2d | 2023-07-10 | 2023-07-11 | 482 | 325d |  |
| 484 | 8.5.20 | Cama de arena e=0.20m | 5d | 2023-06-02 | 2023-06-06 | 470 | 31d | 0d |
| 485 | 8.5.21 | Tubería HDPE Corrugada Ø=900mm (Suministro e instalación) | 2d | 2023-06-07 | 2023-06-08 | 484 | 31d | 0d |
| 486 | 8.5.22 | Tubería HDPE Corrugada Ø=1200mm (Suministro e instalación) | 2d | 2023-06-09 | 2023-06-10 | 485 | 31d | 24d |
| 487 | 8.5.23 | Compuertas Charnela Ø900 (Suministro e instalacion) | 4d | 2023-07-05 | 2023-07-08 | 490, 486 | 7d | 0d |
| 488 | 8.5.24 | Compuertas Charnela Ø1200 (Suministro e instalacion) | 3d | 2023-07-09 | 2023-07-11 | 487 | 7d | 0d |
| 489 | 8.5.25 | Sello en juntas | 2d | 2023-07-12 | 2023-07-13 | 488 | 7d | 0d |
| 490 | 8.5.26 | Waterstop (anillos de estanqueidad) | 2d | 2023-07-03 | 2023-07-04 | 477 | 7d | 0d |
| 491 | 8.5.27 | Pintura bituminosa | 4d | 2023-07-14 | 2023-07-17 | 489 | 7d | 0d |
| 492 | 8.5.28 | Relleno con material granular (incluye extracción de material, zarandeo y combinación de material) | 11d | 2023-07-03 | 2023-07-13 | 477 | 323d |  |

| ID | WBS | Task | Duration | Start | Finish | Predecessors | Total slack | Free slack |
| --- | --- | --- | --- | --- | --- | --- | --- | --- |
| 493 | 8.6 | **Obras Civiles DI-PR-13-D (PAQUETE 3)** | 96d | 2023-07-03 | 2023-10-06 |  | 17d |  |
| 494 | 8.6.1 | Trazo y replanteo de interferencia | 28d | 2023-07-03 | 2023-07-30 | 4 | 17d | 0d |
| 495 | 8.6.2 | Desvío provisional con tubería | 12d | 2023-07-06 | 2023-07-17 | 497 | 17d | 0d |
| 496 | 8.6.3 | Desvío provisional en tierras | 10d | 2023-07-18 | 2023-07-27 | 495 | 17d | 0d |
| 497 | 8.6.4 | Limpieza de terreno manual | 3d | 2023-07-03 | 2023-07-05 | 4 | 17d | 0d |
| 498 | 8.6.5 | Excavaciones no clasificada para estructuras | 3d | 2023-07-28 | 2023-07-30 | 496 | 17d | 0d |
| 499 | 8.6.6 | Excavacion no clasificada de zanja | 14d | 2023-07-31 | 2023-08-13 | 498 | 17d | 0d |
| 500 | 8.6.7 | Relleno estructural | 10d | 2023-09-03 | 2023-09-12 | 502 | 17d | 0d |
| 501 | 8.6.8 | Suministro de roca (Alcantarillas) | 14d | 2023-08-14 | 2023-08-27 | 499 | 17d | 0d |
| 502 | 8.6.9 | Colocación de roca en uña (Alcantarillas) | 6d | 2023-08-28 | 2023-09-02 | 501 | 17d | 0d |
| 503 | 8.6.10 | Concreto de Nivelacion (f'c=100 kg/cm2) | 3d | 2023-09-11 | 2023-09-13 | 500FS-2d | 17d | 0d |
| 504 | 8.6.11 | Concreto Clase C (f'c=280 kg/cm2) Premezclado - Cimientos reforzados | 4d | 2023-09-14 | 2023-09-17 | 503, 507FS-3d, 508FS-8d | 17d | 0d |
| 505 | 8.6.12 | Concreto Clase C (f'c=280 kg/cm2) Premezclado - Muros de contencion | 6d | 2023-09-18 | 2023-09-23 | 504, 506FS-4d | 17d | 0d |
| 506 | 8.6.13 | Encofrado y Desencofrado Caravista | 5d | 2023-09-17 | 2023-09-21 | 507 | 17d | 0d |
| 507 | 8.6.14 | Encofrado y Desencofrado Cara Oculta | 6d | 2023-09-11 | 2023-09-16 | 500FS-2d | 17d | 0d |
| 508 | 8.6.15 | Acero de refuerzo f'y=4200kg/cm2 | 10d | 2023-09-12 | 2023-09-21 | 500FS-1d | 17d | 0d |
| 509 | 8.6.16 | Emboquillado de piedra e=0.20m | 2d | 2023-09-24 | 2023-09-25 | 505 | 240d | 0d |
| 510 | 8.6.17 | Emboquillado de piedra e=0.30m | 6d | 2023-09-26 | 2023-10-01 | 509 | 240d | 0d |
| 511 | 8.6.18 | Emboquillado de piedra e=0.50m | 3d | 2023-10-02 | 2023-10-04 | 510 | 240d |  |
| 512 | 8.6.19 | Cama de arena e=0.20m | 4d | 2023-08-14 | 2023-08-17 | 499 | 52d | 0d |
| 513 | 8.6.20 | Tubería HDPE Corrugada Ø=900mm (Suministro e instalación) | 2d | 2023-08-18 | 2023-08-19 | 512 | 52d | 0d |
| 514 | 8.6.21 | Tubería HDPE Corrugada Ø=1200mm (Suministro e instalación) | 2d | 2023-08-20 | 2023-08-21 | 513 | 52d | 35d |
| 515 | 8.6.22 | Compuertas Charnela Ø1200 (Suministro e instalacion) | 2d | 2023-09-26 | 2023-09-27 | 514, 517 | 17d | 0d |
| 516 | 8.6.23 | Sello en juntas | 2d | 2023-09-28 | 2023-09-29 | 515 | 17d | 0d |
| 517 | 8.6.24 | Waterstop (anillos de estanqueidad) | 2d | 2023-09-24 | 2023-09-25 | 505 | 17d | 0d |
| 518 | 8.6.25 | Pintura bituminosa | 7d | 2023-09-30 | 2023-10-06 | 516 | 17d | 0d |
| 519 | 8.6.26 | Relleno con material granular (incluye extracción de material, zarandeo y combinación de material) | 3d | 2023-09-24 | 2023-09-26 | 505 | 248d |  |
| 520 | 8.6.27 | Concreto clase D (fc=210 kg/cm2) premezclado-cimientos reforzados | 2d | 2023-09-24 | 2023-09-25 | 505 | 238d | 0d |
| 521 | 8.6.28 | Baranda metálica en acero ø 1 1/2" h=1.00m | 2d | 2023-09-25 | 2023-09-26 | 520FS-1d | 248d |  |
| 522 | 8.6.29 | Compuerta plana mural 1.40mx1.40m (suministro e instalación) | 2d | 2023-09-26 | 2023-09-27 | 520 | 238d | 0d |
| 523 | 8.6.30 | Rejilla metalica de 1.80mx(2.68m-3.03m) (suministro e instalación) | 5d | 2023-09-27 | 2023-10-01 | 522FS-1d | 238d | 0d |
| 524 | 8.6.31 | Compuerta plana mural 1.10mx1.10m (suministro e instalacion) | 6d | 2023-09-28 | 2023-10-03 | 523FS-4d | 238d | 0d |
| 525 | 8.6.32 | Rejilla metalica de 1.80mx(2.23m-2.52m) (suministro e instalación) | 5d | 2023-10-02 | 2023-10-06 | 524FS-2d | 238d |  |

| ID | WBS | Task | Duration | Start | Finish | Predecessors | Total slack | Free slack |
| --- | --- | --- | --- | --- | --- | --- | --- | --- |
| 526 | 8.7 | **Obras Civiles DI-PR-17-D (PAQUETE 3)** | 69d | 2023-08-04 | 2023-10-11 |  | 17d |  |
| 527 | 8.7.1 | Trazo y replanteo de interferencia | 14d | 2023-08-04 | 2023-08-17 | 365 | 17d | 0d |
| 528 | 8.7.2 | Desvío provisional en tierras | 41d | 2023-08-18 | 2023-09-27 | 527, 529 | 73d | 0d |
| 529 | 8.7.3 | Limpieza de terreno manual | 14d | 2023-08-04 | 2023-08-17 | 365 | 73d | 0d |
| 530 | 8.7.4 | Excavacion no clasificada de zanja | 12d | 2023-09-28 | 2023-10-09 | 528 | 73d | 0d |
| 531 | 8.7.5 | Relleno estructural | 2d | 2023-10-10 | 2023-10-11 | 530 | 73d | 56d |
| 532 | 8.8 | **Obras Civiles DI-PR-16-D (PAQUETE 3)** | 70d | 2023-08-18 | 2023-10-26 |  | 17d |  |
| 533 | 8.8.1 | Trazo y replanteo de interferencia | 4d | 2023-08-18 | 2023-08-21 | 527 | 17d | 0d |
| 534 | 8.8.2 | Desvío provisional con tubería | 7d | 2023-08-20 | 2023-08-26 | 536 | 156d | 0d |
| 535 | 8.8.3 | Desvío provisional en tierras | 2d | 2023-08-27 | 2023-08-28 | 534 | 156d | 0d |
| 536 | 8.8.4 | Limpieza de terreno manual | 2d | 2023-08-18 | 2023-08-19 | 529 | 156d | 0d |
| 537 | 8.8.5 | Excavaciones no clasificada para estructuras | 4d | 2023-08-29 | 2023-09-01 | 535 | 156d | 0d |
| 538 | 8.8.6 | Excavacion no clasificada de zanja | 2d | 2023-09-02 | 2023-09-03 | 537 | 156d | 0d |
| 539 | 8.8.7 | Relleno estructural | 7d | 2023-09-17 | 2023-09-23 | 541 | 156d | 0d |
| 540 | 8.8.8 | Suministro de roca (Alcantarillas) | 10d | 2023-09-04 | 2023-09-13 | 538 | 156d | 0d |
| 541 | 8.8.9 | Colocación de roca en uña (Alcantarillas) | 3d | 2023-09-14 | 2023-09-16 | 540 | 156d | 0d |
| 542 | 8.8.10 | Concreto de Nivelacion (f'c=100 kg/cm2) | 2d | 2023-09-24 | 2023-09-25 | 539 | 156d | 0d |
| 543 | 8.8.11 | Concreto Clase F (f'c=140 kg/cm2) | 3d | 2023-09-26 | 2023-09-28 | 542 | 156d | 0d |
| 544 | 8.8.12 | Concreto Clase C (f'c=280 kg/cm2) Premezclado - Cimientos reforzados | 3d | 2023-09-29 | 2023-10-01 | 543, 547FS-2d, 548FS-9d | 156d | 0d |
| 545 | 8.8.13 | Concreto Clase C (f'c=280 kg/cm2) Premezclado - Muros de contencion | 6d | 2023-10-02 | 2023-10-07 | 544, 546FS-6d | 156d | 0d |
| 546 | 8.8.14 | Encofrado y Desencofrado Caravista | 6d | 2023-10-01 | 2023-10-06 | 547 | 157d | 1d |
| 547 | 8.8.15 | Encofrado y Desencofrado Cara Oculta | 9d | 2023-09-22 | 2023-09-30 | 539FS-2d | 156d | 0d |
| 548 | 8.8.16 | Acero de refuerzo f'y=4200kg/cm2 | 14d | 2023-09-23 | 2023-10-06 | 539FS-1d | 157d | 1d |
| 549 | 8.8.17 | Emboquillado de piedra e=0.20m | 2d | 2023-10-08 | 2023-10-09 | 545 | 233d | 0d |
| 550 | 8.8.18 | Emboquillado de piedra e=0.30m | 2d | 2023-10-10 | 2023-10-11 | 549 | 233d |  |
| 551 | 8.8.19 | Sello en juntas | 2d | 2023-10-10 | 2023-10-11 | 552 | 228d | 0d |
| 552 | 8.8.20 | Waterstop (anillos de estanqueidad) | 2d | 2023-10-08 | 2023-10-09 | 545 | 228d | 0d |
| 553 | 8.8.21 | Pintura bituminosa | 5d | 2023-10-12 | 2023-10-16 | 551 | 228d |  |
| 554 | 8.8.22 | Suministro e instalacion de geotextil | 2d | 2023-10-06 | 2023-10-07 | 545FS-2d | 237d |  |
| 555 | 8.8.23 | Concreto clase D (fc=210 kg/cm2) premezclado-cimientos reforzados | 2d | 2023-10-08 | 2023-10-09 | 545 | 156d | 0d |
| 556 | 8.8.24 | Baranda metálica en acero ø 1 1/2" h=1.00m | 2d | 2023-10-09 | 2023-10-10 | 555FS-1d | 234d |  |
| 557 | 8.8.25 | Compuerta plana tipo tarjeta 0.60mx0.30m(suministro e instalación) | 3d | 2023-10-17 | 2023-10-19 | 562 | 156d | 0d |
| 558 | 8.8.26 | Compuerta plana mural 2.20mx2.20m (suministro e instalación) | 2d | 2023-10-20 | 2023-10-21 | 557 | 156d | 0d |
| 559 | 8.8.27 | Rejilla metálica 2.00mx(2.30m-2.30m) (suministro e instalacion) | 5d | 2023-10-22 | 2023-10-26 | 558 | 156d | 139d |
| 560 | 8.8.28 | Tubería astm a53 sch-40 dn300mm hd | 3d | 2023-10-10 | 2023-10-12 | 555 | 156d | 0d |
| 561 | 8.8.29 | Unión flexible tipo desser dn300mm hd | 2d | 2023-10-13 | 2023-10-14 | 560 | 156d | 0d |
| 562 | 8.8.30 | Niple espiga-espiga con brida rompeagua de ffd dn300mm l=0.50m | 2d | 2023-10-15 | 2023-10-16 | 561 | 156d | 0d |

| ID | WBS | Task | Duration | Start | Finish | Predecessors | Total slack | Free slack |
| --- | --- | --- | --- | --- | --- | --- | --- | --- |
| 563 | 9 | **FRENTE 3** | 334d | 2023-07-03 | 2024-05-31 |  | 0d |  |
| 564 | 9.1 | **DIQUE DI-PR-19A-3-D (PAQUETE 3)** | 162d | 2023-07-03 | 2023-12-11 |  | 0d |  |
| 565 | 9.1.1 | **Excavaciones** | 66d | 2023-07-03 | 2023-09-06 |  | 0d |  |
| 566 | 9.1.1.1 | Desbroce | 5d | 2023-07-03 | 2023-07-07 | 4 | 0d |  |
| 567 | 9.1.1.2 | Remoción de dique existente | 20d | 2023-07-08 | 2023-07-27 | 566 | 0d |  |
| 568 | 9.1.1.3 | Excavación de cimentación | 12d | 2023-07-28 | 2023-08-08 | 567 | 0d |  |
| 569 | 9.1.1.4 | Perfilado y conformación de Plataforma de fundación | 18d | 2023-07-29 | 2023-08-15 | 568FS-11d | 0d |  |
| 570 | 9.1.1.5 | Excavación de uña | 25d | 2023-08-09 | 2023-09-02 | 568 | 0d |  |
| 571 | 9.1.1.6 | Conformación de material excedente en DME | 61d | 2023-07-08 | 2023-09-06 | 590FS-61d, 591FS-61d | 268d |  |
| 572 | 9.1.1.7 | Conformación de material excedente en DMO | 11d | 2023-07-03 | 2023-07-13 | 588FS-5d, 589FS-5d | 323d |  |
| 573 | 9.1.1.8 | Excavación Localizada - Sobreexcavación | 4d | 2023-09-03 | 2023-09-06 | 570 | 0d |  |
| 574 | 9.1.2 | **Rellenos** | 134d | 2023-07-31 | 2023-12-11 |  | 0d |  |
| 575 | 9.1.2.1 | Relleno con material granular (incluye extracción de material, zarandeo y combinac | 20d | 2023-07-31 | 2023-08-19 | 569FS-16d | 0d |  |
| 576 | 9.1.2.2 | Relleno sin compactar | 16d | 2023-11-21 | 2023-12-06 | 585 | 172d | 0d |
| 577 | 9.1.2.3 | Relleno afirmado | 5d | 2023-12-07 | 2023-12-11 | 576 | 172d | 0d |
| 578 | 9.1.2.4 | Perfilado de Talud del dique | 10d | 2023-08-12 | 2023-08-21 | 575FS-8d | 0d |  |
| 579 | 9.1.2.5 | Relleno con material seleccionado (incluye extracción de material, zarandeo y combinación de material) en sobreexcavación | 60d | 2023-08-20 | 2023-10-18 | 575 | 226d |  |
| 580 | 9.1.3 | **Geotextil** | 29d | 2023-08-13 | 2023-09-10 |  | 0d |  |
| 581 | 9.1.3.1 | Instalación de Geotextil 400 gr/m2 | 28d | 2023-08-14 | 2023-09-10 | 582FS-27d | 0d |  |
| 582 | 9.1.3.2 | Zanja de anclaje | 28d | 2023-08-13 | 2023-09-09 | 578FS-9d | 0d |  |
| 583 | 9.1.4 | **Colocación de roca** | 116d | 2023-07-28 | 2023-11-20 |  | 0d |  |
| 584 | 9.1.4.1 | Colocación de roca en uña | 69d | 2023-08-17 | 2023-10-24 | 581FS-25d, 675 | 0d |  |
| 585 | 9.1.4.2 | Colocación de roca en Talud | 77d | 2023-09-05 | 2023-11-20 | 586, 584FS-50d | 0d |  |
| 586 | 9.1.4.3 | Extracción y Selección de Rocas Reutilizables (50% de roca utilizable) | 39d | 2023-07-28 | 2023-09-04 | 567 | 0d |  |

| ID | WBS | Task | Duration | Start | Finish | Predecessors | Total slack | Free slack |
| --- | --- | --- | --- | --- | --- | --- | --- | --- |
| 587 | 9.1.5 | **Transportes** | 162d | 2023-07-03 | 2023-12-11 |  | 172d |  |
| 588 | 9.1.5.1 | Transporte de material orgánico (a DMO) D<=1km | 5d | 2023-07-03 | 2023-07-07 | 566SS | 323d | 0d |
| 589 | 9.1.5.2 | Transporte de material orgánico (a DMO) D>1km | 5d | 2023-07-03 | 2023-07-07 | 566SS | 323d | 0d |
| 590 | 9.1.5.3 | Transporte de material excedente (dique provisional) D<=1km | 61d | 2023-07-08 | 2023-09-06 | 567SS, 573FF | 268d | 0d |
| 591 | 9.1.5.4 | Transporte de material excedente (dique provisional) D>1km | 61d | 2023-07-08 | 2023-09-06 | 567SS, 573FF | 268d | 0d |
| 592 | 9.1.5.5 | Transporte de material de préstamo (afirmado) D<=1km | 5d | 2023-12-07 | 2023-12-11 | 577SS | 172d |  |
| 593 | 9.1.5.6 | Transporte de material de préstamo (afirmado) D>1km | 5d | 2023-12-07 | 2023-12-11 | 577SS | 172d |  |
| 594 | 9.1.5.7 | Transporte de roca D<=1km | 96d | 2023-08-17 | 2023-11-20 | 584SS, 585FF | 193d |  |
| 595 | 9.1.5.8 | Transporte de roca D>1km | 96d | 2023-08-17 | 2023-11-20 | 584SS, 585FF | 193d |  |
| 596 | 9.1.5.9 | Transporte de material de préstamo cantera de rio (cuerpo de terraplén) D<=1km | 20d | 2023-07-31 | 2023-08-19 | 575SS | 286d |  |
| 597 | 9.1.5.10 | Transporte de material de préstamo cantera de rio (cuerpo de terraplén) D>1km | 20d | 2023-07-31 | 2023-08-19 | 575SS | 286d |  |
| 598 | 9.1.5.11 | Transporte de material seleccionado para zanja D<= 1km | 28d | 2023-08-13 | 2023-09-09 | 582SS | 265d |  |
| 599 | 9.1.5.12 | Transporte de material seleccionado para zanja D>1km | 28d | 2023-08-13 | 2023-09-09 | 582SS | 265d |  |
| 600 | 9.2 | **DIQUE DI-PR-19A-2-D (PAQUETE 3)** | 229d | 2023-08-31 | 2024-04-15 |  | 0d |  |
| 601 | 9.2.1 | **Excavaciones** | 77d | 2023-08-31 | 2023-11-15 |  | 0d |  |
| 602 | 9.2.1.1 | Desbroce | 7d | 2023-08-31 | 2023-09-06 | 566FS+54d | 0d |  |
| 603 | 9.2.1.2 | Remoción de dique existente | 11d | 2023-09-07 | 2023-09-17 | 573, 602 | 0d |  |
| 604 | 9.2.1.3 | Excavación de cimentación | 30d | 2023-09-18 | 2023-10-17 | 603 | 0d |  |
| 605 | 9.2.1.4 | Perfilado y conformación de Plataforma de fundación | 27d | 2023-09-26 | 2023-10-22 | 604FS-22d | 0d |  |
| 606 | 9.2.1.5 | Excavación de uña | 26d | 2023-10-18 | 2023-11-12 | 604 | 0d |  |
| 607 | 9.2.1.6 | Conformación de material excedente en DME | 70d | 2023-09-07 | 2023-11-15 | 626FS-70d, 627FS-70d | 198d |  |
| 608 | 9.2.1.7 | Conformación de material excedente en DMO | 14d | 2023-08-31 | 2023-09-13 | 624FS-7d, 625FS-7d | 261d |  |
| 609 | 9.2.1.8 | Excavación Localizada - Sobreexcavación | 3d | 2023-11-13 | 2023-11-15 | 606 | 0d |  |
| 610 | 9.2.2 | **Rellenos** | 198d | 2023-10-01 | 2024-04-15 |  | 0d |  |
| 611 | 9.2.2.1 | Relleno con material granular (incluye extracción de material, zarandeo y combinac | 35d | 2023-10-01 | 2023-11-04 | 605FS-22d | 0d |  |
| 612 | 9.2.2.2 | Relleno sin compactar | 24d | 2024-03-13 | 2024-04-05 | 621 | 46d | 0d |
| 613 | 9.2.2.3 | Relleno afirmado | 10d | 2024-04-06 | 2024-04-15 | 612 | 46d | 0d |
| 614 | 9.2.2.4 | Perfilado de Talud del dique | 16d | 2023-10-22 | 2023-11-06 | 611FS-14d | 0d |  |
| 615 | 9.2.2.5 | Relleno con material seleccionado (incluye extracción de material, zarandeo y combinación de material) en sobreexcavación | 51d | 2023-11-05 | 2023-12-25 | 611 | 158d |  |

| ID | WBS | Task | Duration | Start | Finish | Predecessors | Total slack | Free slack |
| --- | --- | --- | --- | --- | --- | --- | --- | --- |
| 616 | 9.2.3 | **Geotextil** | 43d | 2023-10-23 | 2023-12-04 |  | 0d |  |
| 617 | 9.2.3.1 | Instalación de Geotextil 400 gr/m2 | 42d | 2023-10-24 | 2023-12-04 | 618FS-41d | 0d |  |
| 618 | 9.2.3.2 | Zanja de anclaje | 42d | 2023-10-23 | 2023-12-03 | 614FS-15d | 0d |  |
| 619 | 9.2.4 | **Colocación de roca** | 177d | 2023-09-18 | 2024-03-12 |  | 37d |  |
| 620 | 9.2.4.1 | Colocación de roca en uña | 112d | 2023-10-25 | 2024-02-13 | 584, 617FS-41d, 709 | 0d |  |
| 621 | 9.2.4.2 | Colocación de roca en Talud | 113d | 2023-11-21 | 2024-03-12 | 585 | 0d |  |
| 622 | 9.2.4.3 | Extracción y Selección de Rocas Reutilizables (50% de roca utilizable) | 53d | 2023-09-18 | 2023-11-09 | 603 | 204d |  |
| 623 | 9.2.5 | **Transportes** | 229d | 2023-08-31 | 2024-04-15 |  | 46d |  |
| 624 | 9.2.5.1 | Transporte de material orgánico (a DMO) D<=1km | 7d | 2023-08-31 | 2023-09-06 | 602SS | 261d | 0d |
| 625 | 9.2.5.2 | Transporte de material orgánico (a DMO) D>1km | 7d | 2023-08-31 | 2023-09-06 | 602SS | 261d | 0d |
| 626 | 9.2.5.3 | Transporte de material excedente (dique provisional) D<=1km | 70d | 2023-09-07 | 2023-11-15 | 603SS, 609FF | 198d | 0d |
| 627 | 9.2.5.4 | Transporte de material excedente (dique provisional) D> 1km | 70d | 2023-09-07 | 2023-11-15 | 603SS, 609FF | 198d | 0d |
| 628 | 9.2.5.5 | Transporte de material de préstamo (afirmado) D<=1km | 10d | 2024-04-06 | 2024-04-15 | 613SS | 46d |  |
| 629 | 9.2.5.6 | Transporte de material de préstamo (afirmado) D>1km | 10d | 2024-04-06 | 2024-04-15 | 613SS | 46d |  |
| 630 | 9.2.5.7 | Transporte de roca D<=1km | 140d | 2023-10-25 | 2024-03-12 | 620SS, 621FF | 80d |  |
| 631 | 9.2.5.8 | Transporte de roca D>1km | 140d | 2023-10-25 | 2024-03-12 | 620SS, 621FF | 80d |  |
| 632 | 9.2.5.9 | Transporte de material de préstamo cantera de rio (cuerpo de terraplén) D<=1km | 35d | 2023-10-01 | 2023-11-04 | 611SS | 209d |  |
| 633 | 9.2.5.10 | Transporte de material de préstamo cantera de rio (cuerpo de terraplén) D>1km | 35d | 2023-10-01 | 2023-11-04 | 611SS | 209d |  |
| 634 | 9.2.5.11 | Transporte de material seleccionado para zanja D<= 1km | 42d | 2023-10-23 | 2023-12-03 | 618SS | 180d |  |
| 635 | 9.2.5.12 | Transporte de material seleccionado para zanja D> 1km | 42d | 2023-10-23 | 2023-12-03 | 618SS | 180d |  |
| 636 | 9.3 | **DIQUE DI-PR-19A-1-D (PAQUETE 3)** | 201d | 2023-11-13 | 2024-05-31 |  | 0d |  |
| 637 | 9.3.1 | **Excavaciones** | 35d | 2023-11-13 | 2023-12-17 |  | 0d |  |
| 638 | 9.3.1.1 | Desbroce | 3d | 2023-11-13 | 2023-11-15 | 602FS+67d | 0d |  |
| 639 | 9.3.1.2 | Excavación de cimentación | 13d | 2023-11-16 | 2023-11-28 | 609, 638 | 0d |  |
| 640 | 9.3.1.3 | Perfilado y conformación de Plataforma de fundación | 10d | 2023-11-29 | 2023-12-08 | 639 | 0d |  |
| 641 | 9.3.1.4 | Excavación de uña | 16d | 2023-11-29 | 2023-12-14 | 639 | 166d | 0d |
| 642 | 9.3.1.5 | Excavación Localizada - Sobreexcavación | 3d | 2023-12-15 | 2023-12-17 | 641 | 166d | 0d |

| ID | WBS | Task | Duration | Start | Finish | Predecessors | Total slack |
| --- | --- | --- | --- | --- | --- | --- | --- |
| 643 | 9.3.2 | **Rellenos** | 175d | 2023-12-09 | 2024-05-31 |  | 0d |
| 644 | 9.3.2.1 | Relleno con material granular (incluye extracción de material, zarandeo y combinac | 35d | 2023-12-09 | 2024-01-12 | 640 | 0d |
| 645 | 9.3.2.2 | Relleno sin compactar | 9d | 2024-05-20 | 2024-05-28 | 654 | 0d |
| 646 | 9.3.2.3 | Relleno afirmado | 3d | 2024-05-29 | 2024-05-31 | 645 | 0d |
| 647 | 9.3.2.4 | Perfilado de Talud del dique | 9d | 2024-01-13 | 2024-01-21 | 644 | 0d |
| 648 | 9.3.2.5 | Relleno con material seleccionado (incluye extracción de material, zarandeo y combinación de material) en sobreexcavación | 48d | 2024-01-13 | 2024-02-29 | 644 | 92d |
| 649 | 9.3.3 | **Geotextil** | 31d | 2024-01-22 | 2024-02-21 |  | 0d |
| 650 | 9.3.3.1 | Instalación de Geotextil 400 gr/m2 | 30d | 2024-01-23 | 2024-02-21 | 651FS-29d | 0d |
| 651 | 9.3.3.2 | Zanja de anclaje | 30d | 2024-01-22 | 2024-02-20 | 647 | 0d |
| 652 | 9.3.4 | **Colocación de roca** | 96d | 2024-02-14 | 2024-05-19 |  | 0d |
| 653 | 9.3.4.1 | Colocación de roca en uña | 72d | 2024-02-14 | 2024-04-25 | 620, 650FS-8d, 735 | 0d |
| 654 | 9.3.4.2 | Colocación de roca en Talud | 68d | 2024-03-13 | 2024-05-19 | 621, 653FS-44d | 0d |
| 655 | 9.3.5 | **Transportes** | 201d | 2023-11-13 | 2024-05-31 |  | 0d |
| 656 | 9.3.5.1 | Transporte de material orgánico (a DMO) D<=1km | 3d | 2023-11-13 | 2023-11-15 | 638SS | 198d |
| 657 | 9.3.5.2 | Transporte de material orgánico (a DMO) D>1km | 3d | 2023-11-13 | 2023-11-15 | 638SS | 198d |
| 658 | 9.3.5.3 | Transporte de material excedente (dique provisional) D<=1km | 32d | 2023-11-16 | 2023-12-17 | 639SS, 642FF | 166d |
| 659 | 9.3.5.4 | Transporte de material excedente (dique provisional) D> 1km | 32d | 2023-11-16 | 2023-12-17 | 639SS, 642FF | 166d |
| 660 | 9.3.5.5 | Transporte de material de préstamo (afirmado) D<=1km | 3d | 2024-05-29 | 2024-05-31 | 646SS | 0d |
| 661 | 9.3.5.6 | Transporte de material de préstamo (afirmado) D>1km | 3d | 2024-05-29 | 2024-05-31 | 646SS | 0d |
| 662 | 9.3.5.7 | Transporte de roca D<=1km | 96d | 2024-02-14 | 2024-05-19 | 653SS, 654FF | 12d |
| 663 | 9.3.5.8 | Transporte de roca D>1km | 96d | 2024-02-14 | 2024-05-19 | 653SS, 654FF | 12d |
| 664 | 9.3.5.9 | Transporte de material de préstamo cantera de rio (cuerpo de terraplén) D<=1km | 35d | 2023-12-09 | 2024-01-12 | 644SS | 140d |
| 665 | 9.3.5.10 | Transporte de material de préstamo cantera de rio (cuerpo de terraplén) D>1km | 35d | 2023-12-09 | 2024-01-12 | 644SS | 140d |
| 666 | 9.3.5.11 | Transporte de material seleccionado para zanja D<= 1km | 30d | 2024-01-22 | 2024-02-20 | 651SS | 101d |
| 667 | 9.3.5.12 | Transporte de material seleccionado para zanja D> 1km | 30d | 2024-01-22 | 2024-02-20 | 651SS | 101d |

| ID | WBS | Task | Duration | Start | Finish | Predecessors | Total slack | Free slack |
| --- | --- | --- | --- | --- | --- | --- | --- | --- |
| 668 | 9.4 | **Obras Civiles DI-PR-19A-3-D (PAQUETE 3)** | 45d | 2023-07-03 | 2023-08-16 |  | 0d |  |
| 669 | 9.4.1 | Trazo y replanteo de interferencia | 30d | 2023-07-03 | 2023-08-01 | 4 | 304d |  |
| 670 | 9.4.2 | Desvío provisional en tierras | 14d | 2023-07-06 | 2023-07-19 | 671 | 0d |  |
| 671 | 9.4.3 | Limpieza de terreno manual | 3d | 2023-07-03 | 2023-07-05 | 4 | 0d |  |
| 672 | 9.4.4 | Excavacion no clasificada de zanja | 19d | 2023-07-20 | 2023-08-07 | 670 | 0d |  |
| 673 | 9.4.5 | Relleno estructural | 3d | 2023-08-08 | 2023-08-10 | 672 | 0d |  |
| 674 | 9.4.6 | Emboquillado de piedra e=0.20m | 4d | 2023-08-11 | 2023-08-14 | 673 | 0d |  |
| 675 | 9.4.7 | Sello en juntas | 2d | 2023-08-15 | 2023-08-16 | 674 | 0d |  |
| 676 | 9.5 | **Obras Civiles DI-PR-19A-2-D (PAQUETE 3)** | 114d | 2023-07-03 | 2023-10-24 |  | 0d |  |
| 677 | 9.5.1 | Trazo y replanteo de interferencia | 48d | 2023-07-03 | 2023-08-19 | 4 | 122d | 0d |
| 678 | 9.5.2 | Desvío provisional con tubería | 9d | 2023-07-07 | 2023-07-15 | 680 | 0d |  |
| 679 | 9.5.3 | Desvío provisional en tierras | 9d | 2023-07-16 | 2023-07-24 | 678 | 0d |  |
| 680 | 9.5.4 | Limpieza de terreno manual | 4d | 2023-07-03 | 2023-07-06 | 4 | 0d |  |
| 681 | 9.5.5 | Excavaciones no clasificada para estructuras | 4d | 2023-07-25 | 2023-07-28 | 679 | 0d |  |
| 682 | 9.5.6 | Excavacion no clasificada de zanja | 11d | 2023-07-29 | 2023-08-08 | 681 | 0d |  |
| 683 | 9.5.7 | Relleno estructural | 14d | 2023-08-25 | 2023-09-07 | 685 | 0d |  |
| 684 | 9.5.8 | Suministro de roca (Alcantarillas) | 11d | 2023-08-09 | 2023-08-19 | 682 | 0d |  |
| 685 | 9.5.9 | Colocación de roca en uña (Alcantarillas) | 5d | 2023-08-20 | 2023-08-24 | 684 | 0d |  |
| 686 | 9.5.10 | Concreto de Nivelacion (f'c=100 kg/cm2) | 4d | 2023-09-08 | 2023-09-11 | 683 | 0d |  |
| 687 | 9.5.11 | Concreto Clase C (f'c=280 kg/cm2) Premezclado - Cimientos reforzados | 5d | 2023-09-12 | 2023-09-16 | 686, 690FS-3d, 691FS-10d | 0d |  |
| 688 | 9.5.12 | Concreto Clase C (f'c=280 kg/cm2) Premezclado - Muros de contencion | 9d | 2023-09-17 | 2023-09-25 | 687, 689FS-4d | 0d |  |
| 689 | 9.5.13 | Encofrado y Desencofrado Caravista | 6d | 2023-09-15 | 2023-09-20 | 690 | 0d |  |
| 690 | 9.5.14 | Encofrado y Desencofrado Cara Oculta | 7d | 2023-09-08 | 2023-09-14 | 683 | 0d |  |
| 691 | 9.5.15 | Acero de refuerzo f'y=4200kg/cm2 | 14d | 2023-09-08 | 2023-09-21 | 683 | 0d |  |
| 692 | 9.5.16 | Emboquillado de piedra e=0.20m | 9d | 2023-09-26 | 2023-10-04 | 688 | 224d | 0d |
| 693 | 9.5.17 | Emboquillado de piedra e=0.30m | 9d | 2023-10-05 | 2023-10-13 | 692 | 224d | 0d |
| 694 | 9.5.18 | Emboquillado de piedra e=0.50m | 7d | 2023-10-14 | 2023-10-20 | 693 | 224d |  |
| 695 | 9.5.19 | Cama de arena e=0.20m | 6d | 2023-08-09 | 2023-08-14 | 682 | 268d | 0d |
| 696 | 9.5.20 | Tubería HDPE Corrugada Ø=600mm (Suministro e instalación) | 2d | 2023-08-15 | 2023-08-16 | 695 | 268d | 0d |
| 697 | 9.5.21 | Tubería HDPE Corrugada Ø=900mm (Suministro e instalación) | 2d | 2023-08-17 | 2023-08-18 | 696 | 268d | 0d |
| 698 | 9.5.22 | Tubería HDPE Corrugada Ø=1200mm (Suministro e instalación) | 2d | 2023-08-19 | 2023-08-20 | 697 | 268d | 38d |
| 699 | 9.5.23 | Compuertas Charnela Ø900 (Suministro e instalacion) | 2d | 2023-09-28 | 2023-09-29 | 702, 698 | 230d | 0d |
| 700 | 9.5.24 | Compuertas Charnela Ø1200 (Suministro e instalacion) | 4d | 2023-09-30 | 2023-10-03 | 699 | 230d | 0d |
| 701 | 9.5.25 | Sello en juntas | 2d | 2023-10-04 | 2023-10-05 | 700 | 230d | 0d |
| 702 | 9.5.26 | Waterstop (anillos de estanqueidad) | 2d | 2023-09-26 | 2023-09-27 | 688 | 230d | 0d |
| 703 | 9.5.27 | Pintura bituminosa | 9d | 2023-10-06 | 2023-10-14 | 701 | 230d |  |
| 704 | 9.5.28 | Relleno con material granular (incluye extracción de material, zarandeo y combinac | 13d | 2023-09-27 | 2023-10-09 | 688FS+1d | 0d |  |
| 705 | 9.5.29 | Concreto clase D (fc=210 kg/cm2) premezclado-cimientos reforzados | 2d | 2023-10-10 | 2023-10-11 | 704 | 0d |  |
| 706 | 9.5.30 | Baranda metálica en acero ø 1 1/2" h=1.00m | 2d | 2023-10-12 | 2023-10-13 | 705 | 0d |  |
| 707 | 9.5.31 | Rejilla metálica 1.80mx(2.39m-2.70m) (suministro e instalacion) | 3d | 2023-10-14 | 2023-10-16 | 706 | 0d |  |
| 708 | 9.5.32 | Compuerta plana mural 1.10mx1.10m (suministro e instalacion) | 5d | 2023-10-17 | 2023-10-21 | 707 | 0d |  |
| 709 | 9.5.33 | Compuerta metálica tipo tarjeta 600x600 mm (suministro e instalacion) | 3d | 2023-10-22 | 2023-10-24 | 708 | 0d |  |

| ID | WBS | Task | Duration | Start | Finish | Predecessors | Total slack | Free slack |
| --- | --- | --- | --- | --- | --- | --- | --- | --- |
| 710 | 9.6 | **Obras Civiles DI-PR-19A-1-D (PAQUETE 3)** | 56d | 2023-08-20 | 2023-10-14 |  | 122d |  |
| 711 | 9.6.1 | Trazo y replanteo de interferencia | 12d | 2023-08-20 | 2023-08-31 | 677 | 274d |  |
| 712 | 9.6.2 | Desvío provisional con tubería | 9d | 2023-08-22 | 2023-08-30 | 714 | 122d | 0d |
| 713 | 9.6.3 | Desvío provisional en tierras | 5d | 2023-08-31 | 2023-09-04 | 712 | 122d | 0d |
| 714 | 9.6.4 | Limpieza de terreno manual | 2d | 2023-08-20 | 2023-08-21 | 677 | 122d | 0d |
| 715 | 9.6.5 | Excavaciones no clasificada para estructuras | 2d | 2023-09-05 | 2023-09-06 | 713 | 122d | 0d |
| 716 | 9.6.6 | Excavacion no clasificada de zanja | 3d | 2023-09-07 | 2023-09-09 | 715 | 122d | 0d |
| 717 | 9.6.7 | Relleno estructural | 6d | 2023-09-16 | 2023-09-21 | 719 | 122d | 0d |
| 718 | 9.6.8 | Suministro de roca (Alcantarillas) | 4d | 2023-09-10 | 2023-09-13 | 716 | 122d | 0d |
| 719 | 9.6.9 | Colocación de roca en uña (Alcantarillas) | 2d | 2023-09-14 | 2023-09-15 | 718 | 122d | 0d |
| 720 | 9.6.10 | Concreto de Nivelacion (f'c=100 kg/cm2) | 3d | 2023-09-22 | 2023-09-24 | 717 | 122d | 0d |
| 721 | 9.6.11 | Concreto Clase C (f'c=280 kg/cm2) Premezclado - Cimientos reforzados | 3d | 2023-09-25 | 2023-09-27 | 720, 724FS-2d, 725FS-6d | 122d | 0d |
| 722 | 9.6.12 | Concreto Clase C (f'c=280 kg/cm2) Premezclado - Muros de contencion | 4d | 2023-09-28 | 2023-10-01 | 721, 723FS-3d | 122d | 0d |
| 723 | 9.6.13 | Encofrado y Desencofrado Caravista | 4d | 2023-09-27 | 2023-09-30 | 724 | 122d | 0d |
| 724 | 9.6.14 | Encofrado y Desencofrado Cara Oculta | 5d | 2023-09-22 | 2023-09-26 | 717 | 122d | 0d |
| 725 | 9.6.15 | Acero de refuerzo f'y=4200kg/cm2 | 9d | 2023-09-22 | 2023-09-30 | 717 | 122d | 0d |
| 726 | 9.6.16 | Emboquillado de piedra e=0.20m | 3d | 2023-10-02 | 2023-10-04 | 722 | 235d | 0d |
| 727 | 9.6.17 | Emboquillado de piedra e=0.30m | 3d | 2023-10-05 | 2023-10-07 | 726 | 235d | 0d |
| 728 | 9.6.18 | Emboquillado de piedra e=0.50m | 2d | 2023-10-08 | 2023-10-09 | 727 | 235d |  |
| 729 | 9.6.19 | Cama de arena e=0.20m | 2d | 2023-09-10 | 2023-09-11 | 716 | 142d | 0d |
| 730 | 9.6.20 | Tubería HDPE Corrugada Ø=1200mm (Suministro e instalación) | 2d | 2023-09-12 | 2023-09-13 | 729 | 142d | 20d |
| 731 | 9.6.21 | Compuertas Charnela Ø1200 (Suministro e instalacion) | 2d | 2023-10-04 | 2023-10-05 | 733, 730 | 122d | 0d |
| 732 | 9.6.22 | Sello en juntas | 2d | 2023-10-06 | 2023-10-07 | 731 | 122d | 0d |
| 733 | 9.6.23 | Waterstop (anillos de estanqueidad) | 2d | 2023-10-02 | 2023-10-03 | 722 | 122d | 0d |
| 734 | 9.6.24 | Pintura bituminosa | 4d | 2023-10-08 | 2023-10-11 | 732 | 122d | 0d |
| 735 | 9.6.25 | Compuerta plana tipo tarjeta 0.60mx0.30m(suministro e instalación) | 3d | 2023-10-12 | 2023-10-14 | 734 | 122d |  |

| ID | WBS | Task | Type | Duration | Start | Finish | Predecessors | Total slack | Free slack |
| --- | --- | --- | --- | --- | --- | --- | --- | --- | --- |
| 736 | 10 | **Obras Civiles Botadero** |  | 45d | 2023-04-02 | 2023-05-16 |  | 381d |  |
| 737 | 10.1 | Remoción de residuos solidos |  | 45d | 2023-04-02 | 2023-05-16 | 3 | 381d |  |
| 738 | 11 | **Accesos DI-PR-13-D (PAQUETE 2)** |  | 12d | 2023-04-16 | 2023-04-27 |  | 0d |  |
| 739 | 11.1 | **Superficie de rodadura** |  | 12d | 2023-04-16 | 2023-04-27 |  | 0d |  |
| 740 | 11.1.1 | Concreto clase C (f'c=280 kg/cm2) en losa |  | 4d | 2023-04-22 | 2023-04-25 | 741, 743 | 0d |  |
| 741 | 11.1.2 | Encofrado y desencofrado pavimento rígido e=0.15m |  | 6d | 2023-04-16 | 2023-04-21 | 3FS+14d | 0d |  |
| 742 | 11.1.3 | Junta en Pavimentos con Pasadores |  | 2d | 2023-04-26 | 2023-04-27 | 740 | 0d |  |
| 743 | 11.1.4 | Concreto Ciclopeo f'c=210 kg/cm2 + 30% PM |  | 2d | 2023-04-20 | 2023-04-21 | 3FS+18d | 0d |  |
| 744 | 12 | **Accesos DI-PR-12-I (PAQUETE 2)** |  | 18d | 2023-04-04 | 2023-04-21 |  | 7d |  |
| 745 | 12.1 | **Superficie de rodadura** |  | 18d | 2023-04-04 | 2023-04-21 |  | 7d |  |
| 746 | 12.1.1 | Concreto clase C (f'c=280 kg/cm2) en losa |  | 6d | 2023-04-13 | 2023-04-18 | 747, 749 | 7d | 0d |
| 747 | 12.1.2 | Encofrado y desencofrado pavimento rígido e=0.15m |  | 9d | 2023-04-04 | 2023-04-12 | 3FS+2d | 7d | 0d |
| 748 | 12.1.3 | Junta en Pavimentos con Pasadores |  | 3d | 2023-04-19 | 2023-04-21 | 746 | 7d | 0d |
| 749 | 12.1.4 | Concreto Ciclopeo f'c=210 kg/cm2 + 30% PM |  | 2d | 2023-04-11 | 2023-04-12 | 3FS+9d | 7d | 0d |
| 750 | 13 | **Accesos DI-PR-19A-D (PAQUETE 3)** |  | 14d | 2023-07-03 | 2023-07-16 |  | 320d |  |
| 751 | 13.1 | **Superficie de rodadura** |  | 14d | 2023-07-03 | 2023-07-16 |  | 320d |  |
| 752 | 13.1.1 | Concreto clase C (f'c=280 kg/cm2) en losa |  | 5d | 2023-07-10 | 2023-07-14 | 753, 755 | 320d | 0d |
| 753 | 13.1.2 | Encofrado y desencofrado pavimento rígido e=0.15m |  | 7d | 2023-07-03 | 2023-07-09 | 4 | 320d | 0d |
| 754 | 13.1.3 | Junta en Pavimentos con Pasadores |  | 2d | 2023-07-15 | 2023-07-16 | 752 | 320d |  |
| 755 | 13.1.4 | Concreto Ciclopeo f'c=210 kg/cm2 + 30% PM |  | 2d | 2023-07-03 | 2023-07-04 | 4 | 325d | 5d |
| 756 | 14 | **Accesos DI-PR-19B-D (PAQUETE 3)** |  | 10d | 2023-06-23 | 2023-07-02 |  | 0d |  |
| 757 | 14.1 | **Superficie de rodadura** |  | 10d | 2023-06-23 | 2023-07-02 |  | 0d |  |
| 758 | 14.1.1 | Concreto clase C (f'c=280 kg/cm2) en losa |  | 3d | 2023-06-28 | 2023-06-30 | 759, 761 | 0d |  |
| 759 | 14.1.2 | Encofrado y desencofrado pavimento rígido e=0.15m |  | 5d | 2023-06-23 | 2023-06-27 | 4FS-10d | 0d |  |
| 760 | 14.1.3 | Junta en Pavimentos con Pasadores |  | 2d | 2023-07-01 | 2023-07-02 | 758 | 0d |  |
| 761 | 14.1.4 | Concreto Ciclopeo f'c=210 kg/cm2 + 30% PM |  | 2d | 2023-06-26 | 2023-06-27 | 4FS-7d | 0d |  |
| 762 | 15 | Hito: Fin de proyecto | milestone | 0d | 2024-05-31 | 2024-05-31 | 7, 11 | 0d |  |
